# Projet X

How a schedule from MS Project changed from version to version. A marks actual dates.

## Version 1 (saved 2008-06-17, file 20-Planning détaillé pour fiche 24-Polo.mpp)

| ID | WBS | Task | Duration | Start | Finish | Predecessors | Total float |
| --- | --- | --- | --- | --- | --- | --- | --- |
| 1 |  | Début du projet | 0d | 2008-04-17 | 2008-04-17 |  | 67.35d |
| 2 | 2 | **GESTION DU PROJET** | 7.35d | 2008-04-17 | 2008-04-29 |  | 0d |
| 3 | 2.1 | **Initialiser le projet** | 1.75d | 2008-04-17 | 2008-04-18 |  | 0d |
| 4 | 2.1.1 | **Réception** | 0.5d | 2008-04-17 | 2008-04-17 |  | 0d |
| 5 |  | Réceptionner la demande de projet du commanditaire | 0.25d | 2008-04-17 | 2008-04-17 |  | 0d |
| 6 |  | Demande de projet du commanditaire | 0d | 2008-04-17 | 2008-04-17 | 5 | 0d |
| 7 |  | Examiner la demande du commanditaire | 0.25d | 2008-04-17 | 2008-04-17 | 6 | 0d |
| 8 |  | Réponse à la demande de projet | 0d | 2008-04-17 | 2008-04-17 | 7 | 66.85d |
| 9 | 2.1.2 | **Affectation** | 1.25d | 2008-04-17 | 2008-04-18 |  | 0d |
| 10 |  | Officialiser la nomination du chef de projet | 0.25d | 2008-04-17 | 2008-04-17 | 7 | 0d |
| 11 |  | Note d’affectation du chef de projet | 0d | 2008-04-18 | 2008-04-18 | 10FS+1d | 0d |
| 12 | 2.2 | **Préparer le projet** | 4d | 2008-04-21 | 2008-04-25 |  | 0d |
| 13 | 2.2.1 | **Objet** | 0.25d | 2008-04-21 | 2008-04-21 |  | 0d |
| 14 |  | Définir l’objet précis du projet | 0.25d | 2008-04-21 | 2008-04-21 | 11 | 65.35d |
| 15 |  | Note de cadrage | 0d | 2008-04-21 | 2008-04-21 | 14 | 65.35d |
| 16 |  | Lister les motifs et définir le contexte | 0.25d | 2008-04-21 | 2008-04-21 | 11 | 0d |
| 17 |  | Note de cadrage (suite) | 0d | 2008-04-21 | 2008-04-21 | 16 | 0d |
| 18 | 2.2.2 | **Objectifs** | 0.75d | 2008-04-22 | 2008-04-23 |  | 0d |
| 19 |  | Définir les objectifs de qualité | 0.25d | 2008-04-22 | 2008-04-22 | 17FS+1d | 64.1d |
| 20 |  | Note de cadrage (suite) | 0d | 2008-04-22 | 2008-04-22 | 19 | 64.1d |
| 21 |  | Définir les objectifs de temps | 0.25d | 2008-04-22 | 2008-04-22 | 17FS+1d | 64.1d |
| 22 |  | macro-planning | 0d | 2008-04-22 | 2008-04-22 | 21 | 64.1d |
| 23 |  | Définir les objectifs de charge et de coûts | 0.25d | 2008-04-22 | 2008-04-22 | 17FS+1d | 63.85d |
| 24 |  | macro-planning de charge | 0d | 2008-04-22 | 2008-04-22 | 23 | 64.1d |
| 25 |  | Budget prévisionnel | 0d | 2008-04-22 | 2008-04-22 | 23 | 64.1d |
| 26 |  | Définir les objectifs de communication | 0.25d | 2008-04-22 | 2008-04-22 | 23 | 63.85d |
| 27 |  | Stratégie de communication | 0d | 2008-04-22 | 2008-04-22 | 26 | 63.85d |
| 28 |  | Définir les objectifs complémentaires | 0.25d | 2008-04-22 | 2008-04-22 | 17FS+1d | 0d |
| 29 |  | Note de cadrage (suite) | 0d | 2008-04-22 | 2008-04-22 | 28 | 0d |
| 30 |  | Préciser les contraintes sur objectifs | 0.25d | 2008-04-22 | 2008-04-22 | 29 | 0d |
| 31 |  | Note de cadrage (suite) | 0d | 2008-04-22 | 2008-04-22 | 30 | 0d |
| 32 |  | Vérifier l’adéquation entre les objectifs | 0.25d | 2008-04-23 | 2008-04-23 | 31 | 0d |
| 33 |  | Note de cadrage (suite) | 0d | 2008-04-23 | 2008-04-23 | 32 | 0d |
| 34 | 2.2.3 | **Domaine** | 1.25d | 2008-04-23 | 2008-04-24 |  | 0d |
| 35 |  | Identifier le périmètre et les acteurs | 1d | 2008-04-23 | 2008-04-24 | 33 | 0d |
| 36 |  | Fichier des acteurs | 0d | 2008-04-24 | 2008-04-24 | 35 | 62.6d |
| 37 |  | Définir la structure choisie pour la gestion du projet | 0.25d | 2008-04-24 | 2008-04-24 | 33, 35FF | 0d |
| 38 |  | Organigramme Projet | 0d | 2008-04-24 | 2008-04-24 | 37 | 0d |
| 39 |  | Définir les rôles des acteurs dans les structures projets | 0.25d | 2008-04-24 | 2008-04-24 | 38 | 0d |
| 40 |  | Fiche de poste | 0d | 2008-04-24 | 2008-04-24 | 39 | 62.35d |
| 41 |  | Carte des acteurs | 0d | 2008-04-24 | 2008-04-24 | 39 | 0d |
| 42 | 2.2.4 | **Risques** | 0.25d | 2008-04-24 | 2008-04-24 |  | 0d |
| 43 |  | Identifier, analyser et gérer les freins | 0.25d | 2008-04-24 | 2008-04-24 | 41 | 0d |
| 44 |  | Grille des freins | 0d | 2008-04-24 | 2008-04-24 | 43 | 0d |
| 45 |  | Identifier, analyser et gérer les facilitants | 0.25d | 2008-04-24 | 2008-04-24 | 41 | 62.1d |
| 46 |  | Grille des facilitants | 0d | 2008-04-24 | 2008-04-24 | 44 | 0d |
| 47 | 2.2.5 | **Méthode** | 0.25d | 2008-04-24 | 2008-04-24 |  | 62.1d |
| 48 |  | Choisir une méthode et structurer la réal. du produit | 0.25d | 2008-04-24 | 2008-04-24 | 41 | 62.1d |
| 49 |  | Fiche méthode | 0d | 2008-04-24 | 2008-04-24 | 48 | 62.1d |
| 50 | 2.2.6 | **Communication** | 0.25d | 2008-04-25 | 2008-04-25 |  | 0d |
| 51 |  | Définir les axes, cibles et moyens de communication | 0.25d | 2008-04-25 | 2008-04-25 | 46 | 0d |
| 52 |  | Charte graphique | 0d | 2008-04-25 | 2008-04-25 | 51 | 61.85d |
| 53 |  | Plan de communication | 0d | 2008-04-25 | 2008-04-25 | 51 | 0d |
| 54 | 2.2.7 | **Contractualisation** | 0.25d | 2008-04-25 | 2008-04-25 |  | 0d |
| 55 |  | Rédiger la note de cadrage | 0.25d | 2008-04-25 | 2008-04-25 | 53 | 0d |
| 56 |  | Note de cadrage (suite) | 0d | 2008-04-25 | 2008-04-25 | 55 | 0d |
| 57 | 2.3 | **Planifier le projet** | 1.1d | 2008-04-25 | 2008-04-28 |  | 0d |
| 58 | 2.3.1 | **Planification détallée** | 0.6d | 2008-04-25 | 2008-04-28 |  | 0d |
| 59 |  | Définir l’environnement de planification | 0.1d | 2008-04-25 | 2008-04-25 | 56 | 0d |
| 60 |  | Charte de planification | 0d | 2008-04-25 | 2008-04-25 | 59 | 0d |
| 61 |  | Ordonner la liste des tâches de fabrication du produit | 0.1d | 2008-04-25 | 2008-04-25 | 60 | 0d |
| 62 |  | Organigramme des tâches | 0d | 2008-04-25 | 2008-04-25 | 61 | 0d |
| 63 |  | Affecter des durées ou des charges aux tâches | 0.1d | 2008-04-25 | 2008-04-25 | 62 | 0d |
| 64 |  | Planning détaillé | 0d | 2008-04-25 | 2008-04-25 | 63 | 0d |
| 65 |  | Définir les liens entre les tâches | 0.1d | 2008-04-25 | 2008-04-28 | 64 | 0d |
| 66 |  | Planning détaillé (suite) | 0d | 2008-04-28 | 2008-04-28 | 65 | 0d |
| 67 |  | Intégrer les tâches de gestion de projet | 0.1d | 2008-04-28 | 2008-04-28 | 66 | 0d |
| 68 |  | Planning détaillé (suite) | 0d | 2008-04-28 | 2008-04-28 | 67 | 0d |
| 69 |  | Affecter les ressources sur les tâches | 0.1d | 2008-04-28 | 2008-04-28 | 68 | 0d |
| 70 |  | Tableau des ressources | 0d | 2008-04-28 | 2008-04-28 | 69 | 0d |

| ID | WBS | Task | Duration | Start | Finish | Predecessors | Total float |
| --- | --- | --- | --- | --- | --- | --- | --- |
| 71 |  | Planning détaillé (suite) | 0d | 2008-04-28 | 2008-04-28 | 70 | 0d |
| 72 | 2.3.2 | **Validation** | 0.5d | 2008-04-28 | 2008-04-28 |  | 0d |
| 73 |  | Optimiser le planning détaillé du prévu | 0.25d | 2008-04-28 | 2008-04-28 | 71 | 0d |
| 74 |  | Planning détaillé (suite) | 0d | 2008-04-28 | 2008-04-28 | 73 | 0d |
| 75 |  | Valider, communiquer et enregistrer le planning | 0.25d | 2008-04-28 | 2008-04-28 | 74 | 0d |
| 76 |  | Contrat de planning | 0d | 2008-04-28 | 2008-04-28 | 75 | 0d |
| 77 | 2.4 | **Piloter le projet** | 0.5d | 2008-04-28 | 2008-04-29 |  | 0d |
| 78 | 2.4.1 | **Lancement** | 0.5d | 2008-04-28 | 2008-04-29 |  | 0d |
| 79 |  | Lancer la réalisation | 0.25d | 2008-04-28 | 2008-04-29 | 76 | 0d |
| 80 |  | Journal du projet | 0d | 2008-04-29 | 2008-04-29 | 79 | 0d |
| 81 |  | Fiche de reporting | 0d | 2008-04-29 | 2008-04-29 | 80 | 0d |
| 82 |  | Mettre en œuvre le plan de communication | 0.25d | 2008-04-29 | 2008-04-29 | 81 | 0d |
| 83 |  | Plan de communication (suite) | 0d | 2008-04-29 | 2008-04-29 | 82 | 0d |
| 84 | 3 | **FABRICATION DU PRODUIT** | 56d | 2008-04-29 | 2008-07-28 |  | 0d |
| 85 | 3.1 | **Etude de la gestion des stocks** | 4d | 2008-04-29 | 2008-05-05 |  | 0d |
| 86 | 3.1.1 | **Etude opérationnelle** | 2d | 2008-04-29 | 2008-05-01 |  | 0d |
| 87 |  | Analyse de l'existant | 1d | 2008-04-29 | 2008-04-30 | 83 | 0d |
| 88 |  | Feuille d'analyse | 0d | 2008-04-30 | 2008-04-30 | 87 | 0d |
| 89 |  | Recherche des améliorations | 1d | 2008-04-30 | 2008-05-01 | 88 | 0d |
| 90 |  | Liste des améliorations | 0d | 2008-05-01 | 2008-05-01 | 89 | 0d |
| 91 | 3.1.2 | **Etude fonctionnelle** | 4d | 2008-04-29 | 2008-05-05 |  | 0d |
| 92 |  | Analyse de l'existant | 1d | 2008-04-29 | 2008-04-30 | 83 | 1d |
| 93 |  | Organigramme fonctionnel | 0d | 2008-05-01 | 2008-05-01 | 92, 90 | 0d |
| 94 |  | Rédaction du cahier des charges | 2d | 2008-05-01 | 2008-05-05 | 93 | 0d |
| 95 |  | Cahier des charges | 0d | 2008-05-05 | 2008-05-05 | 94 | 0d |
| 96 | 3.2 | **Mise en place de la gestion des stocks** | 30.5d | 2008-05-05 | 2008-06-23 |  | 25.5d |
| 97 | 3.2.1 | **Recherche progiciels** | 6d | 2008-05-05 | 2008-05-14 |  | 25.5d |
| 98 |  | Recherche des prestataires | 5d | 2008-05-05 | 2008-05-13 | 95 | 25.5d |
| 99 |  | Liste des prestataires | 0d | 2008-05-13 | 2008-05-13 | 98 | 25.5d |
| 100 |  | Présélection des progiciels | 1d | 2008-05-13 | 2008-05-14 | 99 | 25.5d |
| 101 |  | Liste des logiciels | 0d | 2008-05-14 | 2008-05-14 | 100 | 25.5d |
| 102 | 3.2.2 | **Choix progiciels** | 2d | 2008-05-14 | 2008-05-19 |  | 25.5d |
| 103 |  | Réalisation d'un dossier de choix | 1d | 2008-05-14 | 2008-05-15 | 101 | 25.5d |
| 104 |  | Choix du progiciel | 0.5d | 2008-05-15 | 2008-05-16 | 103 | 25.5d |
| 105 |  | Dossier de choix | 0d | 2008-05-16 | 2008-05-16 | 104 | 25.5d |
| 106 |  | Passage de la commande | 0.5d | 2008-05-16 | 2008-05-19 | 105 | 48d |
| 107 |  | Bon de commande | 0d | 2008-05-19 | 2008-05-19 | 106 | 48d |
| 108 | 3.2.3 | **Mise en place** | 4d | 2008-05-16 | 2008-05-23 |  | 44.5d |
| 109 |  | Commande des matériels | 0.5d | 2008-05-16 | 2008-05-19 | 105 | 44.5d |
| 110 |  | Bon de commande | 0d | 2008-05-19 | 2008-05-19 | 109 | 44.5d |
| 111 |  | Vérification des matériels | 1d | 2008-05-19 | 2008-05-20 | 110 | 44.5d |
| 112 |  | PV de réception | 0d | 2008-05-20 | 2008-05-20 | 111 | 44.5d |
| 113 |  | Installation des matériels | 1d | 2008-05-20 | 2008-05-21 | 112 | 44.5d |
| 114 |  | Installation du réseau | 1d | 2008-05-20 | 2008-05-21 | 112 | 44.5d |
| 115 |  | Partie matérielle installée | 0d | 2008-05-21 | 2008-05-21 | 114, 113 | 44.5d |
| 116 |  | Installation des systèmes d'exploitation | 1d | 2008-05-21 | 2008-05-22 | 115 | 44.5d |
| 117 |  | Installation du progiciel de gestion des stocks | 0.5d | 2008-05-22 | 2008-05-23 | 116 | 44.5d |
| 118 |  | Partie logicielle installée | 0d | 2008-05-23 | 2008-05-23 | 117 | 44.5d |
| 119 | 3.2.4 | **Paramétrage** | 7d | 2008-05-16 | 2008-05-28 |  | 25.5d |
| 120 |  | Définition des paramètres | 2d | 2008-05-16 | 2008-05-20 | 105 | 25.5d |
| 121 |  | Paramétrage du logiciel | 5d | 2008-05-20 | 2008-05-28 | 120 | 25.5d |
| 122 |  | Logiciel paramétré | 0d | 2008-05-28 | 2008-05-28 | 121 | 41.5d |
| 123 | 3.2.5 | **Tests** | 12d | 2008-05-16 | 2008-06-05 |  | 25.5d |
| 124 |  | Définition des données de test | 1d | 2008-05-16 | 2008-05-19 | 105 | 31.5d |
| 125 |  | Tests du logiciel | 5d | 2008-05-28 | 2008-06-05 | 121, 124 | 25.5d |
| 126 |  | Logiciel testé | 0d | 2008-06-05 | 2008-06-05 | 125 | 25.5d |
| 127 | 3.2.6 | **Recette** | 6d | 2008-06-05 | 2008-06-16 |  | 25.5d |
| 128 |  | Effectuer la recette | 1d | 2008-06-05 | 2008-06-06 | 126 | 25.5d |
| 129 |  | PV de recette | 0d | 2008-06-06 | 2008-06-06 | 128 | 25.5d |
| 130 |  | Mettre en production | 5d | 2008-06-06 | 2008-06-16 | 129 | 25.5d |
| 131 |  | Logiciel opérationnel | 0d | 2008-06-16 | 2008-06-16 | 130 | 25.5d |
| 132 | 3.2.7 | **Formation** | 5d | 2008-06-16 | 2008-06-23 |  | 25.5d |
| 133 |  | Former les utilisateurs | 5d | 2008-06-16 | 2008-06-23 | 131 | 25.5d |
| 134 |  | Utilisateurs formés | 0d | 2008-06-23 | 2008-06-23 | 133 | 25.5d |
| 135 | 3.3 | **Etude du site internet** | 11d | 2008-05-05 | 2008-05-22 |  | 0d |
| 136 | 3.3.1 | **Définition fonctions** | 5d | 2008-05-05 | 2008-05-13 |  | 0d |
| 137 |  | Définir les fonctions | 3d | 2008-05-05 | 2008-05-09 | 95 | 0d |
| 138 |  | Rédiger le cahier des charges | 2d | 2008-05-09 | 2008-05-13 | 137 | 0d |
| 139 |  | Cahier des charges | 0d | 2008-05-13 | 2008-05-13 | 138 | 0d |
| 140 | 3.3.2 | **Définition interfaces** | 6d | 2008-05-13 | 2008-05-22 |  | 0d |

| ID | WBS | Task | Duration | Start | Finish | Predecessors | Total float |
| --- | --- | --- | --- | --- | --- | --- | --- |
| 141 |  | Faire les maquettes | 5d | 2008-05-13 | 2008-05-21 | 139 | 0d |
| 142 |  | Valider les maquettes | 1d | 2008-05-21 | 2008-05-22 | 141 | 0d |
| 143 |  | Maquettes validées | 0d | 2008-05-22 | 2008-05-22 | 142 | 0d |
| 144 | 3.4 | **Mise en place du site** | 18d | 2008-05-22 | 2008-06-20 |  | 0d |
| 145 | 3.4.1 | **Développements** | 16d | 2008-05-22 | 2008-06-17 |  | 0d |
| 146 |  | Définir le nombre de prototypes | 1d | 2008-05-22 | 2008-05-23 | 143 | 0d |
| 147 |  | Réaliser le prototype (n fois) | 15d | 2008-05-23 | 2008-06-17 | 146 | 0d |
| 148 |  | Tester le prototype (n fois) | 15d | 2008-05-23 | 2008-06-17 | 146 | 0d |
| 149 |  | Définir les améliorations (n fois) | 15d | 2008-05-23 | 2008-06-17 | 146 | 0d |
| 150 |  | Prototypes (n) | 0d | 2008-06-17 | 2008-06-17 | 147, 148, 149 | 0d |
| 151 | 3.4.2 | **Installation** | 2d | 2008-06-17 | 2008-06-20 |  | 0d |
| 152 |  | Réaliser l'installation avec le prestataire d'accès | 2d | 2008-06-17 | 2008-06-20 | 150 | 0d |
| 153 |  | Accès internet | 0d | 2008-06-20 | 2008-06-20 | 152 | 0d |
| 154 | 3.5 | **Mise en production du site** | 23d | 2008-06-20 | 2008-07-28 |  | 0d |
| 155 | 3.5.1 | **Test finaux** | 10d | 2008-06-20 | 2008-07-07 |  | 0d |
| 156 |  | Faire les tests finaux | 10d | 2008-06-20 | 2008-07-07 | 153 | 0d |
| 157 | 3.5.2 | **Recette** | 3d | 2008-07-07 | 2008-07-10 |  | 0d |
| 158 |  | Effectuer la recette | 3d | 2008-07-07 | 2008-07-10 | 156 | 0d |
| 159 |  | PV de recette | 0d | 2008-07-10 | 2008-07-10 | 158 | 0d |
| 160 | 3.5.3 | **Formation** | 10d | 2008-07-10 | 2008-07-28 |  | 0d |
| 161 |  | Elaborer la doc utilisateurs | 5d | 2008-07-10 | 2008-07-18 | 159 | 0d |
| 162 |  | Doc utilisateurs | 0d | 2008-07-18 | 2008-07-18 | 161 | 0d |
| 163 |  | Former les utilisateurs | 5d | 2008-07-18 | 2008-07-28 | 162 | 0d |
| 164 |  | Utilisateurs formés | 0d | 2008-07-28 | 2008-07-28 | 163 | 0d |
| 165 | 4 | **GESTION DU PROJET** | 67.35d | 2008-04-17 | 2008-08-01 |  | 0d |
| 166 | 4.1 | **Piloter le projet** | 1d | 2008-04-17 | 2008-04-18 |  | 66.35d |
| 167 | 4.1.1 | **Réalisation** | 1d | 2008-04-17 | 2008-04-18 |  | 66.35d |
| 168 | 4.1.1.1 | **Piloter la réalisation du produit** | 1d | 2008-04-17 | 2008-04-18 |  | 66.35d |
| 169 |  | Faire les réunions de comité de pilotage | 1d | 2008-04-17 | 2008-04-18 |  | 66.35d |
| 170 |  | Rapport flash | 0d | 2008-04-17 | 2008-04-17 |  | 67.35d |
| 171 |  | Faire les réunion avec l'équipe projet | 1d | 2008-04-17 | 2008-04-18 |  | 66.35d |
| 172 |  | Vérifier le reporting | 1d | 2008-04-17 | 2008-04-18 |  | 66.35d |
| 173 |  | Fiche de reporting (suite) | 0d | 2008-04-17 | 2008-04-17 |  | 67.35d |
| 174 |  | Mettre à jour la planning | 1d | 2008-04-17 | 2008-04-18 |  | 66.35d |
| 175 |  | Planning détaillé (suite) | 0d | 2008-04-17 | 2008-04-17 |  | 67.35d |
| 176 |  | Mettre à jour la documentation | 1d | 2008-04-17 | 2008-04-18 |  | 66.35d |
| 177 |  | œuvre en œuvre la communication | 1d | 2008-04-17 | 2008-04-18 |  | 66.35d |
| 178 |  | Faire un bilan intermédiaire | 1d | 2008-04-17 | 2008-04-18 |  | 66.35d |
| 179 |  | Bilan intermédiaire | 0d | 2008-04-17 | 2008-04-17 |  | 67.35d |
| 180 | 4.2 | **Faire le bilan du projet** | 4d | 2008-07-28 | 2008-08-01 |  | 0d |
| 181 | 4.2.1 | **Promotion** | 1d | 2008-07-28 | 2008-07-29 |  | 0d |
| 182 |  | Vendre le projet | 1d | 2008-07-28 | 2008-07-29 | 164 | 0d |
| 183 |  | Présentation de projet | 0d | 2008-07-29 | 2008-07-29 | 182 | 0d |
| 184 | 4.2.2 | **Désengagement** | 1d | 2008-07-29 | 2008-07-30 |  | 0d |
| 185 |  | Mettre un terme à l'engagement contractuel | 1d | 2008-07-29 | 2008-07-30 | 183 | 0d |
| 186 |  | Note de désengagement | 0d | 2008-07-30 | 2008-07-30 | 185 | 0d |
| 187 | 4.2.3 | **Capitalisation** | 2d | 2008-07-30 | 2008-08-01 |  | 0d |
| 188 |  | Organiser les réunions de débriefing | 1d | 2008-07-30 | 2008-07-31 | 186 | 0d |
| 189 |  | Bilan final de projet | 0d | 2008-07-31 | 2008-07-31 | 188 | 0d |
| 190 |  | Archiver les dossiers du projet | 1d | 2008-07-31 | 2008-08-01 | 189 | 0d |
| 191 |  | Note d’archivage | 0d | 2008-08-01 | 2008-08-01 | 190 | 0d |
| 192 |  | Fin du projet | 0d | 2008-08-01 | 2008-08-01 | 191 | 0d |

## Version 2 (saved 2008-06-17, file 20-Planning détaillé pour fiche 25-Polo.mpp)

Last finish stays 2008-08-01.

Added:

| ID | Task | Duration | Start | Finish | Predecessors | Constraint |
| --- | --- | --- | --- | --- | --- | --- |
| 169 | **Reporting CAPS** | 66.53d | 2008-04-17 09:00 | 2008-08-01 09:15 |  |  |
| 170 | Reporting CAPS 1 | 15min | 2008-04-17 09:00 | 2008-04-17 09:15 |  | start no earlier than 2008-04-17 08:00 |
| 171 | Reporting CAPS 2 | 15min | 2008-04-18 09:00 | 2008-04-18 09:15 |  | start no earlier than 2008-04-18 08:00 |
| 172 | Reporting CAPS 3 | 15min | 2008-04-21 09:00 | 2008-04-21 09:15 |  | start no earlier than 2008-04-19 08:00 |
| 173 | Reporting CAPS 4 | 15min | 2008-04-21 09:00 | 2008-04-21 09:15 |  | start no earlier than 2008-04-20 08:00 |
| 174 | Reporting CAPS 5 | 15min | 2008-04-21 09:00 | 2008-04-21 09:15 |  | start no earlier than 2008-04-21 08:00 |
| 175 | Reporting CAPS 6 | 15min | 2008-04-22 09:00 | 2008-04-22 09:15 |  | start no earlier than 2008-04-22 08:00 |
| 176 | Reporting CAPS 7 | 15min | 2008-04-23 09:00 | 2008-04-23 09:15 |  | start no earlier than 2008-04-23 08:00 |
| 177 | Reporting CAPS 8 | 15min | 2008-04-24 09:00 | 2008-04-24 09:15 |  | start no earlier than 2008-04-24 08:00 |
| 178 | Reporting CAPS 9 | 15min | 2008-04-25 09:00 | 2008-04-25 09:15 |  | start no earlier than 2008-04-25 08:00 |
| 179 | Reporting CAPS 10 | 15min | 2008-04-28 09:00 | 2008-04-28 09:15 |  | start no earlier than 2008-04-26 08:00 |
| 180 | Reporting CAPS 11 | 15min | 2008-04-28 09:00 | 2008-04-28 09:15 |  | start no earlier than 2008-04-27 08:00 |
| 181 | Reporting CAPS 12 | 15min | 2008-04-28 09:00 | 2008-04-28 09:15 |  | start no earlier than 2008-04-28 08:00 |
| 182 | Reporting CAPS 13 | 15min | 2008-04-29 09:00 | 2008-04-29 09:15 |  | start no earlier than 2008-04-29 08:00 |
| 183 | Reporting CAPS 14 | 15min | 2008-04-30 09:00 | 2008-04-30 09:15 |  | start no earlier than 2008-04-30 08:00 |
| 184 | Reporting CAPS 15 | 15min | 2008-05-01 09:00 | 2008-05-01 09:15 |  | start no earlier than 2008-05-01 08:00 |
| 185 | Reporting CAPS 16 | 15min | 2008-05-02 09:00 | 2008-05-02 09:15 |  | start no earlier than 2008-05-02 08:00 |
| 186 | Reporting CAPS 17 | 15min | 2008-05-05 09:00 | 2008-05-05 09:15 |  | start no earlier than 2008-05-03 08:00 |
| 187 | Reporting CAPS 18 | 15min | 2008-05-05 09:00 | 2008-05-05 09:15 |  | start no earlier than 2008-05-04 08:00 |
| 188 | Reporting CAPS 19 | 15min | 2008-05-05 09:00 | 2008-05-05 09:15 |  | start no earlier than 2008-05-05 08:00 |
| 189 | Reporting CAPS 20 | 15min | 2008-05-06 09:00 | 2008-05-06 09:15 |  | start no earlier than 2008-05-06 08:00 |
| 190 | Reporting CAPS 21 | 15min | 2008-05-07 09:00 | 2008-05-07 09:15 |  | start no earlier than 2008-05-07 08:00 |
| 191 | Reporting CAPS 22 | 15min | 2008-05-08 09:00 | 2008-05-08 09:15 |  | start no earlier than 2008-05-08 08:00 |
| 192 | Reporting CAPS 23 | 15min | 2008-05-09 09:00 | 2008-05-09 09:15 |  | start no earlier than 2008-05-09 08:00 |
| 193 | Reporting CAPS 24 | 15min | 2008-05-12 09:00 | 2008-05-12 09:15 |  | start no earlier than 2008-05-10 08:00 |
| 194 | Reporting CAPS 25 | 15min | 2008-05-12 09:00 | 2008-05-12 09:15 |  | start no earlier than 2008-05-11 08:00 |
| 195 | Reporting CAPS 26 | 15min | 2008-05-12 09:00 | 2008-05-12 09:15 |  | start no earlier than 2008-05-12 08:00 |
| 196 | Reporting CAPS 27 | 15min | 2008-05-13 09:00 | 2008-05-13 09:15 |  | start no earlier than 2008-05-13 08:00 |
| 197 | Reporting CAPS 28 | 15min | 2008-05-14 09:00 | 2008-05-14 09:15 |  | start no earlier than 2008-05-14 08:00 |
| 198 | Reporting CAPS 29 | 15min | 2008-05-15 09:00 | 2008-05-15 09:15 |  | start no earlier than 2008-05-15 08:00 |
| 199 | Reporting CAPS 30 | 15min | 2008-05-16 09:00 | 2008-05-16 09:15 |  | start no earlier than 2008-05-16 08:00 |
| 200 | Reporting CAPS 31 | 15min | 2008-05-19 09:00 | 2008-05-19 09:15 |  | start no earlier than 2008-05-17 08:00 |
| 201 | Reporting CAPS 32 | 15min | 2008-05-19 09:00 | 2008-05-19 09:15 |  | start no earlier than 2008-05-18 08:00 |
| 202 | Reporting CAPS 33 | 15min | 2008-05-19 09:00 | 2008-05-19 09:15 |  | start no earlier than 2008-05-19 08:00 |
| 203 | Reporting CAPS 34 | 15min | 2008-05-20 09:00 | 2008-05-20 09:15 |  | start no earlier than 2008-05-20 08:00 |
| 204 | Reporting CAPS 35 | 15min | 2008-05-21 09:00 | 2008-05-21 09:15 |  | start no earlier than 2008-05-21 08:00 |
| 205 | Reporting CAPS 36 | 15min | 2008-05-22 09:00 | 2008-05-22 09:15 |  | start no earlier than 2008-05-22 08:00 |
| 206 | Reporting CAPS 37 | 15min | 2008-05-23 09:00 | 2008-05-23 09:15 |  | start no earlier than 2008-05-23 08:00 |
| 207 | Reporting CAPS 38 | 15min | 2008-05-26 09:00 | 2008-05-26 09:15 |  | start no earlier than 2008-05-24 08:00 |
| 208 | Reporting CAPS 39 | 15min | 2008-05-26 09:00 | 2008-05-26 09:15 |  | start no earlier than 2008-05-25 08:00 |
| 209 | Reporting CAPS 40 | 15min | 2008-05-26 09:00 | 2008-05-26 09:15 |  | start no earlier than 2008-05-26 08:00 |
| 210 | Reporting CAPS 41 | 15min | 2008-05-27 09:00 | 2008-05-27 09:15 |  | start no earlier than 2008-05-27 08:00 |
| 211 | Reporting CAPS 42 | 15min | 2008-05-28 09:00 | 2008-05-28 09:15 |  | start no earlier than 2008-05-28 08:00 |
| 212 | Reporting CAPS 43 | 15min | 2008-05-29 09:00 | 2008-05-29 09:15 |  | start no earlier than 2008-05-29 08:00 |
| 213 | Reporting CAPS 44 | 15min | 2008-05-30 09:00 | 2008-05-30 09:15 |  | start no earlier than 2008-05-30 08:00 |
| 214 | Reporting CAPS 45 | 15min | 2008-06-02 09:00 | 2008-06-02 09:15 |  | start no earlier than 2008-05-31 08:00 |
| 215 | Reporting CAPS 46 | 15min | 2008-06-02 09:00 | 2008-06-02 09:15 |  | start no earlier than 2008-06-01 08:00 |
| 216 | Reporting CAPS 47 | 15min | 2008-06-02 09:00 | 2008-06-02 09:15 |  | start no earlier than 2008-06-02 08:00 |
| 217 | Reporting CAPS 48 | 15min | 2008-06-03 09:00 | 2008-06-03 09:15 |  | start no earlier than 2008-06-03 08:00 |
| 218 | Reporting CAPS 49 | 15min | 2008-06-04 09:00 | 2008-06-04 09:15 |  | start no earlier than 2008-06-04 08:00 |
| 219 | Reporting CAPS 50 | 15min | 2008-06-05 09:00 | 2008-06-05 09:15 |  | start no earlier than 2008-06-05 08:00 |
| 220 | Reporting CAPS 51 | 15min | 2008-06-06 09:00 | 2008-06-06 09:15 |  | start no earlier than 2008-06-06 08:00 |
| 221 | Reporting CAPS 52 | 15min | 2008-06-09 09:00 | 2008-06-09 09:15 |  | start no earlier than 2008-06-07 08:00 |
| 222 | Reporting CAPS 53 | 15min | 2008-06-09 09:00 | 2008-06-09 09:15 |  | start no earlier than 2008-06-08 08:00 |
| 223 | Reporting CAPS 54 | 15min | 2008-06-09 09:00 | 2008-06-09 09:15 |  | start no earlier than 2008-06-09 08:00 |
| 224 | Reporting CAPS 55 | 15min | 2008-06-10 09:00 | 2008-06-10 09:15 |  | start no earlier than 2008-06-10 08:00 |
| 225 | Reporting CAPS 56 | 15min | 2008-06-11 09:00 | 2008-06-11 09:15 |  | start no earlier than 2008-06-11 08:00 |
| 226 | Reporting CAPS 57 | 15min | 2008-06-12 09:00 | 2008-06-12 09:15 |  | start no earlier than 2008-06-12 08:00 |
| 227 | Reporting CAPS 58 | 15min | 2008-06-13 09:00 | 2008-06-13 09:15 |  | start no earlier than 2008-06-13 08:00 |
| 228 | Reporting CAPS 59 | 15min | 2008-06-16 09:00 | 2008-06-16 09:15 |  | start no earlier than 2008-06-14 08:00 |
| 229 | Reporting CAPS 60 | 15min | 2008-06-16 09:00 | 2008-06-16 09:15 |  | start no earlier than 2008-06-15 08:00 |
| 230 | Reporting CAPS 61 | 15min | 2008-06-16 09:00 | 2008-06-16 09:15 |  | start no earlier than 2008-06-16 08:00 |
| 231 | Reporting CAPS 62 | 15min | 2008-06-17 09:00 | 2008-06-17 09:15 |  | start no earlier than 2008-06-17 08:00 |
| 232 | Reporting CAPS 63 | 15min | 2008-06-18 09:00 | 2008-06-18 09:15 |  | start no earlier than 2008-06-18 08:00 |
| 233 | Reporting CAPS 64 | 15min | 2008-06-19 09:00 | 2008-06-19 09:15 |  | start no earlier than 2008-06-19 08:00 |
| 234 | Reporting CAPS 65 | 15min | 2008-06-20 09:00 | 2008-06-20 09:15 |  | start no earlier than 2008-06-20 08:00 |
| 235 | Reporting CAPS 66 | 15min | 2008-06-23 09:00 | 2008-06-23 09:15 |  | start no earlier than 2008-06-21 08:00 |
| 236 | Reporting CAPS 67 | 15min | 2008-06-23 09:00 | 2008-06-23 09:15 |  | start no earlier than 2008-06-22 08:00 |
| 237 | Reporting CAPS 68 | 15min | 2008-06-23 09:00 | 2008-06-23 09:15 |  | start no earlier than 2008-06-23 08:00 |
| 238 | Reporting CAPS 69 | 15min | 2008-06-24 09:00 | 2008-06-24 09:15 |  | start no earlier than 2008-06-24 08:00 |
| 239 | Reporting CAPS 70 | 15min | 2008-06-25 09:00 | 2008-06-25 09:15 |  | start no earlier than 2008-06-25 08:00 |
| 240 | Reporting CAPS 71 | 15min | 2008-06-26 09:00 | 2008-06-26 09:15 |  | start no earlier than 2008-06-26 08:00 |
| 241 | Reporting CAPS 72 | 15min | 2008-06-27 09:00 | 2008-06-27 09:15 |  | start no earlier than 2008-06-27 08:00 |
| 242 | Reporting CAPS 73 | 15min | 2008-06-30 09:00 | 2008-06-30 09:15 |  | start no earlier than 2008-06-28 08:00 |
| 243 | Reporting CAPS 74 | 15min | 2008-06-30 09:00 | 2008-06-30 09:15 |  | start no earlier than 2008-06-29 08:00 |
| 244 | Reporting CAPS 75 | 15min | 2008-06-30 09:00 | 2008-06-30 09:15 |  | start no earlier than 2008-06-30 08:00 |
| 245 | Reporting CAPS 76 | 15min | 2008-07-01 09:00 | 2008-07-01 09:15 |  | start no earlier than 2008-07-01 08:00 |
| 246 | Reporting CAPS 77 | 15min | 2008-07-02 09:00 | 2008-07-02 09:15 |  | start no earlier than 2008-07-02 08:00 |
| 247 | Reporting CAPS 78 | 15min | 2008-07-03 09:00 | 2008-07-03 09:15 |  | start no earlier than 2008-07-03 08:00 |
| 248 | Reporting CAPS 79 | 15min | 2008-07-04 09:00 | 2008-07-04 09:15 |  | start no earlier than 2008-07-04 08:00 |
| 249 | Reporting CAPS 80 | 15min | 2008-07-07 09:00 | 2008-07-07 09:15 |  | start no earlier than 2008-07-05 08:00 |
| 250 | Reporting CAPS 81 | 15min | 2008-07-07 09:00 | 2008-07-07 09:15 |  | start no earlier than 2008-07-06 08:00 |
| 251 | Reporting CAPS 82 | 15min | 2008-07-07 09:00 | 2008-07-07 09:15 |  | start no earlier than 2008-07-07 08:00 |
| 252 | Reporting CAPS 83 | 15min | 2008-07-08 09:00 | 2008-07-08 09:15 |  | start no earlier than 2008-07-08 08:00 |
| 253 | Reporting CAPS 84 | 15min | 2008-07-09 09:00 | 2008-07-09 09:15 |  | start no earlier than 2008-07-09 08:00 |
| 254 | Reporting CAPS 85 | 15min | 2008-07-10 09:00 | 2008-07-10 09:15 |  | start no earlier than 2008-07-10 08:00 |
| 255 | Reporting CAPS 86 | 15min | 2008-07-11 09:00 | 2008-07-11 09:15 |  | start no earlier than 2008-07-11 08:00 |
| 256 | Reporting CAPS 87 | 15min | 2008-07-14 09:00 | 2008-07-14 09:15 |  | start no earlier than 2008-07-12 08:00 |
| 257 | Reporting CAPS 88 | 15min | 2008-07-14 09:00 | 2008-07-14 09:15 |  | start no earlier than 2008-07-13 08:00 |
| 258 | Reporting CAPS 89 | 15min | 2008-07-14 09:00 | 2008-07-14 09:15 |  | start no earlier than 2008-07-14 08:00 |
| 259 | Reporting CAPS 90 | 15min | 2008-07-15 09:00 | 2008-07-15 09:15 |  | start no earlier than 2008-07-15 08:00 |
| 260 | Reporting CAPS 91 | 15min | 2008-07-16 09:00 | 2008-07-16 09:15 |  | start no earlier than 2008-07-16 08:00 |
| 261 | Reporting CAPS 92 | 15min | 2008-07-17 09:00 | 2008-07-17 09:15 |  | start no earlier than 2008-07-17 08:00 |
| 262 | Reporting CAPS 93 | 15min | 2008-07-18 09:00 | 2008-07-18 09:15 |  | start no earlier than 2008-07-18 08:00 |
| 263 | Reporting CAPS 94 | 15min | 2008-07-21 09:00 | 2008-07-21 09:15 |  | start no earlier than 2008-07-19 08:00 |
| 264 | Reporting CAPS 95 | 15min | 2008-07-21 09:00 | 2008-07-21 09:15 |  | start no earlier than 2008-07-20 08:00 |
| 265 | Reporting CAPS 96 | 15min | 2008-07-21 09:00 | 2008-07-21 09:15 |  | start no earlier than 2008-07-21 08:00 |
| 266 | Reporting CAPS 97 | 15min | 2008-07-22 09:00 | 2008-07-22 09:15 |  | start no earlier than 2008-07-22 08:00 |
| 267 | Reporting CAPS 98 | 15min | 2008-07-23 09:00 | 2008-07-23 09:15 |  | start no earlier than 2008-07-23 08:00 |
| 268 | Reporting CAPS 99 | 15min | 2008-07-24 09:00 | 2008-07-24 09:15 |  | start no earlier than 2008-07-24 08:00 |
| 269 | Reporting CAPS 100 | 15min | 2008-07-25 09:00 | 2008-07-25 09:15 |  | start no earlier than 2008-07-25 08:00 |
| 270 | Reporting CAPS 101 | 15min | 2008-07-28 09:00 | 2008-07-28 09:15 |  | start no earlier than 2008-07-26 08:00 |
| 271 | Reporting CAPS 102 | 15min | 2008-07-28 09:00 | 2008-07-28 09:15 |  | start no earlier than 2008-07-27 08:00 |
| 272 | Reporting CAPS 103 | 15min | 2008-07-28 09:00 | 2008-07-28 09:15 |  | start no earlier than 2008-07-28 08:00 |
| 273 | Reporting CAPS 104 | 15min | 2008-07-29 09:00 | 2008-07-29 09:15 |  | start no earlier than 2008-07-29 08:00 |
| 274 | Reporting CAPS 105 | 15min | 2008-07-30 09:00 | 2008-07-30 09:15 |  | start no earlier than 2008-07-30 08:00 |
| 275 | Reporting CAPS 106 | 15min | 2008-07-31 09:00 | 2008-07-31 09:15 |  | start no earlier than 2008-07-31 08:00 |
| 276 | Reporting CAPS 107 | 15min | 2008-08-01 09:00 | 2008-08-01 09:15 |  | start no earlier than 2008-08-01 08:00 |
| 277 | **Reporting PO** | 62.19d | 2008-04-21 09:00 | 2008-07-29 09:30 |  |  |
| 278 | Reporting PO 1 | 30min | 2008-04-21 09:00 | 2008-04-21 09:30 |  | start no earlier than 2008-04-21 08:00 |
| 279 | Reporting PO 2 | 30min | 2008-04-22 09:00 | 2008-04-22 09:30 |  | start no earlier than 2008-04-22 08:00 |
| 280 | Reporting PO 3 | 30min | 2008-04-28 09:00 | 2008-04-28 09:30 |  | start no earlier than 2008-04-28 08:00 |
| 281 | Reporting PO 4 | 30min | 2008-04-29 09:00 | 2008-04-29 09:30 |  | start no earlier than 2008-04-29 08:00 |
| 282 | Reporting PO 5 | 30min | 2008-05-05 09:00 | 2008-05-05 09:30 |  | start no earlier than 2008-05-05 08:00 |
| 283 | Reporting PO 6 | 30min | 2008-05-06 09:00 | 2008-05-06 09:30 |  | start no earlier than 2008-05-06 08:00 |
| 284 | Reporting PO 7 | 30min | 2008-05-12 09:00 | 2008-05-12 09:30 |  | start no earlier than 2008-05-12 08:00 |
| 285 | Reporting PO 8 | 30min | 2008-05-13 09:00 | 2008-05-13 09:30 |  | start no earlier than 2008-05-13 08:00 |
| 286 | Reporting PO 9 | 30min | 2008-05-19 09:00 | 2008-05-19 09:30 |  | start no earlier than 2008-05-19 08:00 |
| 287 | Reporting PO 10 | 30min | 2008-05-20 09:00 | 2008-05-20 09:30 |  | start no earlier than 2008-05-20 08:00 |
| 288 | Reporting PO 11 | 30min | 2008-05-26 09:00 | 2008-05-26 09:30 |  | start no earlier than 2008-05-26 08:00 |
| 289 | Reporting PO 12 | 30min | 2008-05-27 09:00 | 2008-05-27 09:30 |  | start no earlier than 2008-05-27 08:00 |
| 290 | Reporting PO 13 | 30min | 2008-06-02 09:00 | 2008-06-02 09:30 |  | start no earlier than 2008-06-02 08:00 |
| 291 | Reporting PO 14 | 30min | 2008-06-03 09:00 | 2008-06-03 09:30 |  | start no earlier than 2008-06-03 08:00 |
| 292 | Reporting PO 15 | 30min | 2008-06-09 09:00 | 2008-06-09 09:30 |  | start no earlier than 2008-06-09 08:00 |
| 293 | Reporting PO 16 | 30min | 2008-06-10 09:00 | 2008-06-10 09:30 |  | start no earlier than 2008-06-10 08:00 |
| 294 | Reporting PO 17 | 30min | 2008-06-16 09:00 | 2008-06-16 09:30 |  | start no earlier than 2008-06-16 08:00 |
| 295 | Reporting PO 18 | 30min | 2008-06-17 09:00 | 2008-06-17 09:30 |  | start no earlier than 2008-06-17 08:00 |
| 296 | Reporting PO 19 | 30min | 2008-06-23 09:00 | 2008-06-23 09:30 |  | start no earlier than 2008-06-23 08:00 |
| 297 | Reporting PO 20 | 30min | 2008-06-24 09:00 | 2008-06-24 09:30 |  | start no earlier than 2008-06-24 08:00 |
| 298 | Reporting PO 21 | 30min | 2008-06-30 09:00 | 2008-06-30 09:30 |  | start no earlier than 2008-06-30 08:00 |
| 299 | Reporting PO 22 | 30min | 2008-07-01 09:00 | 2008-07-01 09:30 |  | start no earlier than 2008-07-01 08:00 |
| 300 | Reporting PO 23 | 30min | 2008-07-07 09:00 | 2008-07-07 09:30 |  | start no earlier than 2008-07-07 08:00 |
| 301 | Reporting PO 24 | 30min | 2008-07-08 09:00 | 2008-07-08 09:30 |  | start no earlier than 2008-07-08 08:00 |
| 302 | Reporting PO 25 | 30min | 2008-07-14 09:00 | 2008-07-14 09:30 |  | start no earlier than 2008-07-14 08:00 |
| 303 | Reporting PO 26 | 30min | 2008-07-15 09:00 | 2008-07-15 09:30 |  | start no earlier than 2008-07-15 08:00 |
| 304 | Reporting PO 27 | 30min | 2008-07-21 09:00 | 2008-07-21 09:30 |  | start no earlier than 2008-07-21 08:00 |
| 305 | Reporting PO 28 | 30min | 2008-07-22 09:00 | 2008-07-22 09:30 |  | start no earlier than 2008-07-22 08:00 |
| 306 | Reporting PO 29 | 30min | 2008-07-28 09:00 | 2008-07-28 09:30 |  | start no earlier than 2008-07-28 08:00 |
| 307 | Reporting PO 30 | 30min | 2008-07-29 09:00 | 2008-07-29 09:30 |  | start no earlier than 2008-07-29 08:00 |
| 308 | **Reporting commanditaire** | 61.28d | 2008-04-22 09:00 | 2008-07-29 09:15 |  |  |
| 309 | Reporting commanditaire 1 | 15min | 2008-04-22 09:00 | 2008-04-22 09:15 |  | start no earlier than 2008-04-22 08:00 |
| 310 | Reporting commanditaire 2 | 15min | 2008-04-29 09:00 | 2008-04-29 09:15 |  | start no earlier than 2008-04-29 08:00 |
| 311 | Reporting commanditaire 3 | 15min | 2008-05-06 09:00 | 2008-05-06 09:15 |  | start no earlier than 2008-05-06 08:00 |
| 312 | Reporting commanditaire 4 | 15min | 2008-05-13 09:00 | 2008-05-13 09:15 |  | start no earlier than 2008-05-13 08:00 |
| 313 | Reporting commanditaire 5 | 15min | 2008-05-20 09:00 | 2008-05-20 09:15 |  | start no earlier than 2008-05-20 08:00 |
| 314 | Reporting commanditaire 6 | 15min | 2008-05-27 09:00 | 2008-05-27 09:15 |  | start no earlier than 2008-05-27 08:00 |
| 315 | Reporting commanditaire 7 | 15min | 2008-06-03 09:00 | 2008-06-03 09:15 |  | start no earlier than 2008-06-03 08:00 |
| 316 | Reporting commanditaire 8 | 15min | 2008-06-10 09:00 | 2008-06-10 09:15 |  | start no earlier than 2008-06-10 08:00 |
| 317 | Reporting commanditaire 9 | 15min | 2008-06-17 09:00 | 2008-06-17 09:15 |  | start no earlier than 2008-06-17 08:00 |
| 318 | Reporting commanditaire 10 | 15min | 2008-06-24 09:00 | 2008-06-24 09:15 |  | start no earlier than 2008-06-24 08:00 |
| 319 | Reporting commanditaire 11 | 15min | 2008-07-01 09:00 | 2008-07-01 09:15 |  | start no earlier than 2008-07-01 08:00 |
| 320 | Reporting commanditaire 12 | 15min | 2008-07-08 09:00 | 2008-07-08 09:15 |  | start no earlier than 2008-07-08 08:00 |
| 321 | Reporting commanditaire 13 | 15min | 2008-07-15 09:00 | 2008-07-15 09:15 |  | start no earlier than 2008-07-15 08:00 |
| 322 | Reporting commanditaire 14 | 15min | 2008-07-22 09:00 | 2008-07-22 09:15 |  | start no earlier than 2008-07-22 08:00 |
| 323 | Reporting commanditaire 15 | 15min | 2008-07-29 09:00 | 2008-07-29 09:15 |  | start no earlier than 2008-07-29 08:00 |
| 324 | **Fiche de reporting** | 61.25d | 2008-04-21 08:00 | 2008-07-28 08:00 |  |  |
| 325 | Fiche de reporting 1 | 0d | 2008-04-21 08:00 | 2008-04-21 08:00 |  | start no earlier than 2008-04-21 08:00 |
| 326 | Fiche de reporting 2 | 0d | 2008-04-28 08:00 | 2008-04-28 08:00 |  | start no earlier than 2008-04-28 08:00 |
| 327 | Fiche de reporting 3 | 0d | 2008-05-05 08:00 | 2008-05-05 08:00 |  | start no earlier than 2008-05-05 08:00 |
| 328 | Fiche de reporting 4 | 0d | 2008-05-12 08:00 | 2008-05-12 08:00 |  | start no earlier than 2008-05-12 08:00 |
| 329 | Fiche de reporting 5 | 0d | 2008-05-19 08:00 | 2008-05-19 08:00 |  | start no earlier than 2008-05-19 08:00 |
| 330 | Fiche de reporting 6 | 0d | 2008-05-26 08:00 | 2008-05-26 08:00 |  | start no earlier than 2008-05-26 08:00 |
| 331 | Fiche de reporting 7 | 0d | 2008-06-02 08:00 | 2008-06-02 08:00 |  | start no earlier than 2008-06-02 08:00 |
| 332 | Fiche de reporting 8 | 0d | 2008-06-09 08:00 | 2008-06-09 08:00 |  | start no earlier than 2008-06-09 08:00 |
| 333 | Fiche de reporting 9 | 0d | 2008-06-16 08:00 | 2008-06-16 08:00 |  | start no earlier than 2008-06-16 08:00 |
| 334 | Fiche de reporting 10 | 0d | 2008-06-23 08:00 | 2008-06-23 08:00 |  | start no earlier than 2008-06-23 08:00 |
| 335 | Fiche de reporting 11 | 0d | 2008-06-30 08:00 | 2008-06-30 08:00 |  | start no earlier than 2008-06-30 08:00 |
| 336 | Fiche de reporting 12 | 0d | 2008-07-07 08:00 | 2008-07-07 08:00 |  | start no earlier than 2008-07-07 08:00 |
| 337 | Fiche de reporting 13 | 0d | 2008-07-14 08:00 | 2008-07-14 08:00 |  | start no earlier than 2008-07-14 08:00 |
| 338 | Fiche de reporting 14 | 0d | 2008-07-21 08:00 | 2008-07-21 08:00 |  | start no earlier than 2008-07-21 08:00 |
| 339 | Fiche de reporting 15 | 0d | 2008-07-28 08:00 | 2008-07-28 08:00 |  | start no earlier than 2008-07-28 08:00 |
| 340 | **Réunion comité de pilotage** | 57.88d | 2008-04-17 09:00 | 2008-07-18 10:00 |  |  |
| 341 | Réunion comité de pilotage 1 | 1d | 2008-04-17 09:00 | 2008-04-18 10:00 |  | start no earlier than 2008-04-17 08:00 |
| 342 | Réunion comité de pilotage 2 | 1d | 2008-05-19 09:00 | 2008-05-20 10:00 |  | start no earlier than 2008-05-17 08:00 |
| 343 | Réunion comité de pilotage 3 | 1d | 2008-06-17 09:00 | 2008-06-18 10:00 |  | start no earlier than 2008-06-17 08:00 |
| 344 | Réunion comité de pilotage 4 | 1d | 2008-07-17 09:00 | 2008-07-18 10:00 |  | start no earlier than 2008-07-17 08:00 |
| 345 | **Rapport Flash** | 56.88d | 2008-04-17 08:00 | 2008-07-17 08:00 |  |  |
| 346 | Rapport Flash 1 | 0d | 2008-04-17 08:00 | 2008-04-17 08:00 |  | start no earlier than 2008-04-17 08:00 |
| 347 | Rapport Flash 2 | 0d | 2008-05-17 08:00 | 2008-05-17 08:00 |  | start no earlier than 2008-05-17 08:00 |
| 348 | Rapport Flash 3 | 0d | 2008-06-17 08:00 | 2008-06-17 08:00 |  | start no earlier than 2008-06-17 08:00 |
| 349 | Rapport Flash 4 | 0d | 2008-07-17 08:00 | 2008-07-17 08:00 |  | start no earlier than 2008-07-17 08:00 |
| 350 | **Mettre à jour le planning** | 61.38d | 2008-04-21 09:00 | 2008-07-28 10:00 |  |  |
| 351 | Mettre à jour le planning 1 | 1h | 2008-04-21 09:00 | 2008-04-21 10:00 |  | start no earlier than 2008-04-21 08:00 |
| 352 | Mettre à jour le planning 2 | 1h | 2008-04-28 09:00 | 2008-04-28 10:00 |  | start no earlier than 2008-04-28 08:00 |
| 353 | Mettre à jour le planning 3 | 1h | 2008-05-05 09:00 | 2008-05-05 10:00 |  | start no earlier than 2008-05-05 08:00 |
| 354 | Mettre à jour le planning 4 | 1h | 2008-05-12 09:00 | 2008-05-12 10:00 |  | start no earlier than 2008-05-12 08:00 |
| 355 | Mettre à jour le planning 5 | 1h | 2008-05-19 09:00 | 2008-05-19 10:00 |  | start no earlier than 2008-05-19 08:00 |
| 356 | Mettre à jour le planning 6 | 1h | 2008-05-26 09:00 | 2008-05-26 10:00 |  | start no earlier than 2008-05-26 08:00 |
| 357 | Mettre à jour le planning 7 | 1h | 2008-06-02 09:00 | 2008-06-02 10:00 |  | start no earlier than 2008-06-02 08:00 |
| 358 | Mettre à jour le planning 8 | 1h | 2008-06-09 09:00 | 2008-06-09 10:00 |  | start no earlier than 2008-06-09 08:00 |
| 359 | Mettre à jour le planning 9 | 1h | 2008-06-16 09:00 | 2008-06-16 10:00 |  | start no earlier than 2008-06-16 08:00 |
| 360 | Mettre à jour le planning 10 | 1h | 2008-06-23 09:00 | 2008-06-23 10:00 |  | start no earlier than 2008-06-23 08:00 |
| 361 | Mettre à jour le planning 11 | 1h | 2008-06-30 09:00 | 2008-06-30 10:00 |  | start no earlier than 2008-06-30 08:00 |
| 362 | Mettre à jour le planning 12 | 1h | 2008-07-07 09:00 | 2008-07-07 10:00 |  | start no earlier than 2008-07-07 08:00 |
| 363 | Mettre à jour le planning 13 | 1h | 2008-07-14 09:00 | 2008-07-14 10:00 |  | start no earlier than 2008-07-14 08:00 |
| 364 | Mettre à jour le planning 14 | 1h | 2008-07-21 09:00 | 2008-07-21 10:00 |  | start no earlier than 2008-07-21 08:00 |
| 365 | Mettre à jour le planning 15 | 1h | 2008-07-28 09:00 | 2008-07-28 10:00 |  | start no earlier than 2008-07-28 08:00 |
| 366 | **Planning détaillé de suivi** | 61.25d | 2008-04-21 08:00 | 2008-07-28 08:00 |  |  |
| 367 | Planning détaillé de suivi 1 | 0d | 2008-04-21 08:00 | 2008-04-21 08:00 |  | start no earlier than 2008-04-21 08:00 |
| 368 | Planning détaillé de suivi 2 | 0d | 2008-04-28 08:00 | 2008-04-28 08:00 |  | start no earlier than 2008-04-28 08:00 |
| 369 | Planning détaillé de suivi 3 | 0d | 2008-05-05 08:00 | 2008-05-05 08:00 |  | start no earlier than 2008-05-05 08:00 |
| 370 | Planning détaillé de suivi 4 | 0d | 2008-05-12 08:00 | 2008-05-12 08:00 |  | start no earlier than 2008-05-12 08:00 |
| 371 | Planning détaillé de suivi 5 | 0d | 2008-05-19 08:00 | 2008-05-19 08:00 |  | start no earlier than 2008-05-19 08:00 |
| 372 | Planning détaillé de suivi 6 | 0d | 2008-05-26 08:00 | 2008-05-26 08:00 |  | start no earlier than 2008-05-26 08:00 |
| 373 | Planning détaillé de suivi 7 | 0d | 2008-06-02 08:00 | 2008-06-02 08:00 |  | start no earlier than 2008-06-02 08:00 |
| 374 | Planning détaillé de suivi 8 | 0d | 2008-06-09 08:00 | 2008-06-09 08:00 |  | start no earlier than 2008-06-09 08:00 |
| 375 | Planning détaillé de suivi 9 | 0d | 2008-06-16 08:00 | 2008-06-16 08:00 |  | start no earlier than 2008-06-16 08:00 |
| 376 | Planning détaillé de suivi 10 | 0d | 2008-06-23 08:00 | 2008-06-23 08:00 |  | start no earlier than 2008-06-23 08:00 |
| 377 | Planning détaillé de suivi 11 | 0d | 2008-06-30 08:00 | 2008-06-30 08:00 |  | start no earlier than 2008-06-30 08:00 |
| 378 | Planning détaillé de suivi 12 | 0d | 2008-07-07 08:00 | 2008-07-07 08:00 |  | start no earlier than 2008-07-07 08:00 |
| 379 | Planning détaillé de suivi 13 | 0d | 2008-07-14 08:00 | 2008-07-14 08:00 |  | start no earlier than 2008-07-14 08:00 |
| 380 | Planning détaillé de suivi 14 | 0d | 2008-07-21 08:00 | 2008-07-21 08:00 |  | start no earlier than 2008-07-21 08:00 |
| 381 | Planning détaillé de suivi 15 | 0d | 2008-07-28 08:00 | 2008-07-28 08:00 |  | start no earlier than 2008-07-28 08:00 |
| 382 | **Mettre à jour la documentation** | 61.38d | 2008-04-21 09:00 | 2008-07-28 10:00 |  |  |
| 383 | Mettre à jour la documentation 1 | 1h | 2008-04-21 09:00 | 2008-04-21 10:00 |  | start no earlier than 2008-04-21 08:00 |
| 384 | Mettre à jour la documentation 2 | 1h | 2008-04-28 09:00 | 2008-04-28 10:00 |  | start no earlier than 2008-04-28 08:00 |
| 385 | Mettre à jour la documentation 3 | 1h | 2008-05-05 09:00 | 2008-05-05 10:00 |  | start no earlier than 2008-05-05 08:00 |
| 386 | Mettre à jour la documentation 4 | 1h | 2008-05-12 09:00 | 2008-05-12 10:00 |  | start no earlier than 2008-05-12 08:00 |
| 387 | Mettre à jour la documentation 5 | 1h | 2008-05-19 09:00 | 2008-05-19 10:00 |  | start no earlier than 2008-05-19 08:00 |
| 388 | Mettre à jour la documentation 6 | 1h | 2008-05-26 09:00 | 2008-05-26 10:00 |  | start no earlier than 2008-05-26 08:00 |
| 389 | Mettre à jour la documentation 7 | 1h | 2008-06-02 09:00 | 2008-06-02 10:00 |  | start no earlier than 2008-06-02 08:00 |
| 390 | Mettre à jour la documentation 8 | 1h | 2008-06-09 09:00 | 2008-06-09 10:00 |  | start no earlier than 2008-06-09 08:00 |
| 391 | Mettre à jour la documentation 9 | 1h | 2008-06-16 09:00 | 2008-06-16 10:00 |  | start no earlier than 2008-06-16 08:00 |
| 392 | Mettre à jour la documentation 10 | 1h | 2008-06-23 09:00 | 2008-06-23 10:00 |  | start no earlier than 2008-06-23 08:00 |
| 393 | Mettre à jour la documentation 11 | 1h | 2008-06-30 09:00 | 2008-06-30 10:00 |  | start no earlier than 2008-06-30 08:00 |
| 394 | Mettre à jour la documentation 12 | 1h | 2008-07-07 09:00 | 2008-07-07 10:00 |  | start no earlier than 2008-07-07 08:00 |
| 395 | Mettre à jour la documentation 13 | 1h | 2008-07-14 09:00 | 2008-07-14 10:00 |  | start no earlier than 2008-07-14 08:00 |
| 396 | Mettre à jour la documentation 14 | 1h | 2008-07-21 09:00 | 2008-07-21 10:00 |  | start no earlier than 2008-07-21 08:00 |
| 397 | Mettre à jour la documentation 15 | 1h | 2008-07-28 09:00 | 2008-07-28 10:00 |  | start no earlier than 2008-07-28 08:00 |
| 400 | Préparer la communication presse | 5d | 2008-05-26 09:00 | 2008-06-02 16:00 |  | start no earlier than 2008-05-26 08:00 |
| 401 | Envoyer communication presse | 1d | 2008-06-26 09:00 | 2008-06-27 10:00 |  | start no earlier than 2008-06-26 09:00 |
| 402 | Communication presse | 0d | 2008-07-28 11:48 | 2008-07-28 11:48 | 164, 401 |  |
| 403 | Rédiger la communication clients | 1d | 2008-06-26 09:00 | 2008-06-27 10:00 |  | start no earlier than 2008-06-26 09:00 |
| 404 | Envoyer la communication clients | 1d | 2008-07-28 11:48 | 2008-07-29 14:48 | 164 |  |
| 405 | Communication clients | 0d | 2008-07-29 14:48 | 2008-07-29 14:48 | 404 |  |

Removed: 169 Faire les réunions de comité de pilotage; 170 Rapport flash; 171 Faire les réunion avec l'équipe projet; 172 Vérifier le reporting; 173 Fiche de reporting (suite); 174 Mettre à jour la planning; 175 Planning détaillé (suite); 176 Mettre à jour la documentation; 177 œuvre en œuvre la communication

Changed:

| ID | Task | Start | Finish |
| --- | --- | --- | --- |
| 1 | Début du projet | 2008-04-17 → 2008-04-17 08:00 | 2008-04-17 → 2008-04-17 08:00 |
| 2 | **GESTION DU PROJET** | 2008-04-17 → 2008-04-17 09:00 | 2008-04-29 → 2008-04-29 11:48 |
| 3 | **Initialiser le projet** | 2008-04-17 → 2008-04-17 09:00 | 2008-04-18 → 2008-04-18 18:00 |
| 4 | **Réception** | 2008-04-17 → 2008-04-17 09:00 | 2008-04-17 → 2008-04-17 15:00 |
| 5 | Réceptionner la demande de projet du commanditaire | 2008-04-17 → 2008-04-17 09:00 | 2008-04-17 → 2008-04-17 11:00 |
| 6 | Demande de projet du commanditaire | 2008-04-17 → 2008-04-17 11:00 | 2008-04-17 → 2008-04-17 11:00 |
| 7 | Examiner la demande du commanditaire | 2008-04-17 → 2008-04-17 11:00 | 2008-04-17 → 2008-04-17 15:00 |
| 8 | Réponse à la demande de projet | 2008-04-17 → 2008-04-17 15:00 | 2008-04-17 → 2008-04-17 15:00 |
| 9 | **Affectation** | 2008-04-17 → 2008-04-17 15:00 | 2008-04-18 → 2008-04-18 18:00 |
| 10 | Officialiser la nomination du chef de projet | 2008-04-17 → 2008-04-17 15:00 | 2008-04-17 → 2008-04-17 17:00 |
| 11 | Note d’affectation du chef de projet | 2008-04-18 → 2008-04-18 18:00 | 2008-04-18 → 2008-04-18 18:00 |
| 12 | **Préparer le projet** | 2008-04-21 → 2008-04-21 09:00 | 2008-04-25 → 2008-04-25 15:00 |
| 13 | **Objet** | 2008-04-21 → 2008-04-21 09:00 | 2008-04-21 → 2008-04-21 11:00 |
| 14 | Définir l’objet précis du projet | 2008-04-21 → 2008-04-21 09:00 | 2008-04-21 → 2008-04-21 11:00 |
| 15 | Note de cadrage | 2008-04-21 → 2008-04-21 11:00 | 2008-04-21 → 2008-04-21 11:00 |
| 16 | Lister les motifs et définir le contexte | 2008-04-21 → 2008-04-21 09:00 | 2008-04-21 → 2008-04-21 11:00 |
| 17 | Note de cadrage (suite) | 2008-04-21 → 2008-04-21 11:00 | 2008-04-21 → 2008-04-21 11:00 |
| 18 | **Objectifs** | 2008-04-22 → 2008-04-22 14:00 | 2008-04-23 → 2008-04-23 11:00 |
| 19 | Définir les objectifs de qualité | 2008-04-22 → 2008-04-22 14:00 | 2008-04-22 → 2008-04-22 16:00 |
| 20 | Note de cadrage (suite) | 2008-04-22 → 2008-04-22 16:00 | 2008-04-22 → 2008-04-22 16:00 |
| 21 | Définir les objectifs de temps | 2008-04-22 → 2008-04-22 14:00 | 2008-04-22 → 2008-04-22 16:00 |
| 22 | macro-planning | 2008-04-22 → 2008-04-22 16:00 | 2008-04-22 → 2008-04-22 16:00 |
| 23 | Définir les objectifs de charge et de coûts | 2008-04-22 → 2008-04-22 14:00 | 2008-04-22 → 2008-04-22 16:00 |
| 24 | macro-planning de charge | 2008-04-22 → 2008-04-22 16:00 | 2008-04-22 → 2008-04-22 16:00 |
| 25 | Budget prévisionnel | 2008-04-22 → 2008-04-22 16:00 | 2008-04-22 → 2008-04-22 16:00 |
| 26 | Définir les objectifs de communication | 2008-04-22 → 2008-04-22 16:00 | 2008-04-22 → 2008-04-22 18:00 |
| 27 | Stratégie de communication | 2008-04-22 → 2008-04-22 18:00 | 2008-04-22 → 2008-04-22 18:00 |
| 28 | Définir les objectifs complémentaires | 2008-04-22 → 2008-04-22 14:00 | 2008-04-22 → 2008-04-22 16:00 |
| 29 | Note de cadrage (suite) | 2008-04-22 → 2008-04-22 16:00 | 2008-04-22 → 2008-04-22 16:00 |
| 30 | Préciser les contraintes sur objectifs | 2008-04-22 → 2008-04-22 16:00 | 2008-04-22 → 2008-04-22 18:00 |
| 31 | Note de cadrage (suite) | 2008-04-22 → 2008-04-22 18:00 | 2008-04-22 → 2008-04-22 18:00 |
| 32 | Vérifier l’adéquation entre les objectifs | 2008-04-23 → 2008-04-23 09:00 | 2008-04-23 → 2008-04-23 11:00 |
| 33 | Note de cadrage (suite) | 2008-04-23 → 2008-04-23 11:00 | 2008-04-23 → 2008-04-23 11:00 |
| 34 | **Domaine** | 2008-04-23 → 2008-04-23 11:00 | 2008-04-24 → 2008-04-24 16:00 |
| 35 | Identifier le périmètre et les acteurs | 2008-04-23 → 2008-04-23 11:00 | 2008-04-24 → 2008-04-24 12:00 |
| 36 | Fichier des acteurs | 2008-04-24 → 2008-04-24 12:00 | 2008-04-24 → 2008-04-24 12:00 |
| 37 | Définir la structure choisie pour la gestion du projet | 2008-04-24 → 2008-04-24 10:00 | 2008-04-24 → 2008-04-24 12:00 |
| 38 | Organigramme Projet | 2008-04-24 → 2008-04-24 12:00 | 2008-04-24 → 2008-04-24 12:00 |
| 39 | Définir les rôles des acteurs dans les structures projets | 2008-04-24 → 2008-04-24 14:00 | 2008-04-24 → 2008-04-24 16:00 |
| 40 | Fiche de poste | 2008-04-24 → 2008-04-24 16:00 | 2008-04-24 → 2008-04-24 16:00 |
| 41 | Carte des acteurs | 2008-04-24 → 2008-04-24 16:00 | 2008-04-24 → 2008-04-24 16:00 |
| 42 | **Risques** | 2008-04-24 → 2008-04-24 16:00 | 2008-04-24 → 2008-04-24 18:00 |
| 43 | Identifier, analyser et gérer les freins | 2008-04-24 → 2008-04-24 16:00 | 2008-04-24 → 2008-04-24 18:00 |
| 44 | Grille des freins | 2008-04-24 → 2008-04-24 18:00 | 2008-04-24 → 2008-04-24 18:00 |
| 45 | Identifier, analyser et gérer les facilitants | 2008-04-24 → 2008-04-24 16:00 | 2008-04-24 → 2008-04-24 18:00 |
| 46 | Grille des facilitants | 2008-04-24 → 2008-04-24 18:00 | 2008-04-24 → 2008-04-24 18:00 |
| 47 | **Méthode** | 2008-04-24 → 2008-04-24 16:00 | 2008-04-24 → 2008-04-24 18:00 |
| 48 | Choisir une méthode et structurer la réal. du produit | 2008-04-24 → 2008-04-24 16:00 | 2008-04-24 → 2008-04-24 18:00 |
| 49 | Fiche méthode | 2008-04-24 → 2008-04-24 18:00 | 2008-04-24 → 2008-04-24 18:00 |
| 50 | **Communication** | 2008-04-25 → 2008-04-25 09:00 | 2008-04-25 → 2008-04-25 11:00 |
| 51 | Définir les axes, cibles et moyens de communication | 2008-04-25 → 2008-04-25 09:00 | 2008-04-25 → 2008-04-25 11:00 |
| 52 | Charte graphique | 2008-04-25 → 2008-04-25 11:00 | 2008-04-25 → 2008-04-25 11:00 |
| 53 | Plan de communication | 2008-04-25 → 2008-04-25 11:00 | 2008-04-25 → 2008-04-25 11:00 |
| 54 | **Contractualisation** | 2008-04-25 → 2008-04-25 11:00 | 2008-04-25 → 2008-04-25 15:00 |
| 55 | Rédiger la note de cadrage | 2008-04-25 → 2008-04-25 11:00 | 2008-04-25 → 2008-04-25 15:00 |
| 56 | Note de cadrage (suite) | 2008-04-25 → 2008-04-25 15:00 | 2008-04-25 → 2008-04-25 15:00 |
| 57 | **Planifier le projet** | 2008-04-25 → 2008-04-25 15:00 | 2008-04-28 → 2008-04-28 16:48 |
| 58 | **Planification détallée** | 2008-04-25 → 2008-04-25 15:00 | 2008-04-28 → 2008-04-28 10:48 |
| 59 | Définir l’environnement de planification | 2008-04-25 → 2008-04-25 15:00 | 2008-04-25 → 2008-04-25 15:48 |
| 60 | Charte de planification | 2008-04-25 → 2008-04-25 15:48 | 2008-04-25 → 2008-04-25 15:48 |
| 61 | Ordonner la liste des tâches de fabrication du produit | 2008-04-25 → 2008-04-25 15:48 | 2008-04-25 → 2008-04-25 16:36 |
| 62 | Organigramme des tâches | 2008-04-25 → 2008-04-25 16:36 | 2008-04-25 → 2008-04-25 16:36 |
| 63 | Affecter des durées ou des charges aux tâches | 2008-04-25 → 2008-04-25 16:36 | 2008-04-25 → 2008-04-25 17:24 |
| 64 | Planning détaillé | 2008-04-25 → 2008-04-25 17:24 | 2008-04-25 → 2008-04-25 17:24 |
| 65 | Définir les liens entre les tâches | 2008-04-25 → 2008-04-25 17:24 | 2008-04-28 → 2008-04-28 09:12 |
| 66 | Planning détaillé (suite) | 2008-04-28 → 2008-04-28 09:12 | 2008-04-28 → 2008-04-28 09:12 |
| 67 | Intégrer les tâches de gestion de projet | 2008-04-28 → 2008-04-28 09:12 | 2008-04-28 → 2008-04-28 10:00 |
| 68 | Planning détaillé (suite) | 2008-04-28 → 2008-04-28 10:00 | 2008-04-28 → 2008-04-28 10:00 |
| 69 | Affecter les ressources sur les tâches | 2008-04-28 → 2008-04-28 10:00 | 2008-04-28 → 2008-04-28 10:48 |
| 70 | Tableau des ressources | 2008-04-28 → 2008-04-28 10:48 | 2008-04-28 → 2008-04-28 10:48 |

| ID | Task | Start | Finish |
| --- | --- | --- | --- |
| 71 | Planning détaillé (suite) | 2008-04-28 → 2008-04-28 10:48 | 2008-04-28 → 2008-04-28 10:48 |
| 72 | **Validation** | 2008-04-28 → 2008-04-28 10:48 | 2008-04-28 → 2008-04-28 16:48 |
| 73 | Optimiser le planning détaillé du prévu | 2008-04-28 → 2008-04-28 10:48 | 2008-04-28 → 2008-04-28 14:48 |
| 74 | Planning détaillé (suite) | 2008-04-28 → 2008-04-28 14:48 | 2008-04-28 → 2008-04-28 14:48 |
| 75 | Valider, communiquer et enregistrer le planning | 2008-04-28 → 2008-04-28 14:48 | 2008-04-28 → 2008-04-28 16:48 |
| 76 | Contrat de planning | 2008-04-28 → 2008-04-28 16:48 | 2008-04-28 → 2008-04-28 16:48 |
| 77 | **Piloter le projet** | 2008-04-28 → 2008-04-28 16:48 | 2008-04-29 → 2008-04-29 11:48 |
| 78 | **Lancement** | 2008-04-28 → 2008-04-28 16:48 | 2008-04-29 → 2008-04-29 11:48 |
| 79 | Lancer la réalisation | 2008-04-28 → 2008-04-28 16:48 | 2008-04-29 → 2008-04-29 09:48 |
| 80 | Journal du projet | 2008-04-29 → 2008-04-29 09:48 | 2008-04-29 → 2008-04-29 09:48 |
| 81 | Fiche de reporting | 2008-04-29 → 2008-04-29 09:48 | 2008-04-29 → 2008-04-29 09:48 |
| 82 | Mettre en œuvre le plan de communication | 2008-04-29 → 2008-04-29 09:48 | 2008-04-29 → 2008-04-29 11:48 |
| 83 | Plan de communication (suite) | 2008-04-29 → 2008-04-29 11:48 | 2008-04-29 → 2008-04-29 11:48 |
| 84 | **FABRICATION DU PRODUIT** | 2008-04-29 → 2008-04-29 11:48 | 2008-07-28 → 2008-07-28 11:48 |
| 85 | **Etude de la gestion des stocks** | 2008-04-29 → 2008-04-29 11:48 | 2008-05-05 → 2008-05-05 17:48 |
| 86 | **Etude opérationnelle** | 2008-04-29 → 2008-04-29 11:48 | 2008-05-01 → 2008-05-01 15:48 |
| 87 | Analyse de l'existant | 2008-04-29 → 2008-04-29 11:48 | 2008-04-30 → 2008-04-30 14:48 |
| 88 | Feuille d'analyse | 2008-04-30 → 2008-04-30 14:48 | 2008-04-30 → 2008-04-30 14:48 |
| 89 | Recherche des améliorations | 2008-04-30 → 2008-04-30 14:48 | 2008-05-01 → 2008-05-01 15:48 |
| 90 | Liste des améliorations | 2008-05-01 → 2008-05-01 15:48 | 2008-05-01 → 2008-05-01 15:48 |
| 91 | **Etude fonctionnelle** | 2008-04-29 → 2008-04-29 11:48 | 2008-05-05 → 2008-05-05 17:48 |
| 92 | Analyse de l'existant | 2008-04-29 → 2008-04-29 11:48 | 2008-04-30 → 2008-04-30 14:48 |
| 93 | Organigramme fonctionnel | 2008-05-01 → 2008-05-01 15:48 | 2008-05-01 → 2008-05-01 15:48 |
| 94 | Rédaction du cahier des charges | 2008-05-01 → 2008-05-01 15:48 | 2008-05-05 → 2008-05-05 17:48 |
| 95 | Cahier des charges | 2008-05-05 → 2008-05-05 17:48 | 2008-05-05 → 2008-05-05 17:48 |
| 96 | **Mise en place de la gestion des stocks** | 2008-05-05 → 2008-05-05 17:48 | 2008-06-23 → 2008-06-23 16:48 |
| 97 | **Recherche progiciels** | 2008-05-05 → 2008-05-05 17:48 | 2008-05-14 → 2008-05-14 16:48 |
| 98 | Recherche des prestataires | 2008-05-05 → 2008-05-05 17:48 | 2008-05-13 → 2008-05-13 15:48 |
| 99 | Liste des prestataires | 2008-05-13 → 2008-05-13 15:48 | 2008-05-13 → 2008-05-13 15:48 |
| 100 | Présélection des progiciels | 2008-05-13 → 2008-05-13 15:48 | 2008-05-14 → 2008-05-14 16:48 |
| 101 | Liste des logiciels | 2008-05-14 → 2008-05-14 16:48 | 2008-05-14 → 2008-05-14 16:48 |
| 102 | **Choix progiciels** | 2008-05-14 → 2008-05-14 16:48 | 2008-05-19 → 2008-05-19 09:48 |
| 103 | Réalisation d'un dossier de choix | 2008-05-14 → 2008-05-14 16:48 | 2008-05-15 → 2008-05-15 17:48 |
| 104 | Choix du progiciel | 2008-05-15 → 2008-05-15 17:48 | 2008-05-16 → 2008-05-16 14:48 |
| 105 | Dossier de choix | 2008-05-16 → 2008-05-16 14:48 | 2008-05-16 → 2008-05-16 14:48 |
| 106 | Passage de la commande | 2008-05-16 → 2008-05-16 14:48 | 2008-05-19 → 2008-05-19 09:48 |
| 107 | Bon de commande | 2008-05-19 → 2008-05-19 09:48 | 2008-05-19 → 2008-05-19 09:48 |
| 108 | **Mise en place** | 2008-05-16 → 2008-05-16 14:48 | 2008-05-23 → 2008-05-23 09:48 |
| 109 | Commande des matériels | 2008-05-16 → 2008-05-16 14:48 | 2008-05-19 → 2008-05-19 09:48 |
| 110 | Bon de commande | 2008-05-19 → 2008-05-19 09:48 | 2008-05-19 → 2008-05-19 09:48 |
| 111 | Vérification des matériels | 2008-05-19 → 2008-05-19 09:48 | 2008-05-20 → 2008-05-20 10:48 |
| 112 | PV de réception | 2008-05-20 → 2008-05-20 10:48 | 2008-05-20 → 2008-05-20 10:48 |
| 113 | Installation des matériels | 2008-05-20 → 2008-05-20 10:48 | 2008-05-21 → 2008-05-21 11:48 |
| 114 | Installation du réseau | 2008-05-20 → 2008-05-20 10:48 | 2008-05-21 → 2008-05-21 11:48 |
| 115 | Partie matérielle installée | 2008-05-21 → 2008-05-21 11:48 | 2008-05-21 → 2008-05-21 11:48 |
| 116 | Installation des systèmes d'exploitation | 2008-05-21 → 2008-05-21 11:48 | 2008-05-22 → 2008-05-22 14:48 |
| 117 | Installation du progiciel de gestion des stocks | 2008-05-22 → 2008-05-22 14:48 | 2008-05-23 → 2008-05-23 09:48 |
| 118 | Partie logicielle installée | 2008-05-23 → 2008-05-23 09:48 | 2008-05-23 → 2008-05-23 09:48 |
| 119 | **Paramétrage** | 2008-05-16 → 2008-05-16 14:48 | 2008-05-28 → 2008-05-28 14:48 |
| 120 | Définition des paramètres | 2008-05-16 → 2008-05-16 14:48 | 2008-05-20 → 2008-05-20 16:48 |
| 121 | Paramétrage du logiciel | 2008-05-20 → 2008-05-20 16:48 | 2008-05-28 → 2008-05-28 14:48 |
| 122 | Logiciel paramétré | 2008-05-28 → 2008-05-28 14:48 | 2008-05-28 → 2008-05-28 14:48 |
| 123 | **Tests** | 2008-05-16 → 2008-05-16 14:48 | 2008-06-05 → 2008-06-05 10:48 |
| 124 | Définition des données de test | 2008-05-16 → 2008-05-16 14:48 | 2008-05-19 → 2008-05-19 15:48 |
| 125 | Tests du logiciel | 2008-05-28 → 2008-05-28 14:48 | 2008-06-05 → 2008-06-05 10:48 |
| 126 | Logiciel testé | 2008-06-05 → 2008-06-05 10:48 | 2008-06-05 → 2008-06-05 10:48 |
| 127 | **Recette** | 2008-06-05 → 2008-06-05 10:48 | 2008-06-16 → 2008-06-16 09:48 |
| 128 | Effectuer la recette | 2008-06-05 → 2008-06-05 10:48 | 2008-06-06 → 2008-06-06 11:48 |
| 129 | PV de recette | 2008-06-06 → 2008-06-06 11:48 | 2008-06-06 → 2008-06-06 11:48 |
| 130 | Mettre en production | 2008-06-06 → 2008-06-06 11:48 | 2008-06-16 → 2008-06-16 09:48 |
| 131 | Logiciel opérationnel | 2008-06-16 → 2008-06-16 09:48 | 2008-06-16 → 2008-06-16 09:48 |
| 132 | **Formation** | 2008-06-16 → 2008-06-16 09:48 | 2008-06-23 → 2008-06-23 16:48 |
| 133 | Former les utilisateurs | 2008-06-16 → 2008-06-16 09:48 | 2008-06-23 → 2008-06-23 16:48 |
| 134 | Utilisateurs formés | 2008-06-23 → 2008-06-23 16:48 | 2008-06-23 → 2008-06-23 16:48 |
| 135 | **Etude du site internet** | 2008-05-05 → 2008-05-05 17:48 | 2008-05-22 → 2008-05-22 14:48 |
| 136 | **Définition fonctions** | 2008-05-05 → 2008-05-05 17:48 | 2008-05-13 → 2008-05-13 15:48 |
| 137 | Définir les fonctions | 2008-05-05 → 2008-05-05 17:48 | 2008-05-09 → 2008-05-09 11:48 |
| 138 | Rédiger le cahier des charges | 2008-05-09 → 2008-05-09 11:48 | 2008-05-13 → 2008-05-13 15:48 |
| 139 | Cahier des charges | 2008-05-13 → 2008-05-13 15:48 | 2008-05-13 → 2008-05-13 15:48 |
| 140 | **Définition interfaces** | 2008-05-13 → 2008-05-13 15:48 | 2008-05-22 → 2008-05-22 14:48 |

| ID | Task | Start | Finish | Duration | Total float | Other |
| --- | --- | --- | --- | --- | --- | --- |
| 141 | Faire les maquettes | 2008-05-13 → 2008-05-13 15:48 | 2008-05-21 → 2008-05-21 11:48 |  |  |  |
| 142 | Valider les maquettes | 2008-05-21 → 2008-05-21 11:48 | 2008-05-22 → 2008-05-22 14:48 |  |  |  |
| 143 | Maquettes validées | 2008-05-22 → 2008-05-22 14:48 | 2008-05-22 → 2008-05-22 14:48 |  |  |  |
| 144 | **Mise en place du site** | 2008-05-22 → 2008-05-22 14:48 | 2008-06-20 → 2008-06-20 09:48 |  |  |  |
| 145 | **Développements** | 2008-05-22 → 2008-05-22 14:48 | 2008-06-17 → 2008-06-17 16:48 |  |  |  |
| 146 | Définir le nombre de prototypes | 2008-05-22 → 2008-05-22 14:48 | 2008-05-23 → 2008-05-23 15:48 |  |  |  |
| 147 | Réaliser le prototype (n fois) | 2008-05-23 → 2008-05-23 15:48 | 2008-06-17 → 2008-06-17 16:48 |  |  |  |
| 148 | Tester le prototype (n fois) | 2008-05-23 → 2008-05-23 15:48 | 2008-06-17 → 2008-06-17 16:48 |  |  |  |
| 149 | Définir les améliorations (n fois) | 2008-05-23 → 2008-05-23 15:48 | 2008-06-17 → 2008-06-17 16:48 |  |  |  |
| 150 | Prototypes (n) | 2008-06-17 → 2008-06-17 16:48 | 2008-06-17 → 2008-06-17 16:48 |  |  |  |
| 151 | **Installation** | 2008-06-17 → 2008-06-17 16:48 | 2008-06-20 → 2008-06-20 09:48 |  |  |  |
| 152 | Réaliser l'installation avec le prestataire d'accès | 2008-06-17 → 2008-06-17 16:48 | 2008-06-20 → 2008-06-20 09:48 |  |  |  |
| 153 | Accès internet | 2008-06-20 → 2008-06-20 09:48 | 2008-06-20 → 2008-06-20 09:48 |  |  |  |
| 154 | **Mise en production du site** | 2008-06-20 → 2008-06-20 09:48 | 2008-07-28 → 2008-07-28 11:48 |  |  |  |
| 155 | **Test finaux** | 2008-06-20 → 2008-06-20 09:48 | 2008-07-07 → 2008-07-07 14:48 |  |  |  |
| 156 | Faire les tests finaux | 2008-06-20 → 2008-06-20 09:48 | 2008-07-07 → 2008-07-07 14:48 |  |  |  |
| 157 | **Recette** | 2008-07-07 → 2008-07-07 14:48 | 2008-07-10 → 2008-07-10 17:48 |  |  |  |
| 158 | Effectuer la recette | 2008-07-07 → 2008-07-07 14:48 | 2008-07-10 → 2008-07-10 17:48 |  |  |  |
| 159 | PV de recette | 2008-07-10 → 2008-07-10 17:48 | 2008-07-10 → 2008-07-10 17:48 |  |  |  |
| 160 | **Formation** | 2008-07-10 → 2008-07-10 17:48 | 2008-07-28 → 2008-07-28 11:48 |  |  |  |
| 161 | Elaborer la doc utilisateurs | 2008-07-10 → 2008-07-10 17:48 | 2008-07-18 → 2008-07-18 15:48 |  |  |  |
| 162 | Doc utilisateurs | 2008-07-18 → 2008-07-18 15:48 | 2008-07-18 → 2008-07-18 15:48 |  |  |  |
| 163 | Former les utilisateurs | 2008-07-18 → 2008-07-18 15:48 | 2008-07-28 → 2008-07-28 11:48 |  |  |  |
| 164 | Utilisateurs formés | 2008-07-28 → 2008-07-28 11:48 | 2008-07-28 → 2008-07-28 11:48 |  |  |  |
| 165 | **GESTION DU PROJET** | 2008-04-17 → 2008-04-17 08:00 | 2008-08-01 → 2008-08-01 17:48 |  |  |  |
| 166 | **Piloter le projet** | 2008-04-17 → 2008-04-17 08:00 | 2008-04-18 → 2008-08-01 09:15 (+105d) | 1d → 66.53d | 66.35d → 0.82d |  |
| 167 | **Réalisation** | 2008-04-17 → 2008-04-17 08:00 | 2008-04-18 → 2008-08-01 09:15 (+105d) | 1d → 66.53d | 66.35d → 0.82d |  |
| 168 | **Piloter la réalisation du produit** | 2008-04-17 → 2008-04-17 08:00 | 2008-04-18 → 2008-08-01 09:15 (+105d) | 1d → 66.53d | 66.35d → 0.82d |  |
| 398 | Faire un bilan intermédiaire | 2008-04-17 → 2008-05-15 09:00 (+28d) | 2008-04-18 → 2008-05-16 10:00 (+28d) |  | 66.35d → 48.85d | constraint none → start no earlier than 2008-05-15 09:00 |
| 399 | Bilan intermédiaire | 2008-04-17 → 2008-05-16 10:00 (+29d) | 2008-04-17 → 2008-05-16 10:00 (+29d) |  | 67.35d → 48.85d | constraint none → start no earlier than 2008-05-16 10:00 |
| 406 | **Faire le bilan du projet** | 2008-07-28 → 2008-07-28 11:48 | 2008-08-01 → 2008-08-01 17:48 |  |  |  |
| 407 | **Promotion** | 2008-07-28 → 2008-07-28 11:48 | 2008-07-29 → 2008-07-29 14:48 |  |  |  |
| 408 | Vendre le projet | 2008-07-28 → 2008-07-28 11:48 | 2008-07-29 → 2008-07-29 14:48 |  |  |  |
| 409 | Présentation de projet | 2008-07-29 → 2008-07-29 14:48 | 2008-07-29 → 2008-07-29 14:48 |  |  |  |
| 410 | **Désengagement** | 2008-07-29 → 2008-07-29 14:48 | 2008-07-30 → 2008-07-30 15:48 |  |  |  |
| 411 | Mettre un terme à l'engagement contractuel | 2008-07-29 → 2008-07-29 14:48 | 2008-07-30 → 2008-07-30 15:48 |  |  |  |
| 412 | Note de désengagement | 2008-07-30 → 2008-07-30 15:48 | 2008-07-30 → 2008-07-30 15:48 |  |  |  |
| 413 | **Capitalisation** | 2008-07-30 → 2008-07-30 15:48 | 2008-08-01 → 2008-08-01 17:48 |  |  |  |
| 414 | Organiser les réunions de débriefing | 2008-07-30 → 2008-07-30 15:48 | 2008-07-31 → 2008-07-31 16:48 |  |  |  |
| 415 | Bilan final de projet | 2008-07-31 → 2008-07-31 16:48 | 2008-07-31 → 2008-07-31 16:48 |  |  |  |
| 416 | Archiver les dossiers du projet | 2008-07-31 → 2008-07-31 16:48 | 2008-08-01 → 2008-08-01 17:48 |  |  |  |
| 417 | Note d’archivage | 2008-08-01 → 2008-08-01 17:48 | 2008-08-01 → 2008-08-01 17:48 |  |  |  |
| 418 | Fin du projet | 2008-08-01 → 2008-08-01 17:48 | 2008-08-01 → 2008-08-01 17:48 |  |  |  |

## Version 3 (saved 2008-06-17, file 20-Planning détaillé-Polo.mpp)

Last finish 2008-08-01 → 2008-09-18 (+48d).

Changed:

| ID | Task | Start | Finish | Duration | Total float | Other |
| --- | --- | --- | --- | --- | --- | --- |
| 2 | **GESTION DU PROJET** |  | 2008-04-29 11:48 → 2008-04-30 09:12 (+1d) | 7.35d → 7.9d |  |  |
| 5 | Réceptionner la demande de projet du commanditaire |  |  |  |  | resources none → Henri |
| 7 | Examiner la demande du commanditaire |  |  |  |  | resources none → Karen |
| 10 | Officialiser la nomination du chef de projet |  |  |  |  | resources none → Karen [50%]; Henri |
| 14 | Définir l’objet précis du projet |  |  |  | 65.35d → 95.03d | resources none → Karen [50%] |
| 16 | Lister les motifs et définir le contexte |  |  |  |  | resources none → Karen [50%] |
| 19 | Définir les objectifs de qualité |  | 2008-04-22 16:00 → 2008-04-22 18:00 | 0.25d → 0.5d | 64.1d → 93.53d | resources none → Karen [75%]; Henri [75%] |
| 20 | Note de cadrage (suite) | 2008-04-22 16:00 → 2008-04-22 18:00 | 2008-04-22 16:00 → 2008-04-22 18:00 |  | 64.1d → 93.53d |  |
| 21 | Définir les objectifs de temps |  |  |  | 64.1d → 93.78d | resources none → Karen [50%] |
| 23 | Définir les objectifs de charge et de coûts |  |  |  | 63.85d → 93.53d | resources none → Karen [50%] |
| 26 | Définir les objectifs de communication |  |  |  | 63.85d → 93.53d | resources none → Christophe |
| 28 | Définir les objectifs complémentaires |  |  |  |  | resources none → Karen [12.5%]; Henri [12.5%] |
| 30 | Préciser les contraintes sur objectifs |  |  |  |  | resources none → Karen [12.5%]; Henri [12.5%] |
| 32 | Vérifier l’adéquation entre les objectifs |  |  |  |  | resources none → Karen [50%] |
| 35 | Identifier le périmètre et les acteurs |  |  |  |  | resources none → Karen [50%] |
| 37 | Définir la structure choisie pour la gestion du projet |  |  |  |  | resources none → Karen [25%] |
| 39 | Définir les rôles des acteurs dans les structures projets |  |  |  |  | resources none → Karen [25%] |
| 43 | Identifier, analyser et gérer les freins |  |  |  |  | resources none → Karen [50%]; Henri [50%] |
| 45 | Identifier, analyser et gérer les facilitants |  |  |  | 62.1d → 91.78d | resources none → Karen [25%]; Henri [25%] |
| 48 | Choisir une méthode et structurer la réal. du produit |  |  |  | 62.1d → 91.78d | resources none → Claudio [50%]; François [50%] |
| 51 | Définir les axes, cibles et moyens de communication |  |  |  |  | resources none → Christophe |
| 55 | Rédiger la note de cadrage |  |  |  |  | resources none → Henri [50%]; Karen [50%] |
| 57 | **Planifier le projet** |  | 2008-04-28 16:48 → 2008-04-29 14:12 (+1d) | 1.1d → 1.65d |  |  |
| 58 | **Planification détallée** |  | 2008-04-28 10:48 → 2008-04-28 17:12 | 0.6d → 1.15d |  |  |
| 59 | Définir l’environnement de planification |  |  |  |  | resources none → Karen [62.5%] |
| 61 | Ordonner la liste des tâches de fabrication du produit |  | 2008-04-25 16:36 → 2008-04-25 17:48 | 0.1d → 0.25d |  | resources none → Karen [50%]; Claudio [50%]; François [50%] |
| 62 | Organigramme des tâches | 2008-04-25 16:36 → 2008-04-25 17:48 | 2008-04-25 16:36 → 2008-04-25 17:48 |  |  |  |
| 63 | Affecter des durées ou des charges aux tâches | 2008-04-25 16:36 → 2008-04-25 17:48 | 2008-04-25 17:24 → 2008-04-28 09:36 (+3d) |  |  | resources none → Karen [62.5%] |
| 64 | Planning détaillé | 2008-04-25 17:24 → 2008-04-28 09:36 (+3d) | 2008-04-25 17:24 → 2008-04-28 09:36 (+3d) |  |  |  |
| 65 | Définir les liens entre les tâches | 2008-04-25 17:24 → 2008-04-28 09:36 (+3d) | 2008-04-28 09:12 → 2008-04-28 10:24 |  |  | resources none → Karen [31.2%] |
| 66 | Planning détaillé (suite) | 2008-04-28 09:12 → 2008-04-28 10:24 | 2008-04-28 09:12 → 2008-04-28 10:24 |  |  |  |
| 67 | Intégrer les tâches de gestion de projet | 2008-04-28 09:12 → 2008-04-28 10:24 | 2008-04-28 10:00 → 2008-04-28 11:12 |  |  | resources none → Karen [12.5%] |
| 68 | Planning détaillé (suite) | 2008-04-28 10:00 → 2008-04-28 11:12 | 2008-04-28 10:00 → 2008-04-28 11:12 |  |  |  |
| 69 | Affecter les ressources sur les tâches | 2008-04-28 10:00 → 2008-04-28 11:12 | 2008-04-28 10:48 → 2008-04-28 17:12 | 0.1d → 0.5d |  | resources none → Karen [50%] |
| 70 | Tableau des ressources | 2008-04-28 10:48 → 2008-04-28 17:12 | 2008-04-28 10:48 → 2008-04-28 17:12 |  |  |  |
| 71 | Planning détaillé (suite) | 2008-04-28 10:48 → 2008-04-28 17:12 | 2008-04-28 10:48 → 2008-04-28 17:12 |  |  |  |
| 72 | **Validation** | 2008-04-28 10:48 → 2008-04-28 17:12 | 2008-04-28 16:48 → 2008-04-29 14:12 (+1d) |  |  |  |
| 73 | Optimiser le planning détaillé du prévu | 2008-04-28 10:48 → 2008-04-28 17:12 | 2008-04-28 14:48 → 2008-04-29 10:12 (+1d) |  |  | resources none → Karen [50%]; Claudio [50%]; François [50%] |
| 74 | Planning détaillé (suite) | 2008-04-28 14:48 → 2008-04-29 10:12 (+1d) | 2008-04-28 14:48 → 2008-04-29 10:12 (+1d) |  |  |  |
| 75 | Valider, communiquer et enregistrer le planning | 2008-04-28 14:48 → 2008-04-29 10:12 (+1d) | 2008-04-28 16:48 → 2008-04-29 14:12 (+1d) |  |  | resources none → Karen [50%]; Christophe [50%] |
| 76 | Contrat de planning | 2008-04-28 16:48 → 2008-04-29 14:12 (+1d) | 2008-04-28 16:48 → 2008-04-29 14:12 (+1d) |  |  |  |
| 77 | **Piloter le projet** | 2008-04-28 16:48 → 2008-04-29 14:12 (+1d) | 2008-04-29 11:48 → 2008-04-30 09:12 (+1d) |  |  |  |
| 78 | **Lancement** | 2008-04-28 16:48 → 2008-04-29 14:12 (+1d) | 2008-04-29 11:48 → 2008-04-30 09:12 (+1d) |  |  |  |
| 79 | Lancer la réalisation | 2008-04-28 16:48 → 2008-04-29 14:12 (+1d) | 2008-04-29 09:48 → 2008-04-29 16:12 |  |  | resources none → Karen [25%]; Christophe [25%] |
| 80 | Journal du projet | 2008-04-29 09:48 → 2008-04-29 16:12 | 2008-04-29 09:48 → 2008-04-29 16:12 |  |  |  |
| 81 | Fiche de reporting | 2008-04-29 09:48 → 2008-04-29 16:12 | 2008-04-29 09:48 → 2008-04-29 16:12 |  |  |  |
| 82 | Mettre en œuvre le plan de communication | 2008-04-29 09:48 → 2008-04-29 16:12 | 2008-04-29 11:48 → 2008-04-30 09:12 (+1d) |  |  | resources none → Christophe |
| 83 | Plan de communication (suite) | 2008-04-29 11:48 → 2008-04-30 09:12 (+1d) | 2008-04-29 11:48 → 2008-04-30 09:12 (+1d) |  |  |  |
| 84 | **FABRICATION DU PRODUIT** | 2008-04-29 11:48 → 2008-04-30 09:12 (+1d) | 2008-07-28 11:48 → 2008-09-12 11:12 (+46d) | 56d → 85.13d |  |  |
| 85 | **Etude de la gestion des stocks** | 2008-04-29 11:48 → 2008-04-30 09:12 (+1d) | 2008-05-05 17:48 → 2008-05-07 16:12 (+2d) | 4d → 5d |  |  |
| 86 | **Etude opérationnelle** | 2008-04-29 11:48 → 2008-04-30 09:12 (+1d) | 2008-05-01 15:48 → 2008-05-02 11:12 (+1d) |  |  |  |
| 87 | Analyse de l'existant | 2008-04-29 11:48 → 2008-04-30 09:12 (+1d) | 2008-04-30 14:48 → 2008-05-01 10:12 (+1d) |  |  | resources none → Patrick [50%] |
| 88 | Feuille d'analyse | 2008-04-30 14:48 → 2008-05-01 10:12 (+1d) | 2008-04-30 14:48 → 2008-05-01 10:12 (+1d) |  |  |  |
| 89 | Recherche des améliorations | 2008-04-30 14:48 → 2008-05-01 10:12 (+1d) | 2008-05-01 15:48 → 2008-05-02 11:12 (+1d) |  |  | resources none → Patrick [50%] |
| 90 | Liste des améliorations | 2008-05-01 15:48 → 2008-05-02 11:12 (+1d) | 2008-05-01 15:48 → 2008-05-02 11:12 (+1d) |  |  |  |
| 91 | **Etude fonctionnelle** | 2008-04-29 11:48 → 2008-04-30 09:12 (+1d) | 2008-05-05 17:48 → 2008-05-07 16:12 (+2d) | 4d → 5d |  |  |
| 92 | Analyse de l'existant | 2008-04-29 11:48 → 2008-04-30 09:12 (+1d) | 2008-04-30 14:48 → 2008-05-01 10:12 (+1d) |  |  | resources none → Henri [50%] |
| 93 | Organigramme fonctionnel | 2008-05-01 15:48 → 2008-05-02 11:12 (+1d) | 2008-05-01 15:48 → 2008-05-02 11:12 (+1d) |  |  |  |
| 94 | Rédaction du cahier des charges | 2008-05-01 15:48 → 2008-05-02 11:12 (+1d) | 2008-05-05 17:48 → 2008-05-07 16:12 (+2d) |  |  | resources none → Henri [50%] |
| 95 | Cahier des charges | 2008-05-05 17:48 → 2008-05-07 16:12 (+2d) | 2008-05-05 17:48 → 2008-05-07 16:12 (+2d) |  |  |  |
| 96 | **Mise en place de la gestion des stocks** | 2008-05-05 17:48 → 2008-05-07 16:12 (+2d) | 2008-06-23 16:48 → 2008-07-28 17:09 (+35d) | 30.5d → 50.87d | 25.5d → 33.26d |  |
| 97 | **Recherche progiciels** | 2008-05-05 17:48 → 2008-05-07 16:12 (+2d) | 2008-05-14 16:48 → 2008-05-16 15:12 (+2d) |  | 25.5d → 33.26d |  |
| 98 | Recherche des prestataires | 2008-05-05 17:48 → 2008-05-07 16:12 (+2d) | 2008-05-13 15:48 → 2008-05-15 14:12 (+2d) |  | 25.5d → 33.26d | resources none → Claudio [20%] |
| 99 | Liste des prestataires | 2008-05-13 15:48 → 2008-05-15 14:12 (+2d) | 2008-05-13 15:48 → 2008-05-15 14:12 (+2d) |  | 25.5d → 33.26d |  |
| 100 | Présélection des progiciels | 2008-05-13 15:48 → 2008-05-15 14:12 (+2d) | 2008-05-14 16:48 → 2008-05-16 15:12 (+2d) |  | 25.5d → 33.26d | resources none → Claudio [50%] |
| 101 | Liste des logiciels | 2008-05-14 16:48 → 2008-05-16 15:12 (+2d) | 2008-05-14 16:48 → 2008-05-16 15:12 (+2d) |  | 25.5d → 33.26d |  |
| 102 | **Choix progiciels** | 2008-05-14 16:48 → 2008-05-16 15:12 (+2d) | 2008-05-19 09:48 → 2008-05-20 15:12 (+1d) | 2d → 1.75d | 25.5d → 33.26d |  |
| 103 | Réalisation d'un dossier de choix | 2008-05-14 16:48 → 2008-05-16 15:12 (+2d) | 2008-05-15 17:48 → 2008-05-19 16:12 (+4d) |  | 25.5d → 33.26d | resources none → Claudio [50%] |
| 104 | Choix du progiciel | 2008-05-15 17:48 → 2008-05-19 16:12 (+4d) | 2008-05-16 14:48 → 2008-05-20 09:12 (+4d) | 0.5d → 0.25d | 25.5d → 33.26d | resources none → Claudio [50%]; Henri; Patrick |
| 105 | Dossier de choix | 2008-05-16 14:48 → 2008-05-20 09:12 (+4d) | 2008-05-16 14:48 → 2008-05-20 09:12 (+4d) |  | 25.5d → 33.26d |  |

| ID | Task | Start | Finish | Duration | Total float | Predecessors | Other |
| --- | --- | --- | --- | --- | --- | --- | --- |
| 106 | Passage de la commande | 2008-05-16 14:48 → 2008-05-20 09:12 (+4d) | 2008-05-19 09:48 → 2008-05-20 15:12 (+1d) |  | 48d → 76.38d |  | resources none → Henri |
| 107 | Bon de commande | 2008-05-19 09:48 → 2008-05-20 15:12 (+1d) | 2008-05-19 09:48 → 2008-05-20 15:12 (+1d) |  | 48d → 76.38d |  |  |
| 108 | **Mise en place** | 2008-05-16 14:48 → 2008-05-20 09:12 (+4d) | 2008-05-23 09:48 → 2008-06-23 16:09 (+31d) | 4d → 21.62d | 44.5d → 55.26d |  |  |
| 109 | Commande des matériels | 2008-05-16 14:48 → 2008-05-20 09:12 (+4d) | 2008-05-19 09:48 → 2008-05-20 15:12 (+1d) |  | 44.5d → 55.26d |  | resources none → Claudio [50%] |
| 110 | Bon de commande | 2008-05-19 09:48 → 2008-05-20 15:12 (+1d) | 2008-05-19 09:48 → 2008-05-20 15:12 (+1d) |  | 44.5d → 55.26d |  |  |
| 111 | Vérification des matériels | 2008-05-19 09:48 → 2008-05-20 15:12 (+1d) | 2008-05-20 10:48 → 2008-05-21 16:12 (+1d) |  | 44.5d → 55.26d |  | resources none → Programmeur 1 |
| 112 | PV de réception | 2008-05-20 10:48 → 2008-05-21 16:12 (+1d) | 2008-05-20 10:48 → 2008-05-21 16:12 (+1d) |  | 44.5d → 55.26d |  |  |
| 113 | Installation des matériels | 2008-05-20 10:48 → 2008-05-21 16:12 (+1d) | 2008-05-21 11:48 → 2008-06-09 11:27 (+19d) |  | 44.5d → 55.26d |  | resources none → Programmeur 2 |
| 114 | Installation du réseau | 2008-05-20 10:48 → 2008-05-21 16:12 (+1d) | 2008-05-21 11:48 → 2008-05-26 09:27 (+5d) | 1d → 2d | 44.5d → 64.26d |  | resources none → Claudio |
| 115 | Partie matérielle installée | 2008-05-21 11:48 → 2008-06-09 11:27 (+19d) | 2008-05-21 11:48 → 2008-06-09 11:27 (+19d) |  | 44.5d → 55.26d |  |  |
| 116 | Installation des systèmes d'exploitation | 2008-05-21 11:48 → 2008-06-09 11:27 (+19d) | 2008-05-22 14:48 → 2008-06-11 15:42 (+20d) | 1d → 2d | 44.5d → 55.26d |  | resources none → Claudio |
| 117 | Installation du progiciel de gestion des stocks | 2008-05-22 14:48 → 2008-06-11 15:42 (+20d) | 2008-05-23 09:48 → 2008-06-23 16:09 (+31d) | 0.5d → 1d | 44.5d → 55.26d |  | resources none → Programmeur 2 [50%] |
| 118 | Partie logicielle installée | 2008-05-23 09:48 → 2008-06-23 16:09 (+31d) | 2008-05-23 09:48 → 2008-06-23 16:09 (+31d) |  | 44.5d → 55.26d |  |  |
| 119 | **Paramétrage** | 2008-05-16 14:48 → 2008-05-20 09:12 (+4d) | 2008-05-28 14:48 → 2008-06-19 17:57 (+22d) | 7d → 20.09d | 25.5d → 33.26d |  |  |
| 120 | Définition des paramètres | 2008-05-16 14:48 → 2008-05-20 09:12 (+4d) | 2008-05-20 16:48 → 2008-05-22 11:12 (+2d) |  | 25.5d → 33.26d |  | resources none → Patrick [25%] |
| 121 | Paramétrage du logiciel | 2008-05-20 16:48 → 2008-05-22 11:12 (+2d) | 2008-05-28 14:48 → 2008-06-19 17:57 (+22d) | 5d → 14.03d | 25.5d → 33.26d |  | resources none → Programmeur 2 [80%]; Machine de développement 3 |
| 122 | Logiciel paramétré | 2008-05-28 14:48 → 2008-06-19 17:57 (+22d) | 2008-05-28 14:48 → 2008-06-19 17:57 (+22d) |  | 41.5d → 56.78d |  |  |
| 123 | **Tests** | 2008-05-16 14:48 → 2008-05-20 09:12 (+4d) | 2008-06-05 10:48 → 2008-06-24 17:09 (+19d) | 12d → 22.62d | 25.5d → 33.26d |  |  |
| 124 | Définition des données de test | 2008-05-16 14:48 → 2008-05-20 09:12 (+4d) | 2008-05-19 15:48 → 2008-05-22 11:12 (+3d) | 1d → 2d | 31.5d → 51.35d |  | resources none → Patrick [50%] |
| 125 | Tests du logiciel | 2008-05-28 14:48 → 2008-06-19 17:57 (+22d) | 2008-06-05 10:48 → 2008-06-24 17:09 (+19d) | 5d → 2.52d | 25.5d → 33.26d |  | resources none → Patrick [40%]; Programmeur 2 |
| 126 | Logiciel testé | 2008-06-05 10:48 → 2008-06-24 17:09 (+19d) | 2008-06-05 10:48 → 2008-06-24 17:09 (+19d) |  | 25.5d → 33.26d |  |  |
| 127 | **Recette** | 2008-06-05 10:48 → 2008-06-24 17:09 (+19d) | 2008-06-16 09:48 → 2008-07-11 14:09 (+25d) | 6d → 11d | 25.5d → 33.26d |  |  |
| 128 | Effectuer la recette | 2008-06-05 10:48 → 2008-06-24 17:09 (+19d) | 2008-06-06 11:48 → 2008-06-26 09:09 (+20d) |  | 25.5d → 33.26d |  | resources none → Henri |
| 129 | PV de recette | 2008-06-06 11:48 → 2008-06-26 09:09 (+20d) | 2008-06-06 11:48 → 2008-06-26 09:09 (+20d) |  | 25.5d → 33.26d |  |  |
| 130 | Mettre en production | 2008-06-06 11:48 → 2008-06-26 09:09 (+20d) | 2008-06-16 09:48 → 2008-07-11 14:09 (+25d) | 5d → 10d | 25.5d → 33.26d |  | resources none → Programmeur 2 [20%] |
| 131 | Logiciel opérationnel | 2008-06-16 09:48 → 2008-07-11 14:09 (+25d) | 2008-06-16 09:48 → 2008-07-11 14:09 (+25d) |  | 25.5d → 33.26d |  |  |
| 132 | **Formation** | 2008-06-16 09:48 → 2008-07-11 14:09 (+25d) | 2008-06-23 16:48 → 2008-07-28 17:09 (+35d) | 5d → 10d | 25.5d → 33.26d |  |  |
| 133 | Former les utilisateurs | 2008-06-16 09:48 → 2008-07-11 14:09 (+25d) | 2008-06-23 16:48 → 2008-07-28 17:09 (+35d) | 5d → 10d | 25.5d → 33.26d |  | resources none → Programmeur 2 [40%] |
| 134 | Utilisateurs formés | 2008-06-23 16:48 → 2008-07-28 17:09 (+35d) | 2008-06-23 16:48 → 2008-07-28 17:09 (+35d) |  | 25.5d → 33.26d |  |  |
| 135 | **Etude du site internet** | 2008-05-05 17:48 → 2008-05-07 16:12 (+2d) | 2008-05-22 14:48 → 2008-05-27 16:12 (+5d) | 11d → 12.25d |  |  |  |
| 136 | **Définition fonctions** | 2008-05-05 17:48 → 2008-05-07 16:12 (+2d) | 2008-05-13 15:48 → 2008-05-15 14:12 (+2d) |  |  |  |  |
| 137 | Définir les fonctions | 2008-05-05 17:48 → 2008-05-07 16:12 (+2d) | 2008-05-09 11:48 → 2008-05-13 10:12 (+4d) |  |  |  | resources none → Henri [33.3%] |
| 138 | Rédiger le cahier des charges | 2008-05-09 11:48 → 2008-05-13 10:12 (+4d) | 2008-05-13 15:48 → 2008-05-15 14:12 (+2d) |  |  |  | resources none → Henri [50%] |
| 139 | Cahier des charges | 2008-05-13 15:48 → 2008-05-15 14:12 (+2d) | 2008-05-13 15:48 → 2008-05-15 14:12 (+2d) |  |  |  |  |
| 140 | **Définition interfaces** | 2008-05-13 15:48 → 2008-05-15 14:12 (+2d) | 2008-05-22 14:48 → 2008-05-27 16:12 (+5d) | 6d → 7.25d |  |  |  |
| 141 | Faire les maquettes | 2008-05-13 15:48 → 2008-05-15 14:12 (+2d) | 2008-05-21 11:48 → 2008-05-26 15:12 (+5d) | 5d → 6.25d |  |  | resources none → François [80%] |
| 142 | Valider les maquettes | 2008-05-21 11:48 → 2008-05-26 15:12 (+5d) | 2008-05-22 14:48 → 2008-05-27 16:12 (+5d) |  |  |  | resources none → Henri [50%] |
| 143 | Maquettes validées | 2008-05-22 14:48 → 2008-05-27 16:12 (+5d) | 2008-05-22 14:48 → 2008-05-27 16:12 (+5d) |  |  |  |  |
| 144 | **Mise en place du site** | 2008-05-22 14:48 → 2008-05-27 16:12 (+5d) | 2008-06-20 09:48 → 2008-08-07 09:12 (+48d) | 18d → 44.88d |  |  |  |
| 145 | **Développements** | 2008-05-22 14:48 → 2008-05-27 16:12 (+5d) | 2008-06-17 16:48 → 2008-07-29 10:12 (+42d) | 16d → 38.88d |  |  |  |
| 146 | Définir le nombre de prototypes | 2008-05-22 14:48 → 2008-05-27 16:12 (+5d) | 2008-05-23 15:48 → 2008-05-28 17:12 (+5d) |  |  |  | resources none → Henri [50%]; François |
| 147 | Réaliser le prototype (n fois) | 2008-05-23 15:48 → 2008-05-28 17:12 (+5d) | 2008-06-17 16:48 → 2008-07-04 10:27 (+17d) |  | 0d → 14.84d |  | resources none → Infographiste [53.3%]; Programmeur 1; Machine de développement 1; Machine de développement 2 |
| 148 | Tester le prototype (n fois) | 2008-05-23 15:48 → 2008-06-10 17:12 (+18d) | 2008-06-17 16:48 → 2008-07-29 10:12 (+42d) | 15d → 23.47d |  |  | resources none → Infographiste [53.3%]; Programmeur 1; Machine de développement 1; Machine de développement 2 |
| 149 | Définir les améliorations (n fois) | 2008-05-23 15:48 → 2008-05-28 17:12 (+5d) | 2008-06-17 16:48 → 2008-07-04 11:57 (+17d) | 15d → 22.47d | 0d → 14.66d |  | resources none → Henri [53.3%]; Infographiste; Programmeur 2 |
| 150 | Prototypes (n) | 2008-06-17 16:48 → 2008-07-29 10:12 (+42d) | 2008-06-17 16:48 → 2008-07-29 10:12 (+42d) |  |  |  |  |
| 151 | **Installation** | 2008-06-17 16:48 → 2008-07-29 10:12 (+42d) | 2008-06-20 09:48 → 2008-08-07 09:12 (+48d) | 2d → 6d |  |  |  |
| 152 | Réaliser l'installation avec le prestataire d'accès | 2008-06-17 16:48 → 2008-07-29 10:12 (+42d) | 2008-06-20 09:48 → 2008-08-07 09:12 (+48d) | 2d → 6d |  |  | resources none → François [50%] |
| 153 | Accès internet | 2008-06-20 09:48 → 2008-08-07 09:12 (+48d) | 2008-06-20 09:48 → 2008-08-07 09:12 (+48d) |  |  |  |  |
| 154 | **Mise en production du site** | 2008-06-20 09:48 → 2008-08-07 09:12 (+48d) | 2008-07-28 11:48 → 2008-09-12 11:12 (+46d) |  |  |  |  |
| 155 | **Test finaux** | 2008-06-20 09:48 → 2008-08-07 09:12 (+48d) | 2008-07-07 14:48 → 2008-08-22 14:12 (+46d) |  |  |  |  |
| 156 | Faire les tests finaux | 2008-06-20 09:48 → 2008-08-07 09:12 (+48d) | 2008-07-07 14:48 → 2008-08-22 14:12 (+46d) |  |  |  | resources none → Programmeur 2 [80%]; Machine de développement 3 [80%] |
| 157 | **Recette** | 2008-07-07 14:48 → 2008-08-22 14:12 (+46d) | 2008-07-10 17:48 → 2008-08-27 17:12 (+48d) |  |  |  |  |
| 158 | Effectuer la recette | 2008-07-07 14:48 → 2008-08-22 14:12 (+46d) | 2008-07-10 17:48 → 2008-08-27 17:12 (+48d) |  |  |  | resources none → Henri [33.3%] |
| 159 | PV de recette | 2008-07-10 17:48 → 2008-08-27 17:12 (+48d) | 2008-07-10 17:48 → 2008-08-27 17:12 (+48d) |  |  |  |  |
| 160 | **Formation** | 2008-07-10 17:48 → 2008-08-27 17:12 (+48d) | 2008-07-28 11:48 → 2008-09-12 11:12 (+46d) |  |  |  |  |
| 161 | Elaborer la doc utilisateurs | 2008-07-10 17:48 → 2008-08-27 17:12 (+48d) | 2008-07-18 15:48 → 2008-09-04 15:12 (+48d) |  |  |  | resources none → François [80%] |
| 162 | Doc utilisateurs | 2008-07-18 15:48 → 2008-09-04 15:12 (+48d) | 2008-07-18 15:48 → 2008-09-04 15:12 (+48d) |  |  |  |  |
| 163 | Former les utilisateurs | 2008-07-18 15:48 → 2008-09-04 15:12 (+48d) | 2008-07-28 11:48 → 2008-09-12 11:12 (+46d) |  |  |  | resources none → Programmeur 2 [80%] |
| 164 | Utilisateurs formés | 2008-07-28 11:48 → 2008-09-12 11:12 (+46d) | 2008-07-28 11:48 → 2008-09-12 11:12 (+46d) |  |  |  |  |
| 165 | **GESTION DU PROJET** |  | 2008-08-01 17:48 → 2008-09-18 17:12 (+48d) | 67.35d → 97.03d |  |  |  |
| 166 | **Piloter le projet** |  | 2008-08-01 09:15 → 2008-09-15 14:12 (+45d) | 66.53d → 94.03d | 0.82d → 3d |  |  |
| 167 | **Réalisation** |  | 2008-08-01 09:15 → 2008-09-15 14:12 (+45d) | 66.53d → 94.03d | 0.82d → 3d |  |  |
| 168 | **Piloter la réalisation du produit** |  | 2008-08-01 09:15 → 2008-09-15 14:12 (+45d) | 66.53d → 94.03d | 0.82d → 3d |  |  |
| 398 | Faire un bilan intermédiaire |  |  |  | 48.85d → 78.53d |  | resources none → Karen [50%]; Henri [50%] |
| 399 | Bilan intermédiaire |  |  |  | 48.85d → 78.53d | none → 398 | constraint start no earlier than 2008-05-16 10:00 → none |
| 400 | Préparer la communication presse |  |  |  | 38.73d → 68.4d |  | resources none → Christophe [20%] |
| 401 | Envoyer communication presse |  |  |  | 22.6d → 52.28d |  | resources none → Christophe [25%] |
| 402 | Communication presse | 2008-07-28 11:48 → 2008-09-12 11:12 (+46d) | 2008-07-28 11:48 → 2008-09-12 11:12 (+46d) |  |  |  |  |
| 403 | Rédiger la communication clients |  |  |  | 22.6d → 52.28d |  | resources none → Henri [50%] |
| 404 | Envoyer la communication clients | 2008-07-28 11:48 → 2008-09-12 11:12 (+46d) | 2008-07-29 14:48 → 2008-09-15 14:12 (+48d) |  |  |  | resources none → Henri |

| ID | Task | Start | Finish | Other |
| --- | --- | --- | --- | --- |
| 405 | Communication clients | 2008-07-29 14:48 → 2008-09-15 14:12 (+48d) | 2008-07-29 14:48 → 2008-09-15 14:12 (+48d) |  |
| 406 | **Faire le bilan du projet** | 2008-07-28 11:48 → 2008-09-12 11:12 (+46d) | 2008-08-01 17:48 → 2008-09-18 17:12 (+48d) |  |
| 407 | **Promotion** | 2008-07-28 11:48 → 2008-09-12 11:12 (+46d) | 2008-07-29 14:48 → 2008-09-15 14:12 (+48d) |  |
| 408 | Vendre le projet | 2008-07-28 11:48 → 2008-09-12 11:12 (+46d) | 2008-07-29 14:48 → 2008-09-15 14:12 (+48d) | resources none → Karen [12.5%]; Henri [12.5%] |
| 409 | Présentation de projet | 2008-07-29 14:48 → 2008-09-15 14:12 (+48d) | 2008-07-29 14:48 → 2008-09-15 14:12 (+48d) |  |
| 410 | **Désengagement** | 2008-07-29 14:48 → 2008-09-15 14:12 (+48d) | 2008-07-30 15:48 → 2008-09-16 15:12 (+48d) |  |
| 411 | Mettre un terme à l'engagement contractuel | 2008-07-29 14:48 → 2008-09-15 14:12 (+48d) | 2008-07-30 15:48 → 2008-09-16 15:12 (+48d) | resources none → Karen [6.2%]; Henri [6.2%] |
| 412 | Note de désengagement | 2008-07-30 15:48 → 2008-09-16 15:12 (+48d) | 2008-07-30 15:48 → 2008-09-16 15:12 (+48d) |  |
| 413 | **Capitalisation** | 2008-07-30 15:48 → 2008-09-16 15:12 (+48d) | 2008-08-01 17:48 → 2008-09-18 17:12 (+48d) |  |
| 414 | Organiser les réunions de débriefing | 2008-07-30 15:48 → 2008-09-16 15:12 (+48d) | 2008-07-31 16:48 → 2008-09-17 16:12 (+48d) | resources none → Karen [50%]; Christophe; Claudio; François |
| 415 | Bilan final de projet | 2008-07-31 16:48 → 2008-09-17 16:12 (+48d) | 2008-07-31 16:48 → 2008-09-17 16:12 (+48d) |  |
| 416 | Archiver les dossiers du projet | 2008-07-31 16:48 → 2008-09-17 16:12 (+48d) | 2008-08-01 17:48 → 2008-09-18 17:12 (+48d) | resources none → Christophe [50%] |
| 417 | Note d’archivage | 2008-08-01 17:48 → 2008-09-18 17:12 (+48d) | 2008-08-01 17:48 → 2008-09-18 17:12 (+48d) |  |
| 418 | Fin du projet | 2008-08-01 17:48 → 2008-09-18 17:12 (+48d) | 2008-08-01 17:48 → 2008-09-18 17:12 (+48d) |  |

## Version 4 (saved 2008-06-17, file 20-Planning détaillé pour fiche 27-Polo.mpp)

Last finish 2008-09-18 → 2008-08-12 (-37d).

Changed:

| ID | Task | Start | Finish | Duration | Total float |
| --- | --- | --- | --- | --- | --- |
| 84 | **FABRICATION DU PRODUIT** |  | 2008-09-12 11:12 → 2008-08-06 09:12 (-37d) | 85.13d → 61.25d |  |
| 85 | **Etude de la gestion des stocks** |  | 2008-05-07 16:12 → 2008-05-06 15:12 (-1d) | 5d → 4d |  |
| 91 | **Etude fonctionnelle** |  | 2008-05-07 16:12 → 2008-05-06 15:12 (-1d) | 5d → 4d |  |
| 94 | Rédaction du cahier des charges |  | 2008-05-07 16:12 → 2008-05-06 15:12 (-1d) |  |  |
| 95 | Cahier des charges | 2008-05-07 16:12 → 2008-05-06 15:12 (-1d) | 2008-05-07 16:12 → 2008-05-06 15:12 (-1d) |  |  |
| 96 | **Mise en place de la gestion des stocks** | 2008-05-07 16:12 → 2008-05-06 15:12 (-1d) | 2008-07-28 17:09 → 2008-07-14 14:12 (-14d) | 50.87d → 42.75d | 33.26d → 18.5d |
| 97 | **Recherche progiciels** | 2008-05-07 16:12 → 2008-05-06 15:12 (-1d) | 2008-05-16 15:12 → 2008-05-15 14:12 (-1d) |  | 33.26d → 18.5d |
| 98 | Recherche des prestataires | 2008-05-07 16:12 → 2008-05-06 15:12 (-1d) | 2008-05-15 14:12 → 2008-05-14 11:12 (-1d) |  | 33.26d → 18.5d |
| 99 | Liste des prestataires | 2008-05-15 14:12 → 2008-05-14 11:12 (-1d) | 2008-05-15 14:12 → 2008-05-14 11:12 (-1d) |  | 33.26d → 18.5d |
| 100 | Présélection des progiciels | 2008-05-15 14:12 → 2008-05-14 11:12 (-1d) | 2008-05-16 15:12 → 2008-05-15 14:12 (-1d) |  | 33.26d → 18.5d |
| 101 | Liste des logiciels | 2008-05-16 15:12 → 2008-05-15 14:12 (-1d) | 2008-05-16 15:12 → 2008-05-15 14:12 (-1d) |  | 33.26d → 18.5d |
| 102 | **Choix progiciels** | 2008-05-16 15:12 → 2008-05-15 14:12 (-1d) | 2008-05-20 15:12 → 2008-05-19 14:12 (-1d) |  | 33.26d → 18.5d |
| 103 | Réalisation d'un dossier de choix | 2008-05-16 15:12 → 2008-05-15 14:12 (-1d) | 2008-05-19 16:12 → 2008-05-16 15:12 (-3d) |  | 33.26d → 18.5d |
| 104 | Choix du progiciel | 2008-05-19 16:12 → 2008-05-16 15:12 (-3d) | 2008-05-20 09:12 → 2008-05-16 17:12 (-4d) |  | 33.26d → 18.5d |
| 105 | Dossier de choix | 2008-05-20 09:12 → 2008-05-16 17:12 (-4d) | 2008-05-20 09:12 → 2008-05-16 17:12 (-4d) |  | 33.26d → 18.5d |
| 106 | Passage de la commande | 2008-05-20 09:12 → 2008-05-16 17:12 (-4d) | 2008-05-20 15:12 → 2008-05-19 14:12 (-1d) |  | 76.38d → 53.5d |
| 107 | Bon de commande | 2008-05-20 15:12 → 2008-05-19 14:12 (-1d) | 2008-05-20 15:12 → 2008-05-19 14:12 (-1d) |  | 76.38d → 53.5d |
| 108 | **Mise en place** | 2008-05-20 09:12 → 2008-05-16 17:12 (-4d) | 2008-06-23 16:09 → 2008-05-28 11:12 (-26d) | 21.62d → 6.5d | 55.26d → 47.5d |
| 109 | Commande des matériels | 2008-05-20 09:12 → 2008-05-16 17:12 (-4d) | 2008-05-20 15:12 → 2008-05-19 14:12 (-1d) |  | 55.26d → 47.5d |
| 110 | Bon de commande | 2008-05-20 15:12 → 2008-05-19 14:12 (-1d) | 2008-05-20 15:12 → 2008-05-19 14:12 (-1d) |  | 55.26d → 47.5d |
| 111 | Vérification des matériels | 2008-05-20 15:12 → 2008-05-19 14:12 (-1d) | 2008-05-21 16:12 → 2008-05-20 15:12 (-1d) |  | 55.26d → 47.5d |
| 112 | PV de réception | 2008-05-21 16:12 → 2008-05-20 15:12 (-1d) | 2008-05-21 16:12 → 2008-05-20 15:12 (-1d) |  | 55.26d → 47.5d |
| 113 | Installation des matériels | 2008-05-21 16:12 → 2008-05-20 15:12 (-1d) | 2008-06-09 11:27 → 2008-05-21 16:12 (-19d) |  | 55.26d → 48.5d |
| 114 | Installation du réseau | 2008-05-21 16:12 → 2008-05-20 15:12 (-1d) | 2008-05-26 09:27 → 2008-05-22 17:12 (-4d) |  | 64.26d → 47.5d |
| 115 | Partie matérielle installée | 2008-06-09 11:27 → 2008-05-22 17:12 (-18d) | 2008-06-09 11:27 → 2008-05-22 17:12 (-18d) |  | 55.26d → 47.5d |
| 116 | Installation des systèmes d'exploitation | 2008-06-09 11:27 → 2008-05-22 17:12 (-18d) | 2008-06-11 15:42 → 2008-05-27 10:12 (-15d) |  | 55.26d → 47.5d |
| 117 | Installation du progiciel de gestion des stocks | 2008-06-11 15:42 → 2008-05-27 10:12 (-15d) | 2008-06-23 16:09 → 2008-05-28 11:12 (-26d) |  | 55.26d → 47.5d |
| 118 | Partie logicielle installée | 2008-06-23 16:09 → 2008-05-28 11:12 (-26d) | 2008-06-23 16:09 → 2008-05-28 11:12 (-26d) |  | 55.26d → 47.5d |
| 119 | **Paramétrage** | 2008-05-20 09:12 → 2008-05-16 17:12 (-4d) | 2008-06-19 17:57 → 2008-06-05 15:12 (-14d) | 20.09d → 12d | 33.26d → 18.5d |
| 120 | Définition des paramètres | 2008-05-20 09:12 → 2008-05-16 17:12 (-4d) | 2008-05-22 11:12 → 2008-05-21 10:12 (-1d) |  | 33.26d → 18.5d |
| 121 | Paramétrage du logiciel | 2008-05-22 11:12 → 2008-05-21 10:12 (-1d) | 2008-06-19 17:57 → 2008-06-05 15:12 (-14d) | 14.03d → 10d | 33.26d → 18.5d |
| 122 | Logiciel paramétré | 2008-06-19 17:57 → 2008-06-05 15:12 (-14d) | 2008-06-19 17:57 → 2008-06-05 15:12 (-14d) |  | 56.78d → 42d |
| 123 | **Tests** | 2008-05-20 09:12 → 2008-05-16 17:12 (-4d) | 2008-06-24 17:09 → 2008-06-10 14:12 (-14d) | 22.62d → 14.5d | 33.26d → 18.5d |
| 124 | Définition des données de test | 2008-05-20 09:12 → 2008-05-16 17:12 (-4d) | 2008-05-22 11:12 → 2008-05-21 10:12 (-1d) |  | 51.35d → 28.5d |
| 125 | Tests du logiciel | 2008-06-19 17:57 → 2008-06-05 15:12 (-14d) | 2008-06-24 17:09 → 2008-06-10 14:12 (-14d) | 2.52d → 2.5d | 33.26d → 18.5d |
| 126 | Logiciel testé | 2008-06-24 17:09 → 2008-06-10 14:12 (-14d) | 2008-06-24 17:09 → 2008-06-10 14:12 (-14d) |  | 33.26d → 18.5d |
| 127 | **Recette** | 2008-06-24 17:09 → 2008-06-10 14:12 (-14d) | 2008-07-11 14:09 → 2008-06-27 09:12 (-14d) |  | 33.26d → 18.5d |
| 128 | Effectuer la recette | 2008-06-24 17:09 → 2008-06-10 14:12 (-14d) | 2008-06-26 09:09 → 2008-06-11 15:12 (-15d) |  | 33.26d → 18.5d |
| 129 | PV de recette | 2008-06-26 09:09 → 2008-06-11 15:12 (-15d) | 2008-06-26 09:09 → 2008-06-11 15:12 (-15d) |  | 33.26d → 18.5d |
| 130 | Mettre en production | 2008-06-26 09:09 → 2008-06-11 15:12 (-15d) | 2008-07-11 14:09 → 2008-06-27 09:12 (-14d) |  | 33.26d → 18.5d |
| 131 | Logiciel opérationnel | 2008-07-11 14:09 → 2008-06-27 09:12 (-14d) | 2008-07-11 14:09 → 2008-06-27 09:12 (-14d) |  | 33.26d → 18.5d |
| 132 | **Formation** | 2008-07-11 14:09 → 2008-06-27 09:12 (-14d) | 2008-07-28 17:09 → 2008-07-14 14:12 (-14d) |  | 33.26d → 18.5d |
| 133 | Former les utilisateurs | 2008-07-11 14:09 → 2008-06-27 09:12 (-14d) | 2008-07-28 17:09 → 2008-07-14 14:12 (-14d) |  | 33.26d → 18.5d |
| 134 | Utilisateurs formés | 2008-07-28 17:09 → 2008-07-14 14:12 (-14d) | 2008-07-28 17:09 → 2008-07-14 14:12 (-14d) |  | 33.26d → 18.5d |
| 135 | **Etude du site internet** | 2008-05-07 16:12 → 2008-05-06 15:12 (-1d) | 2008-05-27 16:12 → 2008-05-26 15:12 (-1d) |  |  |
| 136 | **Définition fonctions** | 2008-05-07 16:12 → 2008-05-06 15:12 (-1d) | 2008-05-15 14:12 → 2008-05-14 11:12 (-1d) |  |  |
| 137 | Définir les fonctions | 2008-05-07 16:12 → 2008-05-06 15:12 (-1d) | 2008-05-13 10:12 → 2008-05-12 09:12 (-1d) |  |  |
| 138 | Rédiger le cahier des charges | 2008-05-13 10:12 → 2008-05-12 09:12 (-1d) | 2008-05-15 14:12 → 2008-05-14 11:12 (-1d) |  |  |
| 139 | Cahier des charges | 2008-05-15 14:12 → 2008-05-14 11:12 (-1d) | 2008-05-15 14:12 → 2008-05-14 11:12 (-1d) |  |  |
| 140 | **Définition interfaces** | 2008-05-15 14:12 → 2008-05-14 11:12 (-1d) | 2008-05-27 16:12 → 2008-05-26 15:12 (-1d) |  |  |
| 141 | Faire les maquettes | 2008-05-15 14:12 → 2008-05-14 11:12 (-1d) | 2008-05-26 15:12 → 2008-05-23 14:12 (-3d) |  |  |
| 142 | Valider les maquettes | 2008-05-26 15:12 → 2008-05-23 14:12 (-3d) | 2008-05-27 16:12 → 2008-05-26 15:12 (-1d) |  |  |
| 143 | Maquettes validées | 2008-05-27 16:12 → 2008-05-26 15:12 (-1d) | 2008-05-27 16:12 → 2008-05-26 15:12 (-1d) |  |  |
| 144 | **Mise en place du site** | 2008-05-27 16:12 → 2008-05-26 15:12 (-1d) | 2008-08-07 09:12 → 2008-06-30 16:12 (-38d) | 44.88d → 22d |  |
| 145 | **Développements** | 2008-05-27 16:12 → 2008-05-26 15:12 (-1d) | 2008-07-29 10:12 → 2008-06-19 17:12 (-40d) | 38.88d → 16d |  |
| 146 | Définir le nombre de prototypes | 2008-05-27 16:12 → 2008-05-26 15:12 (-1d) | 2008-05-28 17:12 → 2008-05-27 16:12 (-1d) |  |  |
| 147 | Réaliser le prototype (n fois) | 2008-05-28 17:12 → 2008-05-27 16:12 (-1d) | 2008-07-04 10:27 → 2008-06-19 17:12 (-15d) |  | 14.84d → 0d |
| 148 | Tester le prototype (n fois) | 2008-06-10 17:12 → 2008-05-27 16:12 (-14d) | 2008-07-29 10:12 → 2008-06-19 17:12 (-40d) | 23.47d → 15d |  |
| 149 | Définir les améliorations (n fois) | 2008-05-28 17:12 → 2008-05-27 16:12 (-1d) | 2008-07-04 11:57 → 2008-06-19 17:12 (-15d) | 22.47d → 15d | 14.66d → 0d |
| 150 | Prototypes (n) | 2008-07-29 10:12 → 2008-06-19 17:12 (-40d) | 2008-07-29 10:12 → 2008-06-19 17:12 (-40d) |  |  |
| 151 | **Installation** | 2008-07-29 10:12 → 2008-06-19 17:12 (-40d) | 2008-08-07 09:12 → 2008-06-30 16:12 (-38d) |  |  |
| 152 | Réaliser l'installation avec le prestataire d'accès | 2008-07-29 10:12 → 2008-06-19 17:12 (-40d) | 2008-08-07 09:12 → 2008-06-30 16:12 (-38d) |  |  |
| 153 | Accès internet | 2008-08-07 09:12 → 2008-06-30 16:12 (-38d) | 2008-08-07 09:12 → 2008-06-30 16:12 (-38d) |  |  |
| 154 | **Mise en production du site** | 2008-08-07 09:12 → 2008-06-30 16:12 (-38d) | 2008-09-12 11:12 → 2008-08-06 09:12 (-37d) |  |  |
| 155 | **Test finaux** | 2008-08-07 09:12 → 2008-06-30 16:12 (-38d) | 2008-08-22 14:12 → 2008-07-16 10:12 (-37d) |  |  |
| 156 | Faire les tests finaux | 2008-08-07 09:12 → 2008-06-30 16:12 (-38d) | 2008-08-22 14:12 → 2008-07-16 10:12 (-37d) |  |  |
| 157 | **Recette** | 2008-08-22 14:12 → 2008-07-16 10:12 (-37d) | 2008-08-27 17:12 → 2008-07-21 15:12 (-37d) |  |  |
| 158 | Effectuer la recette | 2008-08-22 14:12 → 2008-07-16 10:12 (-37d) | 2008-08-27 17:12 → 2008-07-21 15:12 (-37d) |  |  |
| 159 | PV de recette | 2008-08-27 17:12 → 2008-07-21 15:12 (-37d) | 2008-08-27 17:12 → 2008-07-21 15:12 (-37d) |  |  |
| 160 | **Formation** | 2008-08-27 17:12 → 2008-07-21 15:12 (-37d) | 2008-09-12 11:12 → 2008-08-06 09:12 (-37d) |  |  |

| ID | Task | Start | Finish | Duration | Total float | Other |
| --- | --- | --- | --- | --- | --- | --- |
| 161 | Elaborer la doc utilisateurs | 2008-08-27 17:12 → 2008-07-21 15:12 (-37d) | 2008-09-04 15:12 → 2008-07-29 11:12 (-37d) |  |  |  |
| 162 | Doc utilisateurs | 2008-09-04 15:12 → 2008-07-29 11:12 (-37d) | 2008-09-04 15:12 → 2008-07-29 11:12 (-37d) |  |  |  |
| 163 | Former les utilisateurs | 2008-09-04 15:12 → 2008-07-29 11:12 (-37d) | 2008-09-12 11:12 → 2008-08-06 09:12 (-37d) |  |  |  |
| 164 | Utilisateurs formés | 2008-09-12 11:12 → 2008-08-06 09:12 (-37d) | 2008-09-12 11:12 → 2008-08-06 09:12 (-37d) |  |  |  |
| 165 | **GESTION DU PROJET** | 2008-04-17 08:00 → 2000-06-26 09:00 (-2852d) | 2008-09-18 17:12 → 2008-08-12 15:12 (-37d) | 97.03d → 1856.4d |  |  |
| 166 | **Piloter le projet** | 2008-04-17 08:00 → 2000-06-26 09:00 (-2852d) | 2008-09-15 14:12 → 2008-08-07 10:12 (-39d) | 94.03d → 1853.4d |  |  |
| 167 | **Réalisation** | 2008-04-17 08:00 → 2000-06-26 09:00 (-2852d) | 2008-09-15 14:12 → 2008-08-07 10:12 (-39d) | 94.03d → 1853.4d |  |  |
| 168 | **Piloter la réalisation du produit** | 2008-04-17 08:00 → 2000-06-26 09:00 (-2852d) | 2008-09-15 14:12 → 2008-08-07 10:12 (-39d) | 94.03d → 1853.4d |  |  |
| 401 | Envoyer communication presse | 2008-06-26 09:00 → 2000-06-26 09:00 (-2922d) | 2008-06-27 10:00 → 2000-06-27 10:00 (-2922d) |  | 52.28d → 1855.4d | constraint start no earlier than 2008-06-26 09:00 → start no earlier than 2000-06-26 08:00 |
| 402 | Communication presse | 2008-09-12 11:12 → 2008-08-06 09:12 (-37d) | 2008-09-12 11:12 → 2008-08-06 09:12 (-37d) |  |  |  |
| 404 | Envoyer la communication clients | 2008-09-12 11:12 → 2008-08-06 09:12 (-37d) | 2008-09-15 14:12 → 2008-08-07 10:12 (-39d) |  |  |  |
| 405 | Communication clients | 2008-09-15 14:12 → 2008-08-07 10:12 (-39d) | 2008-09-15 14:12 → 2008-08-07 10:12 (-39d) |  |  |  |
| 406 | **Faire le bilan du projet** | 2008-09-12 11:12 → 2008-08-06 09:12 (-37d) | 2008-09-18 17:12 → 2008-08-12 15:12 (-37d) |  |  |  |
| 407 | **Promotion** | 2008-09-12 11:12 → 2008-08-06 09:12 (-37d) | 2008-09-15 14:12 → 2008-08-07 10:12 (-39d) |  |  |  |
| 408 | Vendre le projet | 2008-09-12 11:12 → 2008-08-06 09:12 (-37d) | 2008-09-15 14:12 → 2008-08-07 10:12 (-39d) |  |  |  |
| 409 | Présentation de projet | 2008-09-15 14:12 → 2008-08-07 10:12 (-39d) | 2008-09-15 14:12 → 2008-08-07 10:12 (-39d) |  |  |  |
| 410 | **Désengagement** | 2008-09-15 14:12 → 2008-08-07 10:12 (-39d) | 2008-09-16 15:12 → 2008-08-08 11:12 (-39d) |  |  |  |
| 411 | Mettre un terme à l'engagement contractuel | 2008-09-15 14:12 → 2008-08-07 10:12 (-39d) | 2008-09-16 15:12 → 2008-08-08 11:12 (-39d) |  |  |  |
| 412 | Note de désengagement | 2008-09-16 15:12 → 2008-08-08 11:12 (-39d) | 2008-09-16 15:12 → 2008-08-08 11:12 (-39d) |  |  |  |
| 413 | **Capitalisation** | 2008-09-16 15:12 → 2008-08-08 11:12 (-39d) | 2008-09-18 17:12 → 2008-08-12 15:12 (-37d) |  |  |  |
| 414 | Organiser les réunions de débriefing | 2008-09-16 15:12 → 2008-08-08 11:12 (-39d) | 2008-09-17 16:12 → 2008-08-11 14:12 (-37d) |  |  |  |
| 415 | Bilan final de projet | 2008-09-17 16:12 → 2008-08-11 14:12 (-37d) | 2008-09-17 16:12 → 2008-08-11 14:12 (-37d) |  |  |  |
| 416 | Archiver les dossiers du projet | 2008-09-17 16:12 → 2008-08-11 14:12 (-37d) | 2008-09-18 17:12 → 2008-08-12 15:12 (-37d) |  |  |  |
| 417 | Note d’archivage | 2008-09-18 17:12 → 2008-08-12 15:12 (-37d) | 2008-09-18 17:12 → 2008-08-12 15:12 (-37d) |  |  |  |
| 418 | Fin du projet | 2008-09-18 17:12 → 2008-08-12 15:12 (-37d) | 2008-09-18 17:12 → 2008-08-12 15:12 (-37d) |  |  |  |

## Version 5 (saved 2008-06-17, file 20-Planning détaillé pour fiche 31-Polo.mpp)

Last finish 2008-08-12 → 2000-09-22 (-2881d). Complete tasks 0 → 109.

Added:

| ID | Task | Duration | Start | Finish | Constraint | Resources |
| --- | --- | --- | --- | --- | --- | --- |
| 227 | **Reporting EFII** | 53.44d | 2000-04-20 09:00 | 2000-07-20 09:30 |  |  |
| 228 | Reporting EFII 1 | 30min | 2000-04-20 09:00 | 2000-04-20 09:30 | start no earlier than 2000-04-20 08:00 | Karen; Christophe |
| 229 | Reporting EFII 2 | 30min | 2000-04-27 09:00 | 2000-04-27 09:30 | start no earlier than 2000-04-27 08:00 | Karen; Christophe |
| 230 | Reporting EFII 3 | 30min | 2000-05-04 09:00 | 2000-05-04 09:30 | start no earlier than 2000-05-04 08:00 | Karen; Christophe |
| 231 | Reporting EFII 4 | 30min | 2000-05-11 09:00 | 2000-05-11 09:30 | start no earlier than 2000-05-11 08:00 | Karen; Christophe |
| 232 | Reporting EFII 5 | 30min | 2000-05-18 09:00 | 2000-05-18 09:30 | start no earlier than 2000-05-18 08:00 | Karen; Christophe |
| 233 | Reporting EFII 6 | 30min | 2000-05-25 09:00 | 2000-05-25 09:30 | start no earlier than 2000-05-25 08:00 | Karen; Christophe |
| 234 | Reporting EFII 7 | 30min | 2000-06-08 09:00 | 2000-06-08 09:30 | start no earlier than 2000-06-08 08:00 | Karen; Christophe |
| 235 | Reporting EFII 8 | 30min | 2000-06-15 09:00 | 2000-06-15 09:30 | start no earlier than 2000-06-15 08:00 | Karen; Christophe |
| 236 | Reporting EFII 9 | 30min | 2000-06-22 09:00 | 2000-06-22 09:30 | start no earlier than 2000-06-22 08:00 | Karen; Christophe |
| 237 | Reporting EFII 10 | 30min | 2000-06-29 09:00 | 2000-06-29 09:30 | start no earlier than 2000-06-29 08:00 | Karen; Christophe |
| 238 | Reporting EFII 11 | 30min | 2000-07-06 09:00 | 2000-07-06 09:30 | start no earlier than 2000-07-06 08:00 | Karen; Christophe |
| 239 | Reporting EFII 12 | 30min | 2000-07-13 09:00 | 2000-07-13 09:30 | start no earlier than 2000-07-13 08:00 | Karen; Christophe |
| 240 | Reporting EFII 13 | 30min | 2000-07-20 09:00 | 2000-07-20 09:30 | start no earlier than 2000-07-20 08:00 | Karen; Christophe |
| 275 | **Rapport flash** | 35.88d | 2000-05-01 08:00 | 2000-07-03 08:00 |  |  |
| 276 | Rapport flash 1 | 0d | 2000-05-01 08:00 | 2000-05-01 08:00 | start no earlier than 2000-05-01 08:00 |  |
| 277 | Rapport flash 2 | 0d | 2000-06-05 08:00 | 2000-06-05 08:00 | start no earlier than 2000-06-05 08:00 |  |
| 278 | Rapport flash 3 | 0d | 2000-07-03 08:00 | 2000-07-03 08:00 | start no earlier than 2000-07-03 08:00 |  |

Removed: 227 Reporting CAPS 58; 228 Reporting CAPS 59; 229 Reporting CAPS 60; 230 Reporting CAPS 61; 231 Reporting CAPS 62; 232 Reporting CAPS 63; 233 Reporting CAPS 64; 234 Reporting CAPS 65; 235 Reporting CAPS 66; 236 Reporting CAPS 67; 237 Reporting CAPS 68; 238 Reporting CAPS 69; 239 Reporting CAPS 70; 240 Reporting CAPS 71; 241 Reporting CAPS 72; 242 Reporting CAPS 73; 243 Reporting CAPS 74; 244 Reporting CAPS 75; 245 Reporting CAPS 76; 246 Reporting CAPS 77; 247 Reporting CAPS 78; 248 Reporting CAPS 79; 249 Reporting CAPS 80; 250 Reporting CAPS 81; 251 Reporting CAPS 82; 252 Reporting CAPS 83; 253 Reporting CAPS 84; 254 Reporting CAPS 85; 255 Reporting CAPS 86; 256 Reporting CAPS 87; 257 Reporting CAPS 88; 258 Reporting CAPS 89; 259 Reporting CAPS 90; 260 Reporting CAPS 91; 261 Reporting CAPS 92; 262 Reporting CAPS 93; 263 Reporting CAPS 94; 264 Reporting CAPS 95; 265 Reporting CAPS 96; 266 Reporting CAPS 97; 267 Reporting CAPS 98; 268 Reporting CAPS 99; 269 Reporting CAPS 100; 270 Reporting CAPS 101; 271 Reporting CAPS 102; 272 Reporting CAPS 103; 273 Reporting CAPS 104; 274 Reporting CAPS 105; 275 Reporting CAPS 106; 276 Reporting CAPS 107; 277 Reporting PO; 278 Reporting PO 1; 279 Reporting PO 2; 280 Reporting PO 3; 281 Reporting PO 4; 282 Reporting PO 5; 283 Reporting PO 6; 284 Reporting PO 7; 285 Reporting PO 8; 286 Reporting PO 9; 287 Reporting PO 10; 288 Reporting PO 11; 289 Reporting PO 12; 290 Reporting PO 13; 291 Reporting PO 14; 292 Reporting PO 15; 293 Reporting PO 16; 294 Reporting PO 17; 295 Reporting PO 18; 296 Reporting PO 19; 297 Reporting PO 20; 298 Reporting PO 21; 299 Reporting PO 22; 300 Reporting PO 23; 301 Reporting PO 24; 302 Reporting PO 25; 303 Reporting PO 26; 304 Reporting PO 27; 305 Reporting PO 28; 306 Reporting PO 29; 307 Reporting PO 30; 323 Reporting commanditaire 15; 339 Fiche de reporting 15; 344 Réunion comité de pilotage 4; 345 Rapport Flash; 346 Rapport Flash 1; 347 Rapport Flash 2; 348 Rapport Flash 3; 349 Rapport Flash 4

Changed:

| ID | Task | Start | Finish | Duration | Complete | Total float | Other |
| --- | --- | --- | --- | --- | --- | --- | --- |
| 1 | Début du projet | 2008-04-17 08:00 → 2000-04-17 08:00 A (-2922d) | 2008-04-17 08:00 → 2000-04-17 08:00 A (-2922d) |  | 0% → 100% | 73.15d → none | baseline start none → 2000-04-17 08:00; baseline finish none → 2000-04-17 08:00 |
| 2 | **GESTION DU PROJET** | 2008-04-17 09:00 → 2000-04-17 08:00 A (-2922d) | 2008-04-30 09:12 → 2000-04-26 16:12 A (-2926d) | 7.9d → 6.78d | 0% → 100% | 0d → none | baseline start none → 2000-04-17 08:00; baseline finish none → 2000-04-26 16:12 |
| 3 | **Initialiser le projet** | 2008-04-17 09:00 → 2000-04-17 08:00 A (-2922d) | 2008-04-18 18:00 → 2000-04-18 15:00 A (-2922d) | 1.75d → 1.38d | 0% → 100% | 0d → none | baseline start none → 2000-04-17 08:00; baseline finish none → 2000-04-18 15:00 |
| 4 | **Réception** | 2008-04-17 09:00 → 2000-04-17 08:00 A (-2922d) | 2008-04-17 15:00 → 2000-04-17 12:00 A (-2922d) | 0.5d → 0.38d | 0% → 100% | 0d → none | baseline start none → 2000-04-17 08:00; baseline finish none → 2000-04-17 12:00 |
| 5 | Réceptionner la demande de projet du commanditaire | 2008-04-17 09:00 → 2000-04-17 08:00 A (-2922d) | 2008-04-17 11:00 → 2000-04-17 10:00 A (-2922d) | 0.25d → 0.12d | 0% → 100% | 0d → none | resources Henri → Henri [200%]; baseline start none → 2000-04-17 08:00; baseline finish none → 2000-04-17 10:00 |
| 6 | Demande de projet du commanditaire | 2008-04-17 11:00 → 2000-04-17 10:00 A (-2922d) | 2008-04-17 11:00 → 2000-04-17 10:00 A (-2922d) |  | 0% → 100% | 0d → none | baseline start none → 2000-04-17 10:00; baseline finish none → 2000-04-17 10:00 |
| 7 | Examiner la demande du commanditaire | 2008-04-17 11:00 → 2000-04-17 10:00 A (-2922d) | 2008-04-17 15:00 → 2000-04-17 12:00 A (-2922d) |  | 0% → 100% | 0d → none | baseline start none → 2000-04-17 10:00; baseline finish none → 2000-04-17 12:00 |
| 8 | Réponse à la demande de projet | 2008-04-17 15:00 → 2000-04-17 12:00 A (-2922d) | 2008-04-17 15:00 → 2000-04-17 12:00 A (-2922d) |  | 0% → 100% | 72.65d → none | baseline start none → 2000-04-17 12:00; baseline finish none → 2000-04-17 12:00 |
| 9 | **Affectation** | 2008-04-17 15:00 → 2000-04-17 13:00 A (-2922d) | 2008-04-18 18:00 → 2000-04-18 15:00 A (-2922d) | 1.25d → 1d | 0% → 100% | 0d → none | baseline start none → 2000-04-17 13:00; baseline finish none → 2000-04-18 15:00 |
| 10 | Officialiser la nomination du chef de projet | 2008-04-17 15:00 → 2000-04-17 13:00 A (-2922d) | 2008-04-17 17:00 → 2000-04-17 15:00 A (-2922d) | 0.25d → 0.12d | 0% → 100% | 0d → none | resources Karen [50%]; Henri → Karen; Henri [200%]; baseline start none → 2000-04-17 13:00; baseline finish none → 2000-04-17 15:00 |
| 11 | Note d’affectation du chef de projet | 2008-04-18 18:00 → 2000-04-18 15:00 A (-2922d) | 2008-04-18 18:00 → 2000-04-18 15:00 A (-2922d) |  | 0% → 100% | 0d → none | baseline start none → 2000-04-18 15:00; baseline finish none → 2000-04-18 15:00 |
| 12 | **Préparer le projet** | 2008-04-21 09:00 → 2000-04-18 15:00 A (-2925d) | 2008-04-25 15:00 → 2000-04-24 15:00 A (-2923d) | 4d → 3.5d | 0% → 100% | 0d → none | baseline start none → 2000-04-18 15:00; baseline finish none → 2000-04-24 15:00 |
| 13 | **Objet** | 2008-04-21 09:00 → 2000-04-18 15:00 A (-2925d) | 2008-04-21 11:00 → 2000-04-18 17:00 A (-2925d) |  | 0% → 100% | 0d → none | baseline start none → 2000-04-18 15:00; baseline finish none → 2000-04-18 17:00 |
| 14 | Définir l’objet précis du projet | 2008-04-21 09:00 → 2000-04-18 15:00 A (-2925d) | 2008-04-21 11:00 → 2000-04-18 17:00 A (-2925d) |  | 0% → 100% | 71.15d → none | baseline start none → 2000-04-18 15:00; baseline finish none → 2000-04-18 17:00 |
| 15 | Note de cadrage | 2008-04-21 11:00 → 2000-04-18 17:00 A (-2925d) | 2008-04-21 11:00 → 2000-04-18 17:00 A (-2925d) |  | 0% → 100% | 71.15d → none | baseline start none → 2000-04-18 17:00; baseline finish none → 2000-04-18 17:00 |
| 16 | Lister les motifs et définir le contexte | 2008-04-21 09:00 → 2000-04-18 15:00 A (-2925d) | 2008-04-21 11:00 → 2000-04-18 17:00 A (-2925d) |  | 0% → 100% | 0d → none | baseline start none → 2000-04-18 15:00; baseline finish none → 2000-04-18 17:00 |
| 17 | Note de cadrage (suite) | 2008-04-21 11:00 → 2000-04-18 17:00 A (-2925d) | 2008-04-21 11:00 → 2000-04-18 17:00 A (-2925d) |  | 0% → 100% | 0d → none | baseline start none → 2000-04-18 17:00; baseline finish none → 2000-04-18 17:00 |
| 18 | **Objectifs** | 2008-04-22 14:00 → 2000-04-20 08:00 A (-2924d) | 2008-04-23 11:00 → 2000-04-20 15:00 A (-2925d) | 0.75d → 0.5d | 0% → 100% | 0d → none | baseline start none → 2000-04-20 08:00; baseline finish none → 2000-04-20 15:00 |
| 19 | Définir les objectifs de qualité | 2008-04-22 14:00 → 2000-04-20 08:00 A (-2924d) | 2008-04-22 18:00 → 2000-04-20 12:00 A (-2924d) | 0.5d → 0.38d | 0% → 100% | 69.65d → none | resources Karen [75%]; Henri [75%] → Karen; Henri; baseline start none → 2000-04-20 08:00; baseline finish none → 2000-04-20 12:00 |
| 20 | Note de cadrage (suite) | 2008-04-22 18:00 → 2000-04-20 12:00 A (-2924d) | 2008-04-22 18:00 → 2000-04-20 12:00 A (-2924d) |  | 0% → 100% | 69.65d → none | baseline start none → 2000-04-20 12:00; baseline finish none → 2000-04-20 12:00 |
| 21 | Définir les objectifs de temps | 2008-04-22 14:00 → 2000-04-20 08:00 A (-2924d) | 2008-04-22 16:00 → 2000-04-20 10:00 A (-2924d) | 0.25d → 0.12d | 0% → 100% | 69.9d → none | resources Karen [50%] → Karen; baseline start none → 2000-04-20 08:00; baseline finish none → 2000-04-20 10:00 |
| 22 | macro-planning | 2008-04-22 16:00 → 2000-04-20 10:00 A (-2924d) | 2008-04-22 16:00 → 2000-04-20 10:00 A (-2924d) |  | 0% → 100% | 69.9d → none | baseline start none → 2000-04-20 10:00; baseline finish none → 2000-04-20 10:00 |
| 23 | Définir les objectifs de charge et de coûts | 2008-04-22 14:00 → 2000-04-20 08:00 A (-2924d) | 2008-04-22 16:00 → 2000-04-20 10:00 A (-2924d) | 0.25d → 0.12d | 0% → 100% | 69.65d → none | resources Karen [50%] → Karen; baseline start none → 2000-04-20 08:00; baseline finish none → 2000-04-20 10:00 |
| 24 | macro-planning de charge | 2008-04-22 16:00 → 2000-04-20 10:00 A (-2924d) | 2008-04-22 16:00 → 2000-04-20 10:00 A (-2924d) |  | 0% → 100% | 69.9d → none | baseline start none → 2000-04-20 10:00; baseline finish none → 2000-04-20 10:00 |
| 25 | Budget prévisionnel | 2008-04-22 16:00 → 2000-04-20 10:00 A (-2924d) | 2008-04-22 16:00 → 2000-04-20 10:00 A (-2924d) |  | 0% → 100% | 69.9d → none | baseline start none → 2000-04-20 10:00; baseline finish none → 2000-04-20 10:00 |
| 26 | Définir les objectifs de communication | 2008-04-22 16:00 → 2000-04-20 10:00 A (-2924d) | 2008-04-22 18:00 → 2000-04-20 12:00 A (-2924d) |  | 0% → 100% | 69.65d → none | baseline start none → 2000-04-20 10:00; baseline finish none → 2000-04-20 12:00 |
| 27 | Stratégie de communication | 2008-04-22 18:00 → 2000-04-20 12:00 A (-2924d) | 2008-04-22 18:00 → 2000-04-20 12:00 A (-2924d) |  | 0% → 100% | 69.65d → none | baseline start none → 2000-04-20 12:00; baseline finish none → 2000-04-20 12:00 |
| 28 | Définir les objectifs complémentaires | 2008-04-22 14:00 → 2000-04-20 08:00 A (-2924d) | 2008-04-22 16:00 → 2000-04-20 10:00 A (-2924d) | 0.25d → 0.12d | 0% → 100% | 0d → none | resources Karen [12.5%]; Henri [12.5%] → Karen [25%]; Henri [25%]; baseline start none → 2000-04-20 08:00; baseline finish none → 2000-04-20 10:00 |
| 29 | Note de cadrage (suite) | 2008-04-22 16:00 → 2000-04-20 10:00 A (-2924d) | 2008-04-22 16:00 → 2000-04-20 10:00 A (-2924d) |  | 0% → 100% | 0d → none | baseline start none → 2000-04-20 10:00; baseline finish none → 2000-04-20 10:00 |
| 30 | Préciser les contraintes sur objectifs | 2008-04-22 16:00 → 2000-04-20 10:00 A (-2924d) | 2008-04-22 18:00 → 2000-04-20 12:00 A (-2924d) |  | 0% → 100% | 0d → none | baseline start none → 2000-04-20 10:00; baseline finish none → 2000-04-20 12:00 |
| 31 | Note de cadrage (suite) | 2008-04-22 18:00 → 2000-04-20 12:00 A (-2924d) | 2008-04-22 18:00 → 2000-04-20 12:00 A (-2924d) |  | 0% → 100% | 0d → none | baseline start none → 2000-04-20 12:00; baseline finish none → 2000-04-20 12:00 |
| 32 | Vérifier l’adéquation entre les objectifs | 2008-04-23 09:00 → 2000-04-20 13:00 A (-2925d) | 2008-04-23 11:00 → 2000-04-20 15:00 A (-2925d) | 0.25d → 0.12d | 0% → 100% | 0d → none | resources Karen [50%] → Karen; baseline start none → 2000-04-20 13:00; baseline finish none → 2000-04-20 15:00 |
| 33 | Note de cadrage (suite) | 2008-04-23 11:00 → 2000-04-20 15:00 A (-2925d) | 2008-04-23 11:00 → 2000-04-20 15:00 A (-2925d) |  | 0% → 100% | 0d → none | baseline start none → 2000-04-20 15:00; baseline finish none → 2000-04-20 15:00 |
| 34 | **Domaine** | 2008-04-23 11:00 → 2000-04-20 15:00 A (-2925d) | 2008-04-24 16:00 → 2000-04-21 17:00 A (-2925d) | 1.25d → 1.12d | 0% → 100% | 0d → none | baseline start none → 2000-04-20 15:00; baseline finish none → 2000-04-21 17:00 |
| 35 | Identifier le périmètre et les acteurs | 2008-04-23 11:00 → 2000-04-20 15:00 A (-2925d) | 2008-04-24 12:00 → 2000-04-21 15:00 A (-2925d) | 1d → 0.88d | 0% → 100% | 0d → none | resources Karen [50%] → Karen [57.1%]; baseline start none → 2000-04-20 15:00; baseline finish none → 2000-04-21 15:00 |
| 36 | Fichier des acteurs | 2008-04-24 12:00 → 2000-04-21 15:00 A (-2925d) | 2008-04-24 12:00 → 2000-04-21 15:00 A (-2925d) |  | 0% → 100% | 68.4d → none | baseline start none → 2000-04-21 15:00; baseline finish none → 2000-04-21 15:00 |
| 37 | Définir la structure choisie pour la gestion du projet | 2008-04-24 10:00 → 2000-04-21 13:00 A (-2925d) | 2008-04-24 12:00 → 2000-04-21 15:00 A (-2925d) | 0.25d → 0.12d | 0% → 100% | 0d → none | resources Karen [25%] → Karen [50%]; baseline start none → 2000-04-21 13:00; baseline finish none → 2000-04-21 15:00 |
| 38 | Organigramme Projet | 2008-04-24 12:00 → 2000-04-21 15:00 A (-2925d) | 2008-04-24 12:00 → 2000-04-21 15:00 A (-2925d) |  | 0% → 100% | 0d → none | baseline start none → 2000-04-21 15:00; baseline finish none → 2000-04-21 15:00 |
| 39 | Définir les rôles des acteurs dans les structures projets | 2008-04-24 14:00 → 2000-04-21 15:00 A (-2925d) | 2008-04-24 16:00 → 2000-04-21 17:00 A (-2925d) |  | 0% → 100% | 0d → none | baseline start none → 2000-04-21 15:00; baseline finish none → 2000-04-21 17:00 |
| 40 | Fiche de poste | 2008-04-24 16:00 → 2000-04-21 17:00 A (-2925d) | 2008-04-24 16:00 → 2000-04-21 17:00 A (-2925d) |  | 0% → 100% | 68.15d → none | baseline start none → 2000-04-21 17:00; baseline finish none → 2000-04-21 17:00 |
| 41 | Carte des acteurs | 2008-04-24 16:00 → 2000-04-21 17:00 A (-2925d) | 2008-04-24 16:00 → 2000-04-21 17:00 A (-2925d) |  | 0% → 100% | 0d → none | baseline start none → 2000-04-21 17:00; baseline finish none → 2000-04-21 17:00 |
| 42 | **Risques** | 2008-04-24 16:00 → 2000-04-24 08:00 A (-2922d) | 2008-04-24 18:00 → 2000-04-24 10:00 A (-2922d) | 0.25d → 0.12d | 0% → 100% | 0d → none | baseline start none → 2000-04-24 08:00; baseline finish none → 2000-04-24 10:00 |
| 43 | Identifier, analyser et gérer les freins | 2008-04-24 16:00 → 2000-04-24 08:00 A (-2922d) | 2008-04-24 18:00 → 2000-04-24 10:00 A (-2922d) | 0.25d → 0.12d | 0% → 100% | 0d → none | resources Karen [50%]; Henri [50%] → Karen; Henri; baseline start none → 2000-04-24 08:00; baseline finish none → 2000-04-24 10:00 |
| 44 | Grille des freins | 2008-04-24 18:00 → 2000-04-24 10:00 A (-2922d) | 2008-04-24 18:00 → 2000-04-24 10:00 A (-2922d) |  | 0% → 100% | 0d → none | baseline start none → 2000-04-24 10:00; baseline finish none → 2000-04-24 10:00 |
| 45 | Identifier, analyser et gérer les facilitants | 2008-04-24 16:00 → 2000-04-24 08:00 A (-2922d) | 2008-04-24 18:00 → 2000-04-24 10:00 A (-2922d) | 0.25d → 0.12d | 0% → 100% | 67.9d → none | resources Karen [25%]; Henri [25%] → Karen [50%]; Henri [50%]; baseline start none → 2000-04-24 08:00; baseline finish none → 2000-04-24 10:00 |
| 46 | Grille des facilitants | 2008-04-24 18:00 → 2000-04-24 10:00 A (-2922d) | 2008-04-24 18:00 → 2000-04-24 10:00 A (-2922d) |  | 0% → 100% | 0d → none | baseline start none → 2000-04-24 10:00; baseline finish none → 2000-04-24 10:00 |
| 47 | **Méthode** | 2008-04-24 16:00 → 2000-04-24 08:00 A (-2922d) | 2008-04-24 18:00 → 2000-04-24 10:00 A (-2922d) | 0.25d → 0.12d | 0% → 100% | 67.9d → none | baseline start none → 2000-04-24 08:00; baseline finish none → 2000-04-24 10:00 |
| 48 | Choisir une méthode et structurer la réal. du produit | 2008-04-24 16:00 → 2000-04-24 08:00 A (-2922d) | 2008-04-24 18:00 → 2000-04-24 10:00 A (-2922d) | 0.25d → 0.12d | 0% → 100% | 67.9d → none | resources Claudio [50%]; François [50%] → Claudio; François; baseline start none → 2000-04-24 08:00; baseline finish none → 2000-04-24 10:00 |
| 49 | Fiche méthode | 2008-04-24 18:00 → 2000-04-24 10:00 A (-2922d) | 2008-04-24 18:00 → 2000-04-24 10:00 A (-2922d) |  | 0% → 100% | 67.9d → none | baseline start none → 2000-04-24 10:00; baseline finish none → 2000-04-24 10:00 |
| 50 | **Communication** | 2008-04-25 09:00 → 2000-04-24 10:00 A (-2923d) | 2008-04-25 11:00 → 2000-04-24 12:00 A (-2923d) |  | 0% → 100% | 0d → none | baseline start none → 2000-04-24 10:00; baseline finish none → 2000-04-24 12:00 |
| 51 | Définir les axes, cibles et moyens de communication | 2008-04-25 09:00 → 2000-04-24 10:00 A (-2923d) | 2008-04-25 11:00 → 2000-04-24 12:00 A (-2923d) |  | 0% → 100% | 0d → none | baseline start none → 2000-04-24 10:00; baseline finish none → 2000-04-24 12:00 |
| 52 | Charte graphique | 2008-04-25 11:00 → 2000-04-24 12:00 A (-2923d) | 2008-04-25 11:00 → 2000-04-24 12:00 A (-2923d) |  | 0% → 100% | 67.65d → none | baseline start none → 2000-04-24 12:00; baseline finish none → 2000-04-24 12:00 |
| 53 | Plan de communication | 2008-04-25 11:00 → 2000-04-24 12:00 A (-2923d) | 2008-04-25 11:00 → 2000-04-24 12:00 A (-2923d) |  | 0% → 100% | 0d → none | baseline start none → 2000-04-24 12:00; baseline finish none → 2000-04-24 12:00 |
| 54 | **Contractualisation** | 2008-04-25 11:00 → 2000-04-24 13:00 A (-2923d) | 2008-04-25 15:00 → 2000-04-24 15:00 A (-2923d) | 0.25d → 0.12d | 0% → 100% | 0d → none | baseline start none → 2000-04-24 13:00; baseline finish none → 2000-04-24 15:00 |
| 55 | Rédiger la note de cadrage | 2008-04-25 11:00 → 2000-04-24 13:00 A (-2923d) | 2008-04-25 15:00 → 2000-04-24 15:00 A (-2923d) | 0.25d → 0.12d | 0% → 100% | 0d → none | resources Henri [50%]; Karen [50%] → Henri; Karen; baseline start none → 2000-04-24 13:00; baseline finish none → 2000-04-24 15:00 |
| 56 | Note de cadrage (suite) | 2008-04-25 15:00 → 2000-04-24 15:00 A (-2923d) | 2008-04-25 15:00 → 2000-04-24 15:00 A (-2923d) |  | 0% → 100% | 0d → none | baseline start none → 2000-04-24 15:00; baseline finish none → 2000-04-24 15:00 |
| 57 | **Planifier le projet** | 2008-04-25 15:00 → 2000-04-24 15:00 A (-2923d) | 2008-04-29 14:12 → 2000-04-26 11:12 A (-2925d) | 1.65d → 1.52d | 0% → 100% | 0d → none | baseline start none → 2000-04-24 15:00; baseline finish none → 2000-04-26 11:12 |
| 58 | **Planification détallée** | 2008-04-25 15:00 → 2000-04-24 15:00 A (-2923d) | 2008-04-28 17:12 → 2000-04-25 16:12 A (-2925d) | 1.15d → 1.02d | 0% → 100% | 0d → none | baseline start none → 2000-04-24 15:00; baseline finish none → 2000-04-25 16:12 |
| 59 | Définir l’environnement de planification | 2008-04-25 15:00 → 2000-04-24 15:00 A (-2923d) | 2008-04-25 15:48 → 2000-04-24 15:48 A (-2923d) |  | 0% → 100% | 0d → none | baseline start none → 2000-04-24 15:00; baseline finish none → 2000-04-24 15:48 |
| 60 | Charte de planification | 2008-04-25 15:48 → 2000-04-24 15:48 A (-2923d) | 2008-04-25 15:48 → 2000-04-24 15:48 A (-2923d) |  | 0% → 100% | 0d → none | baseline start none → 2000-04-24 15:48; baseline finish none → 2000-04-24 15:48 |
| 61 | Ordonner la liste des tâches de fabrication du produit | 2008-04-25 15:48 → 2000-04-24 15:48 A (-2923d) | 2008-04-25 17:48 → 2000-04-25 08:48 A (-2922d) | 0.25d → 0.28d | 0% → 100% | 0d → none | resources Karen [50%]; Claudio [50%]; François [50%] → Karen [45.5%]; Claudio [45.5%]; François [45.5%]; baseline start none → 2000-04-24 15:48; baseline finish none → 2000-04-25 08:48 |
| 62 | Organigramme des tâches | 2008-04-25 17:48 → 2000-04-25 08:48 A (-2922d) | 2008-04-25 17:48 → 2000-04-25 08:48 A (-2922d) |  | 0% → 100% | 0d → none | baseline start none → 2000-04-25 08:48; baseline finish none → 2000-04-25 08:48 |
| 63 | Affecter des durées ou des charges aux tâches | 2008-04-25 17:48 → 2000-04-25 08:48 A (-2922d) | 2008-04-28 09:36 → 2000-04-25 09:36 A (-2925d) | 0.1d → 0.07d | 0% → 100% | 0d → none | resources Karen [62.5%] → Karen [83.3%]; baseline start none → 2000-04-25 08:48; baseline finish none → 2000-04-25 09:36 |
| 64 | Planning détaillé | 2008-04-28 09:36 → 2000-04-25 09:36 A (-2925d) | 2008-04-28 09:36 → 2000-04-25 09:36 A (-2925d) |  | 0% → 100% | 0d → none | baseline start none → 2000-04-25 09:36; baseline finish none → 2000-04-25 09:36 |
| 65 | Définir les liens entre les tâches | 2008-04-28 09:36 → 2000-04-25 09:36 A (-2925d) | 2008-04-28 10:24 → 2000-04-25 10:24 A (-2925d) |  | 0% → 100% | 0d → none | baseline start none → 2000-04-25 09:36; baseline finish none → 2000-04-25 10:24 |
| 66 | Planning détaillé (suite) | 2008-04-28 10:24 → 2000-04-25 10:24 A (-2925d) | 2008-04-28 10:24 → 2000-04-25 10:24 A (-2925d) |  | 0% → 100% | 0d → none | baseline start none → 2000-04-25 10:24; baseline finish none → 2000-04-25 10:24 |
| 67 | Intégrer les tâches de gestion de projet | 2008-04-28 10:24 → 2000-04-25 10:24 A (-2925d) | 2008-04-28 11:12 → 2000-04-25 11:12 A (-2925d) |  | 0% → 100% | 0d → none | baseline start none → 2000-04-25 10:24; baseline finish none → 2000-04-25 11:12 |
| 68 | Planning détaillé (suite) | 2008-04-28 11:12 → 2000-04-25 11:12 A (-2925d) | 2008-04-28 11:12 → 2000-04-25 11:12 A (-2925d) |  | 0% → 100% | 0d → none | baseline start none → 2000-04-25 11:12; baseline finish none → 2000-04-25 11:12 |
| 69 | Affecter les ressources sur les tâches | 2008-04-28 11:12 → 2000-04-25 11:12 A (-2925d) | 2008-04-28 17:12 → 2000-04-25 16:12 A (-2925d) | 0.5d → 0.38d | 0% → 100% | 0d → none | resources Karen [50%] → Karen [66.7%]; baseline start none → 2000-04-25 11:12; baseline finish none → 2000-04-25 16:12 |
| 70 | Tableau des ressources | 2008-04-28 17:12 → 2000-04-25 16:12 A (-2925d) | 2008-04-28 17:12 → 2000-04-25 16:12 A (-2925d) |  | 0% → 100% | 0d → none | baseline start none → 2000-04-25 16:12; baseline finish none → 2000-04-25 16:12 |

| ID | Task | Start | Finish | Duration | Complete | Total float | Other |
| --- | --- | --- | --- | --- | --- | --- | --- |
| 71 | Planning détaillé (suite) | 2008-04-28 17:12 → 2000-04-25 16:12 A (-2925d) | 2008-04-28 17:12 → 2000-04-25 16:12 A (-2925d) |  | 0% → 100% | 0d → none | baseline start none → 2000-04-25 16:12; baseline finish none → 2000-04-25 16:12 |
| 72 | **Validation** | 2008-04-28 17:12 → 2000-04-25 16:12 A (-2925d) | 2008-04-29 14:12 → 2000-04-26 11:12 A (-2925d) |  | 0% → 100% | 0d → none | baseline start none → 2000-04-25 16:12; baseline finish none → 2000-04-26 11:12 |
| 73 | Optimiser le planning détaillé du prévu | 2008-04-28 17:12 → 2000-04-25 16:12 A (-2925d) | 2008-04-29 10:12 → 2000-04-26 09:12 A (-2925d) |  | 0% → 100% | 0d → none | baseline start none → 2000-04-25 16:12; baseline finish none → 2000-04-26 09:12 |
| 74 | Planning détaillé (suite) | 2008-04-29 10:12 → 2000-04-26 09:12 A (-2925d) | 2008-04-29 10:12 → 2000-04-26 09:12 A (-2925d) |  | 0% → 100% | 0d → none | baseline start none → 2000-04-26 09:12; baseline finish none → 2000-04-26 09:12 |
| 75 | Valider, communiquer et enregistrer le planning | 2008-04-29 10:12 → 2000-04-26 09:12 A (-2925d) | 2008-04-29 14:12 → 2000-04-26 11:12 A (-2925d) |  | 0% → 100% | 0d → none | baseline start none → 2000-04-26 09:12; baseline finish none → 2000-04-26 11:12 |
| 76 | Contrat de planning | 2008-04-29 14:12 → 2000-04-26 11:12 A (-2925d) | 2008-04-29 14:12 → 2000-04-26 11:12 A (-2925d) |  | 0% → 100% | 0d → none | baseline start none → 2000-04-26 11:12; baseline finish none → 2000-04-26 11:12 |
| 77 | **Piloter le projet** | 2008-04-29 14:12 → 2000-04-26 11:12 A (-2925d) | 2008-04-30 09:12 → 2000-04-26 16:12 A (-2926d) | 0.5d → 0.38d | 0% → 100% | 0d → none | baseline start none → 2000-04-26 11:12; baseline finish none → 2000-04-26 16:12 |
| 78 | **Lancement** | 2008-04-29 14:12 → 2000-04-26 11:12 A (-2925d) | 2008-04-30 09:12 → 2000-04-26 16:12 A (-2926d) | 0.5d → 0.38d | 0% → 100% | 0d → none | baseline start none → 2000-04-26 11:12; baseline finish none → 2000-04-26 16:12 |
| 79 | Lancer la réalisation | 2008-04-29 14:12 → 2000-04-26 11:12 A (-2925d) | 2008-04-29 16:12 → 2000-04-26 14:12 A (-2925d) | 0.25d → 0.12d | 0% → 100% | 0d → none | resources Karen [25%]; Christophe [25%] → Karen [50%]; Christophe [50%]; baseline start none → 2000-04-26 11:12; baseline finish none → 2000-04-26 14:12 |
| 80 | Journal du projet | 2008-04-29 16:12 → 2000-04-26 14:12 A (-2925d) | 2008-04-29 16:12 → 2000-04-26 14:12 A (-2925d) |  | 0% → 100% | 0d → none | baseline start none → 2000-04-26 14:12; baseline finish none → 2000-04-26 14:12 |
| 81 | Fiche de reporting | 2008-04-29 16:12 → 2000-04-26 14:12 A (-2925d) | 2008-04-29 16:12 → 2000-04-26 14:12 A (-2925d) |  | 0% → 100% | 0d → none | baseline start none → 2000-04-26 14:12; baseline finish none → 2000-04-26 14:12 |
| 82 | Mettre en œuvre le plan de communication | 2008-04-29 16:12 → 2000-04-26 14:12 A (-2925d) | 2008-04-30 09:12 → 2000-04-26 16:12 A (-2926d) |  | 0% → 100% | 0d → none | baseline start none → 2000-04-26 14:12; baseline finish none → 2000-04-26 16:12 |
| 83 | Plan de communication (suite) | 2008-04-30 09:12 → 2000-04-26 16:12 A (-2926d) | 2008-04-30 09:12 → 2000-04-26 16:12 A (-2926d) |  | 0% → 100% | 0d → none | baseline start none → 2000-04-26 16:12; baseline finish none → 2000-04-26 16:12 |
| 84 | **FABRICATION DU PRODUIT** | 2008-04-30 09:12 → 2000-04-26 16:12 A (-2926d) | 2008-08-06 09:12 → 2000-09-18 10:12 (-2879d) | 61.25d → 86.13d | 0% → 45% | 0d → 4d | baseline start none → 2000-04-26 16:12; baseline finish none → 2000-08-30 09:12 |
| 85 | **Etude de la gestion des stocks** | 2008-04-30 09:12 → 2000-04-26 16:12 A (-2926d) | 2008-05-06 15:12 → 2000-05-18 16:12 A (-2910d) | 4d → 12.25d | 0% → 100% | 0d → none | baseline start none → 2000-04-26 16:12; baseline finish none → 2000-05-04 16:12 |
| 86 | **Etude opérationnelle** | 2008-04-30 09:12 → 2000-04-26 16:12 A (-2926d) | 2008-05-02 11:12 → 2000-05-15 16:12 A (-2909d) | 2d → 9.62d | 0% → 100% | 0d → none | baseline start none → 2000-04-26 16:12; baseline finish none → 2000-04-28 16:12 |
| 87 | Analyse de l'existant | 2008-04-30 09:12 → 2000-04-26 16:12 A (-2926d) | 2008-05-01 10:12 → 2000-05-12 16:12 A (-2911d) | 1d → 8.75d | 0% → 100% | 0d → none | resources Patrick [50%] → Patrick [57.1%]; baseline start none → 2000-04-26 16:12; baseline finish none → 2000-04-27 16:12 |
| 88 | Feuille d'analyse | 2008-05-01 10:12 → 2000-05-12 16:12 A (-2911d) | 2008-05-01 10:12 → 2000-05-12 16:12 A (-2911d) |  | 0% → 100% | 0d → none | baseline start none → 2000-04-27 16:12; baseline finish none → 2000-04-27 16:12 |
| 89 | Recherche des améliorations | 2008-05-01 10:12 → 2000-05-12 16:12 A (-2911d) | 2008-05-02 11:12 → 2000-05-15 16:12 A (-2909d) | 1d → 0.88d | 0% → 100% | 0d → none | resources Patrick [50%] → Patrick [57.1%]; baseline start none → 2000-04-27 16:12; baseline finish none → 2000-04-28 16:12 |
| 90 | Liste des améliorations | 2008-05-02 11:12 → 2000-05-15 16:12 A (-2909d) | 2008-05-02 11:12 → 2000-05-15 16:12 A (-2909d) |  | 0% → 100% | 0d → none | baseline start none → 2000-04-28 16:12; baseline finish none → 2000-04-28 16:12 |
| 91 | **Etude fonctionnelle** | 2008-04-30 09:12 → 2000-04-26 16:12 A (-2926d) | 2008-05-06 15:12 → 2000-05-18 16:12 A (-2910d) | 4d → 12.25d | 0% → 100% | 0d → none | baseline start none → 2000-04-26 16:12; baseline finish none → 2000-05-04 16:12 |
| 92 | Analyse de l'existant | 2008-04-30 09:12 → 2000-04-26 16:12 A (-2926d) | 2008-05-01 10:12 → 2000-04-27 16:12 A (-2926d) | 1d → 0.88d | 0% → 100% | 1d → none | resources Henri [50%] → Henri [57.1%]; baseline start none → 2000-04-26 16:12; baseline finish none → 2000-04-27 16:12 |
| 93 | Organigramme fonctionnel | 2008-05-02 11:12 → 2000-05-15 16:12 A (-2909d) | 2008-05-02 11:12 → 2000-05-15 16:12 A (-2909d) |  | 0% → 100% | 0d → none | baseline start none → 2000-04-28 16:12; baseline finish none → 2000-04-28 16:12 |
| 94 | Rédaction du cahier des charges | 2008-05-02 11:12 → 2000-05-15 16:12 A (-2909d) | 2008-05-06 15:12 → 2000-05-18 16:12 A (-2910d) | 2d → 1.62d | 0% → 100% | 0d → none | resources Henri [50%] → Henri [61.5%]; baseline start none → 2000-04-28 16:12; baseline finish none → 2000-05-04 16:12 |
| 95 | Cahier des charges | 2008-05-06 15:12 → 2000-05-18 16:12 A (-2910d) | 2008-05-06 15:12 → 2000-05-18 16:12 A (-2910d) |  | 0% → 100% | 0d → none | baseline start none → 2000-05-04 16:12; baseline finish none → 2000-05-04 16:12 |
| 96 | **Mise en place de la gestion des stocks** | 2008-05-06 15:12 → 2000-05-18 16:12 A (-2910d) | 2008-07-14 14:12 → 2000-07-26 17:54 (-2910d) | 42.75d → 41.34d | 0% → 78% | 18.5d → 36.54d | baseline start none → 2000-05-04 16:12; baseline finish none → 2000-07-19 15:09 |
| 97 | **Recherche progiciels** | 2008-05-06 15:12 → 2000-05-18 16:12 A (-2910d) | 2008-05-15 14:12 → 2000-05-23 16:12 A (-2914d) | 6d → 2.62d | 0% → 100% | 18.5d → none | baseline start none → 2000-05-04 16:12; baseline finish none → 2000-05-15 16:12 |
| 98 | Recherche des prestataires | 2008-05-06 15:12 → 2000-05-18 16:12 A (-2910d) | 2008-05-14 11:12 → 2000-05-22 16:12 A (-2914d) | 5d → 1.75d | 0% → 100% | 18.5d → none | resources Claudio [20%] → Claudio [22.9%]; baseline start none → 2000-05-04 16:12; baseline finish none → 2000-05-12 16:12 |
| 99 | Liste des prestataires | 2008-05-14 11:12 → 2000-05-22 16:12 A (-2914d) | 2008-05-14 11:12 → 2000-05-22 16:12 A (-2914d) |  | 0% → 100% | 18.5d → none | baseline start none → 2000-05-12 16:12; baseline finish none → 2000-05-12 16:12 |
| 100 | Présélection des progiciels | 2008-05-14 11:12 → 2000-05-22 16:12 A (-2914d) | 2008-05-15 14:12 → 2000-05-23 16:12 A (-2914d) | 1d → 0.88d | 0% → 100% | 18.5d → none | resources Claudio [50%] → Claudio [57.1%]; baseline start none → 2000-05-12 16:12; baseline finish none → 2000-05-15 16:12 |
| 101 | Liste des logiciels | 2008-05-15 14:12 → 2000-05-23 16:12 A (-2914d) | 2008-05-15 14:12 → 2000-05-23 16:12 A (-2914d) |  | 0% → 100% | 18.5d → none | baseline start none → 2000-05-15 16:12; baseline finish none → 2000-05-15 16:12 |
| 102 | **Choix progiciels** | 2008-05-15 14:12 → 2000-05-23 16:12 A (-2914d) | 2008-05-19 14:12 → 2000-05-26 14:12 A (-2915d) | 1.75d → 2.38d | 0% → 100% | 18.5d → none | baseline start none → 2000-05-15 16:12; baseline finish none → 2000-05-17 14:12 |
| 103 | Réalisation d'un dossier de choix | 2008-05-15 14:12 → 2000-05-23 16:12 A (-2914d) | 2008-05-16 15:12 → 2000-05-25 16:12 A (-2913d) | 1d → 1.75d | 0% → 100% | 18.5d → none | resources Claudio [50%] → Claudio [57.1%]; baseline start none → 2000-05-15 16:12; baseline finish none → 2000-05-16 16:12 |
| 104 | Choix du progiciel | 2008-05-16 15:12 → 2000-05-25 16:12 A (-2913d) | 2008-05-16 17:12 → 2000-05-26 09:12 A (-2912d) |  | 0% → 100% | 18.5d → none | resources Claudio [50%]; Henri; Patrick → Claudio [50%]; Henri [55.6%]; Patrick [55.6%]; baseline start none → 2000-05-16 16:12; baseline finish none → 2000-05-17 09:12 |
| 105 | Dossier de choix | 2008-05-16 17:12 → 2000-05-26 09:12 A (-2912d) | 2008-05-16 17:12 → 2000-05-26 09:12 A (-2912d) |  | 0% → 100% | 18.5d → none | baseline start none → 2000-05-17 09:12; baseline finish none → 2000-05-17 09:12 |
| 106 | Passage de la commande | 2008-05-16 17:12 → 2000-05-26 09:12 A (-2912d) | 2008-05-19 14:12 → 2000-05-26 14:12 A (-2915d) | 0.5d → 0.38d | 0% → 100% | 53.5d → none | resources Henri → Henri [133.3%]; baseline start none → 2000-05-17 09:12; baseline finish none → 2000-05-17 14:12 |
| 107 | Bon de commande | 2008-05-19 14:12 → 2000-05-26 14:12 A (-2915d) | 2008-05-19 14:12 → 2000-05-26 14:12 A (-2915d) |  | 0% → 100% | 53.5d → none | baseline start none → 2000-05-17 14:12; baseline finish none → 2000-05-17 14:12 |
| 108 | **Mise en place** | 2008-05-16 17:12 → 2000-05-26 09:12 A (-2912d) | 2008-05-28 11:12 → 2000-06-29 10:09 A (-2890d) | 6.5d → 19.37d | 0% → 100% | 47.5d → none | baseline start none → 2000-05-17 09:12; baseline finish none → 2000-06-19 15:09 |
| 109 | Commande des matériels | 2008-05-16 17:12 → 2000-05-26 09:12 A (-2912d) | 2008-05-19 14:12 → 2000-05-29 09:12 A (-2912d) | 0.5d → 0.88d | 0% → 100% | 47.5d → none | resources Claudio [50%] → Claudio [57.1%]; baseline start none → 2000-05-17 09:12; baseline finish none → 2000-05-17 14:12 |
| 110 | Bon de commande | 2008-05-19 14:12 → 2000-05-29 09:12 A (-2912d) | 2008-05-19 14:12 → 2000-05-29 09:12 A (-2912d) |  | 0% → 100% | 47.5d → none | baseline start none → 2000-05-17 14:12; baseline finish none → 2000-05-17 14:12 |
| 111 | Vérification des matériels | 2008-05-19 14:12 → 2000-05-29 09:12 A (-2912d) | 2008-05-20 15:12 → 2000-05-30 09:12 A (-2912d) | 1d → 0.88d | 0% → 100% | 47.5d → none | resources Programmeur 1 → Programmeur 1 [114.3%]; baseline start none → 2000-05-17 14:12; baseline finish none → 2000-05-18 14:12 |
| 112 | PV de réception | 2008-05-20 15:12 → 2000-05-30 09:12 A (-2912d) | 2008-05-20 15:12 → 2000-05-30 09:12 A (-2912d) |  | 0% → 100% | 47.5d → none | baseline start none → 2000-05-18 14:12; baseline finish none → 2000-05-18 14:12 |
| 113 | Installation des matériels | 2008-05-20 15:12 → 2000-05-30 09:12 A (-2912d) | 2008-05-21 16:12 → 2000-06-16 09:27 A (-2896d) | 1d → 0.88d | 0% → 100% | 48.5d → none | resources Programmeur 2 → Programmeur 2 [114.2%]; baseline start none → 2000-05-18 14:12; baseline finish none → 2000-06-05 14:27 |
| 114 | Installation du réseau | 2008-05-20 15:12 → 2000-05-30 09:12 A (-2912d) | 2008-05-22 17:12 → 2000-05-31 09:27 A (-2913d) | 2d → 0.88d | 0% → 100% | 47.5d → none | resources Claudio → Claudio [114.3%]; baseline start none → 2000-05-18 14:12; baseline finish none → 2000-05-22 14:27 |
| 115 | Partie matérielle installée | 2008-05-22 17:12 → 2000-06-16 09:27 A (-2897d) | 2008-05-22 17:12 → 2000-06-16 09:27 A (-2897d) |  | 0% → 100% | 47.5d → none | baseline start none → 2000-06-05 14:27; baseline finish none → 2000-06-05 14:27 |
| 116 | Installation des systèmes d'exploitation | 2008-05-22 17:12 → 2000-06-16 09:27 A (-2897d) | 2008-05-27 10:12 → 2000-06-20 09:42 A (-2898d) | 2d → 1.75d | 0% → 100% | 47.5d → none | resources Claudio → Claudio [114.3%]; baseline start none → 2000-06-05 14:27; baseline finish none → 2000-06-07 14:42 |
| 117 | Installation du progiciel de gestion des stocks | 2008-05-27 10:12 → 2000-06-20 09:42 A (-2898d) | 2008-05-28 11:12 → 2000-06-29 10:09 A (-2890d) | 1d → 0.12d | 0% → 100% | 47.5d → none | resources Programmeur 2 [50%] → Programmeur 2 [400%]; baseline start none → 2000-06-07 14:42; baseline finish none → 2000-06-19 15:09 |
| 118 | Partie logicielle installée | 2008-05-28 11:12 → 2000-06-29 10:09 A (-2890d) | 2008-05-28 11:12 → 2000-06-29 10:09 A (-2890d) |  | 0% → 100% | 47.5d → none | baseline start none → 2000-06-19 15:09; baseline finish none → 2000-06-19 15:09 |
| 119 | **Paramétrage** | 2008-05-16 17:12 → 2000-05-26 09:12 A (-2912d) | 2008-06-05 15:12 → 2000-06-29 09:42 A (-2898d) | 12d → 19.31d | 0% → 100% | 18.5d → none | baseline start none → 2000-05-17 09:12; baseline finish none → 2000-06-16 09:57 |
| 120 | Définition des paramètres | 2008-05-16 17:12 → 2000-05-26 09:12 A (-2912d) | 2008-05-21 10:12 → 2000-05-30 09:12 A (-2913d) | 2d → 1.75d | 0% → 100% | 18.5d → none | resources Patrick [25%] → Patrick [28.6%]; baseline start none → 2000-05-17 09:12; baseline finish none → 2000-05-19 09:12 |
| 121 | Paramétrage du logiciel | 2008-05-21 10:12 → 2000-05-30 09:12 A (-2913d) | 2008-06-05 15:12 → 2000-06-29 09:42 A (-2898d) | 10d → 13.33d | 0% → 100% | 18.5d → none | resources Programmeur 2 [80%]; Machine de développement 3 → Programmeur 2 [101.1%]; Machine de développement 3 [114.3%]; baseline start none → 2000-05-19 09:12; baseline finish none → 2000-06-16 09:57 |
| 122 | Logiciel paramétré | 2008-06-05 15:12 → 2000-06-29 09:42 A (-2898d) | 2008-06-05 15:12 → 2000-06-29 09:42 A (-2898d) |  | 0% → 100% | 42d → none | baseline start none → 2000-06-16 09:57; baseline finish none → 2000-06-16 09:57 |
| 123 | **Tests** | 2008-05-16 17:12 → 2000-05-26 09:12 A (-2912d) | 2008-06-10 14:12 → 2000-07-03 14:54 A (-2899d) | 14.5d → 21.46d | 0% → 100% | 18.5d → none | baseline start none → 2000-05-17 09:12; baseline finish none → 2000-06-20 15:09 |
| 124 | Définition des données de test | 2008-05-16 17:12 → 2000-05-26 09:12 A (-2912d) | 2008-05-21 10:12 → 2000-05-30 09:12 A (-2913d) | 2d → 1.75d | 0% → 100% | 28.5d → none | resources Patrick [50%] → Patrick [57.1%]; baseline start none → 2000-05-17 09:12; baseline finish none → 2000-05-19 09:12 |
| 125 | Tests du logiciel | 2008-06-05 15:12 → 2000-06-29 09:42 A (-2898d) | 2008-06-10 14:12 → 2000-07-03 14:54 A (-2899d) | 2.5d → 2.15d | 0% → 100% | 18.5d → none | resources Patrick [40%]; Programmeur 2 → Patrick [47.1%]; Programmeur 2 [114.3%]; baseline start none → 2000-06-16 09:57; baseline finish none → 2000-06-20 15:09 |
| 126 | Logiciel testé | 2008-06-10 14:12 → 2000-07-03 14:54 A (-2899d) | 2008-06-10 14:12 → 2000-07-03 14:54 A (-2899d) |  | 0% → 100% | 18.5d → none | baseline start none → 2000-06-20 15:09; baseline finish none → 2000-06-20 15:09 |
| 127 | **Recette** | 2008-06-10 14:12 → 2000-07-03 14:54 A (-2899d) | 2008-06-27 09:12 → 2000-07-11 14:54 A (-2908d) | 11d → 5.25d | 0% → 100% | 18.5d → none | baseline start none → 2000-06-20 15:09; baseline finish none → 2000-07-05 15:09 |
| 128 | Effectuer la recette | 2008-06-10 14:12 → 2000-07-03 14:54 A (-2899d) | 2008-06-11 15:12 → 2000-07-04 14:54 A (-2899d) | 1d → 0.88d | 0% → 100% | 18.5d → none | resources Henri → Henri [114.3%]; baseline start none → 2000-06-20 15:09; baseline finish none → 2000-06-21 15:09 |
| 129 | PV de recette | 2008-06-11 15:12 → 2000-07-04 14:54 A (-2899d) | 2008-06-11 15:12 → 2000-07-04 14:54 A (-2899d) |  | 0% → 100% | 18.5d → none | baseline start none → 2000-06-21 15:09; baseline finish none → 2000-06-21 15:09 |
| 130 | Mettre en production | 2008-06-11 15:12 → 2000-07-04 14:54 A (-2899d) | 2008-06-27 09:12 → 2000-07-11 14:54 A (-2908d) | 10d → 4.38d | 0% → 100% | 18.5d → none | resources Programmeur 2 [20%] → Programmeur 2 [22.9%]; baseline start none → 2000-06-21 15:09; baseline finish none → 2000-07-05 15:09 |
| 131 | Logiciel opérationnel | 2008-06-27 09:12 → 2000-07-11 14:54 A (-2908d) | 2008-06-27 09:12 → 2000-07-11 14:54 A (-2908d) |  | 0% → 100% | 18.5d → none | baseline start none → 2000-07-05 15:09; baseline finish none → 2000-07-05 15:09 |
| 132 | **Formation** | 2008-06-27 09:12 → 2000-07-11 14:54 (-2908d) | 2008-07-14 14:12 → 2000-07-26 17:54 (-2910d) |  |  | 18.5d → 36.54d | baseline start none → 2000-07-05 15:09; baseline finish none → 2000-07-19 15:09 |
| 133 | Former les utilisateurs | 2008-06-27 09:12 → 2000-07-11 14:54 (-2908d) | 2008-07-14 14:12 → 2000-07-26 17:54 (-2910d) |  |  | 18.5d → 36.54d | baseline start none → 2000-07-05 15:09; baseline finish none → 2000-07-19 15:09 |
| 134 | Utilisateurs formés | 2008-07-14 14:12 → 2000-07-26 17:54 (-2910d) | 2008-07-14 14:12 → 2000-07-26 17:54 (-2910d) |  |  | 18.5d → 36.54d | baseline start none → 2000-07-19 15:09; baseline finish none → 2000-07-19 15:09 |
| 135 | **Etude du site internet** | 2008-05-06 15:12 → 2000-05-18 16:12 A (-2910d) | 2008-05-26 15:12 → 2000-06-07 09:12 A (-2910d) | 12.25d → 10.75d | 0% → 100% | 0d → none | baseline start none → 2000-05-04 16:12; baseline finish none → 2000-05-24 09:12 |
| 136 | **Définition fonctions** | 2008-05-06 15:12 → 2000-05-18 16:12 A (-2910d) | 2008-05-14 11:12 → 2000-05-25 16:12 A (-2911d) | 5d → 4.38d | 0% → 100% | 0d → none | baseline start none → 2000-05-04 16:12; baseline finish none → 2000-05-12 16:12 |
| 137 | Définir les fonctions | 2008-05-06 15:12 → 2000-05-18 16:12 A (-2910d) | 2008-05-12 09:12 → 2000-05-23 16:12 A (-2911d) | 3d → 2.62d | 0% → 100% | 0d → none | resources Henri [33.3%] → Henri [38.1%]; baseline start none → 2000-05-04 16:12; baseline finish none → 2000-05-10 16:12 |
| 138 | Rédiger le cahier des charges | 2008-05-12 09:12 → 2000-05-23 16:12 A (-2911d) | 2008-05-14 11:12 → 2000-05-25 16:12 A (-2911d) | 2d → 1.75d | 0% → 100% | 0d → none | resources Henri [50%] → Henri [57.1%]; baseline start none → 2000-05-10 16:12; baseline finish none → 2000-05-12 16:12 |
| 139 | Cahier des charges | 2008-05-14 11:12 → 2000-05-25 16:12 A (-2911d) | 2008-05-14 11:12 → 2000-05-25 16:12 A (-2911d) |  | 0% → 100% | 0d → none | baseline start none → 2000-05-12 16:12; baseline finish none → 2000-05-12 16:12 |
| 140 | **Définition interfaces** | 2008-05-14 11:12 → 2000-05-25 16:12 A (-2911d) | 2008-05-26 15:12 → 2000-06-07 09:12 A (-2910d) | 7.25d → 6.38d | 0% → 100% | 0d → none | baseline start none → 2000-05-12 16:12; baseline finish none → 2000-05-24 09:12 |

| ID | Task | Start | Finish | Duration | Complete | Total float | Other |
| --- | --- | --- | --- | --- | --- | --- | --- |
| 141 | Faire les maquettes | 2008-05-14 11:12 → 2000-05-25 16:12 A (-2911d) | 2008-05-23 14:12 → 2000-06-06 09:12 A (-2908d) | 6.25d → 5.5d | 0% → 100% | 0d → none | resources François [80%] → François [90.9%]; baseline start none → 2000-05-12 16:12; baseline finish none → 2000-05-23 09:12 |
| 142 | Valider les maquettes | 2008-05-23 14:12 → 2000-06-06 09:12 A (-2908d) | 2008-05-26 15:12 → 2000-06-07 09:12 A (-2910d) | 1d → 0.88d | 0% → 100% | 0d → none | resources Henri [50%] → Henri [57.1%]; baseline start none → 2000-05-23 09:12; baseline finish none → 2000-05-24 09:12 |
| 143 | Maquettes validées | 2008-05-26 15:12 → 2000-06-07 09:12 A (-2910d) | 2008-05-26 15:12 → 2000-06-07 09:12 A (-2910d) |  | 0% → 100% | 0d → none | baseline start none → 2000-05-24 09:12; baseline finish none → 2000-05-24 09:12 |
| 144 | **Mise en place du site** | 2008-05-26 15:12 → 2000-06-07 09:12 A (-2910d) | 2008-06-30 16:12 → 2000-08-10 17:12 (-2881d) | 22d → 40.13d | 0% → 20% |  | baseline start none → 2000-05-24 09:12; baseline finish none → 2000-07-28 09:12 |
| 145 | **Développements** | 2008-05-26 15:12 → 2000-06-07 09:12 A (-2910d) | 2008-06-19 17:12 → 2000-08-08 11:12 (-2872d) | 16d → 37.88d | 0% → 22% |  | baseline start none → 2000-05-24 09:12; baseline finish none → 2000-07-20 09:12 |
| 146 | Définir le nombre de prototypes | 2008-05-26 15:12 → 2000-06-07 09:12 A (-2910d) | 2008-05-27 16:12 → 2000-06-08 10:12 (-2910d) |  | 0% → 25% | 0d → 15.94d | baseline start none → 2000-05-24 09:12; baseline finish none → 2000-05-25 09:12 |
| 147 | Réaliser le prototype (n fois) | 2008-05-27 16:12 → 2000-06-08 09:12 A (-2910d) | 2008-06-19 17:12 → 2000-07-17 09:27 (-2894d) | 15d → 14.97d | 0% → 14% | 0d → 10.47d | baseline start none → 2000-05-25 09:12; baseline finish none → 2000-06-29 09:27 |
| 148 | Tester le prototype (n fois) | 2008-05-27 16:12 → 2000-06-21 09:12 A (-2897d) | 2008-06-19 17:12 → 2000-08-08 11:12 (-2872d) | 15d → 23.47d | 0% → 25% | 0d → -3.75d | baseline start none → 2000-06-07 09:12; baseline finish none → 2000-07-20 09:12 |
| 149 | Définir les améliorations (n fois) | 2008-05-27 16:12 → 2000-06-08 09:12 A (-2910d) | 2008-06-19 17:12 → 2000-07-17 14:57 (-2894d) | 15d → 22.47d | 0% → 24% | 0d → 10.03d | baseline start none → 2000-05-25 09:12; baseline finish none → 2000-06-29 10:57 |
| 150 | Prototypes (n) | 2008-06-19 17:12 → 2000-08-02 09:12 A (-2878d) | 2008-06-19 17:12 → 2000-08-02 09:12 (-2878d) |  | 0% → 25% |  | baseline start none → 2000-07-20 09:12; baseline finish none → 2000-07-20 09:12 |
| 151 | **Installation** | 2008-06-19 17:12 → 2000-08-02 09:12 (-2878d) | 2008-06-30 16:12 → 2000-08-10 17:12 (-2881d) |  |  |  | baseline start none → 2000-07-20 09:12; baseline finish none → 2000-07-28 09:12 |
| 152 | Réaliser l'installation avec le prestataire d'accès | 2008-06-19 17:12 → 2000-08-02 09:12 (-2878d) | 2008-06-30 16:12 → 2000-08-10 17:12 (-2881d) |  |  |  | baseline start none → 2000-07-20 09:12; baseline finish none → 2000-07-28 09:12 |
| 153 | Accès internet | 2008-06-30 16:12 → 2000-08-10 17:12 (-2881d) | 2008-06-30 16:12 → 2000-08-10 17:12 (-2881d) |  |  |  | baseline start none → 2000-07-28 09:12; baseline finish none → 2000-07-28 09:12 |
| 154 | **Mise en production du site** | 2008-06-30 16:12 → 2000-08-10 17:12 (-2881d) | 2008-08-06 09:12 → 2000-09-18 10:12 (-2879d) |  |  |  | baseline start none → 2000-07-28 09:12; baseline finish none → 2000-08-30 09:12 |
| 155 | **Test finaux** | 2008-06-30 16:12 → 2000-08-10 17:12 (-2881d) | 2008-07-16 10:12 → 2000-08-28 11:12 (-2879d) |  |  |  | baseline start none → 2000-07-28 09:12; baseline finish none → 2000-08-11 09:12 |
| 156 | Faire les tests finaux | 2008-06-30 16:12 → 2000-08-10 17:12 (-2881d) | 2008-07-16 10:12 → 2000-08-28 11:12 (-2879d) |  |  |  | baseline start none → 2000-07-28 09:12; baseline finish none → 2000-08-11 09:12 |
| 157 | **Recette** | 2008-07-16 10:12 → 2000-08-28 11:12 (-2879d) | 2008-07-21 15:12 → 2000-08-31 16:12 (-2881d) |  |  |  | baseline start none → 2000-08-11 09:12; baseline finish none → 2000-08-16 09:12 |
| 158 | Effectuer la recette | 2008-07-16 10:12 → 2000-08-28 11:12 (-2879d) | 2008-07-21 15:12 → 2000-08-31 16:12 (-2881d) |  |  |  | baseline start none → 2000-08-11 09:12; baseline finish none → 2000-08-16 09:12 |
| 159 | PV de recette | 2008-07-21 15:12 → 2000-08-31 16:12 (-2881d) | 2008-07-21 15:12 → 2000-08-31 16:12 (-2881d) |  |  |  | baseline start none → 2000-08-16 09:12; baseline finish none → 2000-08-16 09:12 |
| 160 | **Formation** | 2008-07-21 15:12 → 2000-08-31 16:12 (-2881d) | 2008-08-06 09:12 → 2000-09-18 10:12 (-2879d) |  |  |  | baseline start none → 2000-08-16 09:12; baseline finish none → 2000-08-30 09:12 |
| 161 | Elaborer la doc utilisateurs | 2008-07-21 15:12 → 2000-08-31 16:12 (-2881d) | 2008-07-29 11:12 → 2000-09-08 14:12 (-2881d) |  |  |  | baseline start none → 2000-08-16 09:12; baseline finish none → 2000-08-23 09:12 |
| 162 | Doc utilisateurs | 2008-07-29 11:12 → 2000-09-08 14:12 (-2881d) | 2008-07-29 11:12 → 2000-09-08 14:12 (-2881d) |  |  |  | baseline start none → 2000-08-23 09:12; baseline finish none → 2000-08-23 09:12 |
| 163 | Former les utilisateurs | 2008-07-29 11:12 → 2000-09-08 14:12 (-2881d) | 2008-08-06 09:12 → 2000-09-18 10:12 (-2879d) |  |  |  | baseline start none → 2000-08-23 09:12; baseline finish none → 2000-08-30 09:12 |
| 164 | Utilisateurs formés | 2008-08-06 09:12 → 2000-09-18 10:12 (-2879d) | 2008-08-06 09:12 → 2000-09-18 10:12 (-2879d) |  |  |  | baseline start none → 2000-08-30 09:12; baseline finish none → 2000-08-30 09:12 |
| 165 | **GESTION DU PROJET** | 2000-06-26 09:00 → 2000-04-17 08:00 (-70d) | 2008-08-12 15:12 → 2000-09-22 16:12 (-2881d) | 1856.4d → 96.9d |  |  | baseline start none → 2000-04-17 08:00; baseline finish none → 2000-09-05 09:12 |
| 166 | **Piloter le projet** | 2000-06-26 09:00 → 2000-04-17 08:00 (-70d) | 2008-08-07 10:12 → 2000-09-19 11:12 (-2879d) | 1853.4d → 93.9d |  |  | baseline start none → 2000-04-17 08:00; baseline finish none → 2000-08-31 09:12 |
| 167 | **Réalisation** | 2000-06-26 09:00 → 2000-04-17 08:00 (-70d) | 2008-08-07 10:12 → 2000-09-19 11:12 (-2879d) | 1853.4d → 93.9d |  |  | baseline start none → 2000-04-17 08:00; baseline finish none → 2000-08-31 09:12 |
| 168 | **Piloter la réalisation du produit** | 2000-06-26 09:00 → 2000-04-17 08:00 (-70d) | 2008-08-07 10:12 → 2000-09-19 11:12 (-2879d) | 1853.4d → 93.9d |  |  | baseline start none → 2000-04-17 08:00; baseline finish none → 2000-08-31 09:12 |
| 169 | **Reporting CAPS** | 2008-04-17 09:00 → 2000-04-26 09:00 (-2913d) | 2008-08-01 09:15 → 2000-07-19 09:15 (-2935d) | 66.53d → 49.03d |  | 6.62d → 41.75d | baseline start none → 2000-04-26 08:00; baseline finish none → 2000-07-19 08:15 |
| 170 | Reporting CAPS 1 | 2008-04-17 09:00 → 2000-04-26 09:00 (-2913d) | 2008-04-17 09:15 → 2000-04-26 09:15 (-2913d) |  |  | 73.12d → 90.75d | constraint start no earlier than 2008-04-17 08:00 → start no earlier than 2000-04-26 08:00; resources none → Claudio; François; Infographiste; Programmeur 1; Programmeur 2; baseline start none → 2000-04-26 08:00; baseline finish none → 2000-04-26 08:15 |
| 171 | Reporting CAPS 2 | 2008-04-18 09:00 → 2000-04-27 09:00 (-2913d) | 2008-04-18 09:15 → 2000-04-27 09:15 (-2913d) |  |  | 72.24d → 89.87d | constraint start no earlier than 2008-04-18 08:00 → start no earlier than 2000-04-27 08:00; resources none → Claudio; François; Infographiste; Programmeur 1; Programmeur 2; baseline start none → 2000-04-27 08:00; baseline finish none → 2000-04-27 08:15 |
| 172 | Reporting CAPS 3 | 2008-04-21 09:00 → 2000-04-28 09:00 (-2915d) | 2008-04-21 09:15 → 2000-04-28 09:15 (-2915d) |  |  | 71.37d → 89d | constraint start no earlier than 2008-04-19 08:00 → start no earlier than 2000-04-28 08:00; resources none → Claudio; François; Infographiste; Programmeur 1; Programmeur 2; baseline start none → 2000-04-28 08:00; baseline finish none → 2000-04-28 08:15 |
| 173 | Reporting CAPS 4 | 2008-04-21 09:00 → 2000-05-02 09:00 (-2911d) | 2008-04-21 09:15 → 2000-05-02 09:15 (-2911d) |  |  | 71.37d → 88.12d | constraint start no earlier than 2008-04-20 08:00 → start no earlier than 2000-05-02 08:00; resources none → Claudio; François; Infographiste; Programmeur 1; Programmeur 2; baseline start none → 2000-05-02 08:00; baseline finish none → 2000-05-02 08:15 |
| 174 | Reporting CAPS 5 | 2008-04-21 09:00 → 2000-05-03 09:00 (-2910d) | 2008-04-21 09:15 → 2000-05-03 09:15 (-2910d) |  |  | 71.37d → 87.25d | constraint start no earlier than 2008-04-21 08:00 → start no earlier than 2000-05-03 08:00; resources none → Claudio; François; Infographiste; Programmeur 1; Programmeur 2; baseline start none → 2000-05-03 08:00; baseline finish none → 2000-05-03 08:15 |
| 175 | Reporting CAPS 6 | 2008-04-22 09:00 → 2000-05-04 09:00 (-2910d) | 2008-04-22 09:15 → 2000-05-04 09:15 (-2910d) |  |  | 70.49d → 86.37d | constraint start no earlier than 2008-04-22 08:00 → start no earlier than 2000-05-04 08:00; resources none → Claudio; François; Infographiste; Programmeur 1; Programmeur 2; baseline start none → 2000-05-04 08:00; baseline finish none → 2000-05-04 08:15 |
| 176 | Reporting CAPS 7 | 2008-04-23 09:00 → 2000-05-05 09:00 (-2910d) | 2008-04-23 09:15 → 2000-05-05 09:15 (-2910d) |  |  | 69.62d → 85.5d | constraint start no earlier than 2008-04-23 08:00 → start no earlier than 2000-05-05 08:00; resources none → Claudio; François; Infographiste; Programmeur 1; Programmeur 2; baseline start none → 2000-05-05 08:00; baseline finish none → 2000-05-05 08:15 |
| 177 | Reporting CAPS 8 | 2008-04-24 09:00 → 2000-05-09 09:00 (-2907d) | 2008-04-24 09:15 → 2000-05-09 09:15 (-2907d) |  |  | 68.74d → 84.62d | constraint start no earlier than 2008-04-24 08:00 → start no earlier than 2000-05-09 08:00; resources none → Claudio; François; Infographiste; Programmeur 1; Programmeur 2; baseline start none → 2000-05-09 08:00; baseline finish none → 2000-05-09 08:15 |
| 178 | Reporting CAPS 9 | 2008-04-25 09:00 → 2000-05-10 09:00 (-2907d) | 2008-04-25 09:15 → 2000-05-10 09:15 (-2907d) |  |  | 67.87d → 83.75d | constraint start no earlier than 2008-04-25 08:00 → start no earlier than 2000-05-10 08:00; resources none → Claudio; François; Infographiste; Programmeur 1; Programmeur 2; baseline start none → 2000-05-10 08:00; baseline finish none → 2000-05-10 08:15 |
| 179 | Reporting CAPS 10 | 2008-04-28 09:00 → 2000-05-11 09:00 (-2909d) | 2008-04-28 09:15 → 2000-05-11 09:15 (-2909d) |  |  | 66.99d → 82.87d | constraint start no earlier than 2008-04-26 08:00 → start no earlier than 2000-05-11 08:00; resources none → Claudio; François; Infographiste; Programmeur 1; Programmeur 2; baseline start none → 2000-05-11 08:00; baseline finish none → 2000-05-11 08:15 |
| 180 | Reporting CAPS 11 | 2008-04-28 09:00 → 2000-05-12 09:00 (-2908d) | 2008-04-28 09:15 → 2000-05-12 09:15 (-2908d) |  |  | 66.99d → 82d | constraint start no earlier than 2008-04-27 08:00 → start no earlier than 2000-05-12 08:00; resources none → Claudio; François; Infographiste; Programmeur 1; Programmeur 2; baseline start none → 2000-05-12 08:00; baseline finish none → 2000-05-12 08:15 |
| 181 | Reporting CAPS 12 | 2008-04-28 09:00 → 2000-05-15 09:00 (-2905d) | 2008-04-28 09:15 → 2000-05-15 09:15 (-2905d) |  |  | 66.99d → 81.12d | constraint start no earlier than 2008-04-28 08:00 → start no earlier than 2000-05-15 08:00; resources none → Claudio; François; Infographiste; Programmeur 1; Programmeur 2; baseline start none → 2000-05-15 08:00; baseline finish none → 2000-05-15 08:15 |
| 182 | Reporting CAPS 13 | 2008-04-29 09:00 → 2000-05-16 09:00 (-2905d) | 2008-04-29 09:15 → 2000-05-16 09:15 (-2905d) |  |  | 66.12d → 80.25d | constraint start no earlier than 2008-04-29 08:00 → start no earlier than 2000-05-16 08:00; resources none → Claudio; François; Infographiste; Programmeur 1; Programmeur 2; baseline start none → 2000-05-16 08:00; baseline finish none → 2000-05-16 08:15 |
| 183 | Reporting CAPS 14 | 2008-04-30 09:00 → 2000-05-17 09:00 (-2905d) | 2008-04-30 09:15 → 2000-05-17 09:15 (-2905d) |  |  | 65.24d → 79.37d | constraint start no earlier than 2008-04-30 08:00 → start no earlier than 2000-05-17 08:00; resources none → Claudio; François; Infographiste; Programmeur 1; Programmeur 2; baseline start none → 2000-05-17 08:00; baseline finish none → 2000-05-17 08:15 |
| 184 | Reporting CAPS 15 | 2008-05-01 09:00 → 2000-05-18 09:00 (-2905d) | 2008-05-01 09:15 → 2000-05-18 09:15 (-2905d) |  |  | 64.37d → 78.5d | constraint start no earlier than 2008-05-01 08:00 → start no earlier than 2000-05-18 08:00; resources none → Claudio; François; Infographiste; Programmeur 1; Programmeur 2; baseline start none → 2000-05-18 08:00; baseline finish none → 2000-05-18 08:15 |
| 185 | Reporting CAPS 16 | 2008-05-02 09:00 → 2000-05-19 09:00 (-2905d) | 2008-05-02 09:15 → 2000-05-19 09:15 (-2905d) |  |  | 63.49d → 77.62d | constraint start no earlier than 2008-05-02 08:00 → start no earlier than 2000-05-19 08:00; resources none → Claudio; François; Infographiste; Programmeur 1; Programmeur 2; baseline start none → 2000-05-19 08:00; baseline finish none → 2000-05-19 08:15 |
| 186 | Reporting CAPS 17 | 2008-05-05 09:00 → 2000-05-22 09:00 (-2905d) | 2008-05-05 09:15 → 2000-05-22 09:15 (-2905d) |  |  | 62.62d → 76.75d | constraint start no earlier than 2008-05-03 08:00 → start no earlier than 2000-05-22 08:00; resources none → Claudio; François; Infographiste; Programmeur 1; Programmeur 2; baseline start none → 2000-05-22 08:00; baseline finish none → 2000-05-22 08:15 |
| 187 | Reporting CAPS 18 | 2008-05-05 09:00 → 2000-05-23 09:00 (-2904d) | 2008-05-05 09:15 → 2000-05-23 09:15 (-2904d) |  |  | 62.62d → 75.87d | constraint start no earlier than 2008-05-04 08:00 → start no earlier than 2000-05-23 08:00; resources none → Claudio; François; Infographiste; Programmeur 1; Programmeur 2; baseline start none → 2000-05-23 08:00; baseline finish none → 2000-05-23 08:15 |
| 188 | Reporting CAPS 19 | 2008-05-05 09:00 → 2000-05-24 09:00 (-2903d) | 2008-05-05 09:15 → 2000-05-24 09:15 (-2903d) |  |  | 62.62d → 75d | constraint start no earlier than 2008-05-05 08:00 → start no earlier than 2000-05-24 08:00; resources none → Claudio; François; Infographiste; Programmeur 1; Programmeur 2; baseline start none → 2000-05-24 08:00; baseline finish none → 2000-05-24 08:15 |
| 189 | Reporting CAPS 20 | 2008-05-06 09:00 → 2000-05-25 09:00 (-2903d) | 2008-05-06 09:15 → 2000-05-25 09:15 (-2903d) |  |  | 61.74d → 74.12d | constraint start no earlier than 2008-05-06 08:00 → start no earlier than 2000-05-25 08:00; resources none → Claudio; François; Infographiste; Programmeur 1; Programmeur 2; baseline start none → 2000-05-25 08:00; baseline finish none → 2000-05-25 08:15 |
| 190 | Reporting CAPS 21 | 2008-05-07 09:00 → 2000-05-26 09:00 (-2903d) | 2008-05-07 09:15 → 2000-05-26 09:15 (-2903d) |  |  | 60.87d → 73.25d | constraint start no earlier than 2008-05-07 08:00 → start no earlier than 2000-05-26 08:00; resources none → Claudio; François; Infographiste; Programmeur 1; Programmeur 2; baseline start none → 2000-05-26 08:00; baseline finish none → 2000-05-26 08:15 |
| 191 | Reporting CAPS 22 | 2008-05-08 09:00 → 2000-05-29 09:00 (-2901d) | 2008-05-08 09:15 → 2000-05-29 09:15 (-2901d) |  |  | 59.99d → 72.37d | constraint start no earlier than 2008-05-08 08:00 → start no earlier than 2000-05-29 08:00; resources none → Claudio; François; Infographiste; Programmeur 1; Programmeur 2; baseline start none → 2000-05-29 08:00; baseline finish none → 2000-05-29 08:15 |
| 192 | Reporting CAPS 23 | 2008-05-09 09:00 → 2000-05-30 09:00 (-2901d) | 2008-05-09 09:15 → 2000-05-30 09:15 (-2901d) |  |  | 59.12d → 71.5d | constraint start no earlier than 2008-05-09 08:00 → start no earlier than 2000-05-30 08:00; resources none → Claudio; François; Infographiste; Programmeur 1; Programmeur 2; baseline start none → 2000-05-30 08:00; baseline finish none → 2000-05-30 08:15 |
| 193 | Reporting CAPS 24 | 2008-05-12 09:00 → 2000-05-31 09:00 (-2903d) | 2008-05-12 09:15 → 2000-05-31 09:15 (-2903d) |  |  | 58.24d → 70.62d | constraint start no earlier than 2008-05-10 08:00 → start no earlier than 2000-05-31 08:00; resources none → Claudio; François; Infographiste; Programmeur 1; Programmeur 2; baseline start none → 2000-05-31 08:00; baseline finish none → 2000-05-31 08:15 |
| 194 | Reporting CAPS 25 | 2008-05-12 09:00 → 2000-06-02 09:00 (-2901d) | 2008-05-12 09:15 → 2000-06-02 09:15 (-2901d) |  |  | 58.24d → 69.75d | constraint start no earlier than 2008-05-11 08:00 → start no earlier than 2000-06-02 08:00; resources none → Claudio; François; Infographiste; Programmeur 1; Programmeur 2; baseline start none → 2000-06-02 08:00; baseline finish none → 2000-06-02 08:15 |
| 195 | Reporting CAPS 26 | 2008-05-12 09:00 → 2000-06-05 09:00 (-2898d) | 2008-05-12 09:15 → 2000-06-05 09:15 (-2898d) |  |  | 58.24d → 68.87d | constraint start no earlier than 2008-05-12 08:00 → start no earlier than 2000-06-05 08:00; resources none → Claudio; François; Infographiste; Programmeur 1; Programmeur 2; baseline start none → 2000-06-05 08:00; baseline finish none → 2000-06-05 08:15 |
| 196 | Reporting CAPS 27 | 2008-05-13 09:00 → 2000-06-06 09:00 (-2898d) | 2008-05-13 09:15 → 2000-06-06 09:15 (-2898d) |  |  | 57.37d → 68d | constraint start no earlier than 2008-05-13 08:00 → start no earlier than 2000-06-06 08:00; resources none → Claudio; François; Infographiste; Programmeur 1; Programmeur 2; baseline start none → 2000-06-06 08:00; baseline finish none → 2000-06-06 08:15 |
| 197 | Reporting CAPS 28 | 2008-05-14 09:00 → 2000-06-07 09:00 (-2898d) | 2008-05-14 09:15 → 2000-06-07 09:15 (-2898d) |  |  | 56.49d → 67.12d | constraint start no earlier than 2008-05-14 08:00 → start no earlier than 2000-06-07 08:00; resources none → Claudio; François; Infographiste; Programmeur 1; Programmeur 2; baseline start none → 2000-06-07 08:00; baseline finish none → 2000-06-07 08:15 |
| 198 | Reporting CAPS 29 | 2008-05-15 09:00 → 2000-06-08 09:00 (-2898d) | 2008-05-15 09:15 → 2000-06-08 09:15 (-2898d) |  |  | 55.62d → 66.25d | constraint start no earlier than 2008-05-15 08:00 → start no earlier than 2000-06-08 08:00; resources none → Claudio; François; Infographiste; Programmeur 1; Programmeur 2; baseline start none → 2000-06-08 08:00; baseline finish none → 2000-06-08 08:15 |
| 199 | Reporting CAPS 30 | 2008-05-16 09:00 → 2000-06-09 09:00 (-2898d) | 2008-05-16 09:15 → 2000-06-09 09:15 (-2898d) |  |  | 54.74d → 65.37d | constraint start no earlier than 2008-05-16 08:00 → start no earlier than 2000-06-09 08:00; resources none → Claudio; François; Infographiste; Programmeur 1; Programmeur 2; baseline start none → 2000-06-09 08:00; baseline finish none → 2000-06-09 08:15 |
| 200 | Reporting CAPS 31 | 2008-05-19 09:00 → 2000-06-13 09:00 (-2897d) | 2008-05-19 09:15 → 2000-06-13 09:15 (-2897d) |  |  | 53.87d → 64.5d | constraint start no earlier than 2008-05-17 08:00 → start no earlier than 2000-06-13 08:00; resources none → Claudio; François; Infographiste; Programmeur 1; Programmeur 2; baseline start none → 2000-06-13 08:00; baseline finish none → 2000-06-13 08:15 |
| 201 | Reporting CAPS 32 | 2008-05-19 09:00 → 2000-06-14 09:00 (-2896d) | 2008-05-19 09:15 → 2000-06-14 09:15 (-2896d) |  |  | 53.87d → 63.62d | constraint start no earlier than 2008-05-18 08:00 → start no earlier than 2000-06-14 08:00; resources none → Claudio; François; Infographiste; Programmeur 1; Programmeur 2; baseline start none → 2000-06-14 08:00; baseline finish none → 2000-06-14 08:15 |
| 202 | Reporting CAPS 33 | 2008-05-19 09:00 → 2000-06-15 09:00 (-2895d) | 2008-05-19 09:15 → 2000-06-15 09:15 (-2895d) |  |  | 53.87d → 62.75d | constraint start no earlier than 2008-05-19 08:00 → start no earlier than 2000-06-15 08:00; resources none → Claudio; François; Infographiste; Programmeur 1; Programmeur 2; baseline start none → 2000-06-15 08:00; baseline finish none → 2000-06-15 08:15 |
| 203 | Reporting CAPS 34 | 2008-05-20 09:00 → 2000-06-16 09:00 (-2895d) | 2008-05-20 09:15 → 2000-06-16 09:15 (-2895d) |  |  | 52.99d → 61.87d | constraint start no earlier than 2008-05-20 08:00 → start no earlier than 2000-06-16 08:00; resources none → Claudio; François; Infographiste; Programmeur 1; Programmeur 2; baseline start none → 2000-06-16 08:00; baseline finish none → 2000-06-16 08:15 |
| 204 | Reporting CAPS 35 | 2008-05-21 09:00 → 2000-06-19 09:00 (-2893d) | 2008-05-21 09:15 → 2000-06-19 09:15 (-2893d) |  |  | 52.12d → 61d | constraint start no earlier than 2008-05-21 08:00 → start no earlier than 2000-06-19 08:00; resources none → Claudio; François; Infographiste; Programmeur 1; Programmeur 2; baseline start none → 2000-06-19 08:00; baseline finish none → 2000-06-19 08:15 |
| 205 | Reporting CAPS 36 | 2008-05-22 09:00 → 2000-06-20 09:00 (-2893d) | 2008-05-22 09:15 → 2000-06-20 09:15 (-2893d) |  |  | 51.24d → 60.12d | constraint start no earlier than 2008-05-22 08:00 → start no earlier than 2000-06-20 08:00; resources none → Claudio; François; Infographiste; Programmeur 1; Programmeur 2; baseline start none → 2000-06-20 08:00; baseline finish none → 2000-06-20 08:15 |
| 206 | Reporting CAPS 37 | 2008-05-23 09:00 → 2000-06-21 09:00 (-2893d) | 2008-05-23 09:15 → 2000-06-21 09:15 (-2893d) |  |  | 50.37d → 59.25d | constraint start no earlier than 2008-05-23 08:00 → start no earlier than 2000-06-21 08:00; resources none → Claudio; François; Infographiste; Programmeur 1; Programmeur 2; baseline start none → 2000-06-21 08:00; baseline finish none → 2000-06-21 08:15 |
| 207 | Reporting CAPS 38 | 2008-05-26 09:00 → 2000-06-22 09:00 (-2895d) | 2008-05-26 09:15 → 2000-06-22 09:15 (-2895d) |  |  | 49.49d → 58.37d | constraint start no earlier than 2008-05-24 08:00 → start no earlier than 2000-06-22 08:00; resources none → Claudio; François; Infographiste; Programmeur 1; Programmeur 2; baseline start none → 2000-06-22 08:00; baseline finish none → 2000-06-22 08:15 |
| 208 | Reporting CAPS 39 | 2008-05-26 09:00 → 2000-06-23 09:00 (-2894d) | 2008-05-26 09:15 → 2000-06-23 09:15 (-2894d) |  |  | 49.49d → 57.5d | constraint start no earlier than 2008-05-25 08:00 → start no earlier than 2000-06-23 08:00; resources none → Claudio; François; Infographiste; Programmeur 1; Programmeur 2; baseline start none → 2000-06-23 08:00; baseline finish none → 2000-06-23 08:15 |
| 209 | Reporting CAPS 40 | 2008-05-26 09:00 → 2000-06-26 09:00 (-2891d) | 2008-05-26 09:15 → 2000-06-26 09:15 (-2891d) |  |  | 49.49d → 56.62d | constraint start no earlier than 2008-05-26 08:00 → start no earlier than 2000-06-26 08:00; resources none → Claudio; François; Infographiste; Programmeur 1; Programmeur 2; baseline start none → 2000-06-26 08:00; baseline finish none → 2000-06-26 08:15 |
| 210 | Reporting CAPS 41 | 2008-05-27 09:00 → 2000-06-27 09:00 (-2891d) | 2008-05-27 09:15 → 2000-06-27 09:15 (-2891d) |  |  | 48.62d → 55.75d | constraint start no earlier than 2008-05-27 08:00 → start no earlier than 2000-06-27 08:00; resources none → Claudio; François; Infographiste; Programmeur 1; Programmeur 2; baseline start none → 2000-06-27 08:00; baseline finish none → 2000-06-27 08:15 |

| ID | Task | Start | Finish | Duration | Total float | Other |
| --- | --- | --- | --- | --- | --- | --- |
| 211 | Reporting CAPS 42 | 2008-05-28 09:00 → 2000-06-28 09:00 (-2891d) | 2008-05-28 09:15 → 2000-06-28 09:15 (-2891d) |  | 47.74d → 54.87d | constraint start no earlier than 2008-05-28 08:00 → start no earlier than 2000-06-28 08:00; resources none → Claudio; François; Infographiste; Programmeur 1; Programmeur 2; baseline start none → 2000-06-28 08:00; baseline finish none → 2000-06-28 08:15 |
| 212 | Reporting CAPS 43 | 2008-05-29 09:00 → 2000-06-29 09:00 (-2891d) | 2008-05-29 09:15 → 2000-06-29 09:15 (-2891d) |  | 46.87d → 54d | constraint start no earlier than 2008-05-29 08:00 → start no earlier than 2000-06-29 08:00; resources none → Claudio; François; Infographiste; Programmeur 1; Programmeur 2; baseline start none → 2000-06-29 08:00; baseline finish none → 2000-06-29 08:15 |
| 213 | Reporting CAPS 44 | 2008-05-30 09:00 → 2000-06-30 09:00 (-2891d) | 2008-05-30 09:15 → 2000-06-30 09:15 (-2891d) |  | 45.99d → 53.12d | constraint start no earlier than 2008-05-30 08:00 → start no earlier than 2000-06-30 08:00; resources none → Claudio; François; Infographiste; Programmeur 1; Programmeur 2; baseline start none → 2000-06-30 08:00; baseline finish none → 2000-06-30 08:15 |
| 214 | Reporting CAPS 45 | 2008-06-02 09:00 → 2000-07-03 09:00 (-2891d) | 2008-06-02 09:15 → 2000-07-03 09:15 (-2891d) |  | 45.12d → 52.25d | constraint start no earlier than 2008-05-31 08:00 → start no earlier than 2000-07-03 08:00; resources none → Claudio; François; Infographiste; Programmeur 1; Programmeur 2; baseline start none → 2000-07-03 08:00; baseline finish none → 2000-07-03 08:15 |
| 215 | Reporting CAPS 46 | 2008-06-02 09:00 → 2000-07-04 09:00 (-2890d) | 2008-06-02 09:15 → 2000-07-04 09:15 (-2890d) |  | 45.12d → 51.37d | constraint start no earlier than 2008-06-01 08:00 → start no earlier than 2000-07-04 08:00; resources none → Claudio; François; Infographiste; Programmeur 1; Programmeur 2; baseline start none → 2000-07-04 08:00; baseline finish none → 2000-07-04 08:15 |
| 216 | Reporting CAPS 47 | 2008-06-02 09:00 → 2000-07-05 09:00 (-2889d) | 2008-06-02 09:15 → 2000-07-05 09:15 (-2889d) |  | 45.12d → 50.5d | constraint start no earlier than 2008-06-02 08:00 → start no earlier than 2000-07-05 08:00; resources none → Claudio; François; Infographiste; Programmeur 1; Programmeur 2; baseline start none → 2000-07-05 08:00; baseline finish none → 2000-07-05 08:15 |
| 217 | Reporting CAPS 48 | 2008-06-03 09:00 → 2000-07-06 09:00 (-2889d) | 2008-06-03 09:15 → 2000-07-06 09:15 (-2889d) |  | 44.24d → 49.62d | constraint start no earlier than 2008-06-03 08:00 → start no earlier than 2000-07-06 08:00; resources none → Claudio; François; Infographiste; Programmeur 1; Programmeur 2; baseline start none → 2000-07-06 08:00; baseline finish none → 2000-07-06 08:15 |
| 218 | Reporting CAPS 49 | 2008-06-04 09:00 → 2000-07-07 09:00 (-2889d) | 2008-06-04 09:15 → 2000-07-07 09:15 (-2889d) |  | 43.37d → 48.75d | constraint start no earlier than 2008-06-04 08:00 → start no earlier than 2000-07-07 08:00; resources none → Claudio; François; Infographiste; Programmeur 1; Programmeur 2; baseline start none → 2000-07-07 08:00; baseline finish none → 2000-07-07 08:15 |
| 219 | Reporting CAPS 50 | 2008-06-05 09:00 → 2000-07-10 09:00 (-2887d) | 2008-06-05 09:15 → 2000-07-10 09:15 (-2887d) |  | 42.49d → 47.87d | constraint start no earlier than 2008-06-05 08:00 → start no earlier than 2000-07-10 08:00; resources none → Claudio; François; Infographiste; Programmeur 1; Programmeur 2; baseline start none → 2000-07-10 08:00; baseline finish none → 2000-07-10 08:15 |
| 220 | Reporting CAPS 51 | 2008-06-06 09:00 → 2000-07-11 09:00 (-2887d) | 2008-06-06 09:15 → 2000-07-11 09:15 (-2887d) |  | 41.62d → 47d | constraint start no earlier than 2008-06-06 08:00 → start no earlier than 2000-07-11 08:00; resources none → Claudio; François; Infographiste; Programmeur 1; Programmeur 2; baseline start none → 2000-07-11 08:00; baseline finish none → 2000-07-11 08:15 |
| 221 | Reporting CAPS 52 | 2008-06-09 09:00 → 2000-07-12 09:00 (-2889d) | 2008-06-09 09:15 → 2000-07-12 09:15 (-2889d) |  | 40.74d → 46.12d | constraint start no earlier than 2008-06-07 08:00 → start no earlier than 2000-07-12 08:00; resources none → Claudio; François; Infographiste; Programmeur 1; Programmeur 2; baseline start none → 2000-07-12 08:00; baseline finish none → 2000-07-12 08:15 |
| 222 | Reporting CAPS 53 | 2008-06-09 09:00 → 2000-07-13 09:00 (-2888d) | 2008-06-09 09:15 → 2000-07-13 09:15 (-2888d) |  | 40.74d → 45.25d | constraint start no earlier than 2008-06-08 08:00 → start no earlier than 2000-07-13 08:00; resources none → Claudio; François; Infographiste; Programmeur 1; Programmeur 2; baseline start none → 2000-07-13 08:00; baseline finish none → 2000-07-13 08:15 |
| 223 | Reporting CAPS 54 | 2008-06-09 09:00 → 2000-07-14 09:00 (-2887d) | 2008-06-09 09:15 → 2000-07-14 09:15 (-2887d) |  | 40.74d → 44.37d | constraint start no earlier than 2008-06-09 08:00 → start no earlier than 2000-07-14 08:00; resources none → Claudio; François; Infographiste; Programmeur 1; Programmeur 2; baseline start none → 2000-07-14 08:00; baseline finish none → 2000-07-14 08:15 |
| 224 | Reporting CAPS 55 | 2008-06-10 09:00 → 2000-07-17 09:00 (-2885d) | 2008-06-10 09:15 → 2000-07-17 09:15 (-2885d) |  | 39.87d → 43.5d | constraint start no earlier than 2008-06-10 08:00 → start no earlier than 2000-07-17 08:00; resources none → Claudio; François; Infographiste; Programmeur 1; Programmeur 2; baseline start none → 2000-07-17 08:00; baseline finish none → 2000-07-17 08:15 |
| 225 | Reporting CAPS 56 | 2008-06-11 09:00 → 2000-07-18 09:00 (-2885d) | 2008-06-11 09:15 → 2000-07-18 09:15 (-2885d) |  | 38.99d → 42.62d | constraint start no earlier than 2008-06-11 08:00 → start no earlier than 2000-07-18 08:00; resources none → Claudio; François; Infographiste; Programmeur 1; Programmeur 2; baseline start none → 2000-07-18 08:00; baseline finish none → 2000-07-18 08:15 |
| 226 | Reporting CAPS 57 | 2008-06-12 09:00 → 2000-07-19 09:00 (-2885d) | 2008-06-12 09:15 → 2000-07-19 09:15 (-2885d) |  | 38.12d → 41.75d | constraint start no earlier than 2008-06-12 08:00 → start no earlier than 2000-07-19 08:00; resources none → Claudio; François; Infographiste; Programmeur 1; Programmeur 2; baseline start none → 2000-07-19 08:00; baseline finish none → 2000-07-19 08:15 |
| 241 | **Fiche de reporting** | 2008-04-21 08:00 → 2000-04-20 08:00 (-2923d) | 2008-07-28 08:00 → 2000-07-20 08:00 (-2930d) | 61.25d → 53.38d | 10.15d → 40.9d | baseline start none → 2000-04-20 08:00; baseline finish none → 2000-07-20 08:00 |
| 242 | Fiche de reporting 1 | 2008-04-21 08:00 → 2000-04-20 08:00 (-2923d) | 2008-04-21 08:00 → 2000-04-20 08:00 (-2923d) |  | 71.4d → 94.28d | constraint start no earlier than 2008-04-21 08:00 → start no earlier than 2000-04-20 08:00; baseline start none → 2000-04-20 08:00; baseline finish none → 2000-04-20 08:00 |
| 243 | Fiche de reporting 2 | 2008-04-28 08:00 → 2000-04-27 08:00 (-2923d) | 2008-04-28 08:00 → 2000-04-27 08:00 (-2923d) |  | 67.03d → 89.9d | constraint start no earlier than 2008-04-28 08:00 → start no earlier than 2000-04-27 08:00; baseline start none → 2000-04-27 08:00; baseline finish none → 2000-04-27 08:00 |
| 244 | Fiche de reporting 3 | 2008-05-05 08:00 → 2000-05-04 08:00 (-2923d) | 2008-05-05 08:00 → 2000-05-04 08:00 (-2923d) |  | 62.65d → 86.4d | constraint start no earlier than 2008-05-05 08:00 → start no earlier than 2000-05-04 08:00; baseline start none → 2000-05-04 08:00; baseline finish none → 2000-05-04 08:00 |
| 245 | Fiche de reporting 4 | 2008-05-12 08:00 → 2000-05-11 08:00 (-2923d) | 2008-05-12 08:00 → 2000-05-11 08:00 (-2923d) |  | 58.28d → 82.9d | constraint start no earlier than 2008-05-12 08:00 → start no earlier than 2000-05-11 08:00; baseline start none → 2000-05-11 08:00; baseline finish none → 2000-05-11 08:00 |
| 246 | Fiche de reporting 5 | 2008-05-19 08:00 → 2000-05-18 08:00 (-2923d) | 2008-05-19 08:00 → 2000-05-18 08:00 (-2923d) |  | 53.9d → 78.53d | constraint start no earlier than 2008-05-19 08:00 → start no earlier than 2000-05-18 08:00; baseline start none → 2000-05-18 08:00; baseline finish none → 2000-05-18 08:00 |
| 247 | Fiche de reporting 6 | 2008-05-26 08:00 → 2000-05-25 08:00 (-2923d) | 2008-05-26 08:00 → 2000-05-25 08:00 (-2923d) |  | 49.53d → 74.15d | constraint start no earlier than 2008-05-26 08:00 → start no earlier than 2000-05-25 08:00; baseline start none → 2000-05-25 08:00; baseline finish none → 2000-05-25 08:00 |
| 248 | Fiche de reporting 7 | 2008-06-02 08:00 → 2000-06-01 08:00 (-2923d) | 2008-06-02 08:00 → 2000-06-01 08:00 (-2923d) |  | 45.15d → 69.78d | constraint start no earlier than 2008-06-02 08:00 → start no earlier than 2000-06-01 08:00; baseline start none → 2000-06-01 08:00; baseline finish none → 2000-06-01 08:00 |
| 249 | Fiche de reporting 8 | 2008-06-09 08:00 → 2000-06-08 08:00 (-2923d) | 2008-06-09 08:00 → 2000-06-08 08:00 (-2923d) |  | 40.78d → 66.28d | constraint start no earlier than 2008-06-09 08:00 → start no earlier than 2000-06-08 08:00; baseline start none → 2000-06-08 08:00; baseline finish none → 2000-06-08 08:00 |
| 250 | Fiche de reporting 9 | 2008-06-16 08:00 → 2000-06-15 08:00 (-2923d) | 2008-06-16 08:00 → 2000-06-15 08:00 (-2923d) |  | 36.4d → 62.78d | constraint start no earlier than 2008-06-16 08:00 → start no earlier than 2000-06-15 08:00; baseline start none → 2000-06-15 08:00; baseline finish none → 2000-06-15 08:00 |
| 251 | Fiche de reporting 10 | 2008-06-23 08:00 → 2000-06-22 08:00 (-2923d) | 2008-06-23 08:00 → 2000-06-22 08:00 (-2923d) |  | 32.03d → 58.4d | constraint start no earlier than 2008-06-23 08:00 → start no earlier than 2000-06-22 08:00; baseline start none → 2000-06-22 08:00; baseline finish none → 2000-06-22 08:00 |
| 252 | Fiche de reporting 11 | 2008-06-30 08:00 → 2000-06-29 08:00 (-2923d) | 2008-06-30 08:00 → 2000-06-29 08:00 (-2923d) |  | 27.65d → 54.03d | constraint start no earlier than 2008-06-30 08:00 → start no earlier than 2000-06-29 08:00; baseline start none → 2000-06-29 08:00; baseline finish none → 2000-06-29 08:00 |
| 253 | Fiche de reporting 12 | 2008-07-07 08:00 → 2000-07-06 08:00 (-2923d) | 2008-07-07 08:00 → 2000-07-06 08:00 (-2923d) |  | 23.28d → 49.65d | constraint start no earlier than 2008-07-07 08:00 → start no earlier than 2000-07-06 08:00; baseline start none → 2000-07-06 08:00; baseline finish none → 2000-07-06 08:00 |
| 254 | Fiche de reporting 13 | 2008-07-14 08:00 → 2000-07-13 08:00 (-2923d) | 2008-07-14 08:00 → 2000-07-13 08:00 (-2923d) |  | 18.9d → 45.28d | constraint start no earlier than 2008-07-14 08:00 → start no earlier than 2000-07-13 08:00; baseline start none → 2000-07-13 08:00; baseline finish none → 2000-07-13 08:00 |
| 255 | Fiche de reporting 14 | 2008-07-21 08:00 → 2000-07-20 08:00 (-2923d) | 2008-07-21 08:00 → 2000-07-20 08:00 (-2923d) |  | 14.53d → 40.9d | constraint start no earlier than 2008-07-21 08:00 → start no earlier than 2000-07-20 08:00; baseline start none → 2000-07-20 08:00; baseline finish none → 2000-07-20 08:00 |
| 256 | **Reporting commanditaire** | 2008-04-22 09:00 → 2000-04-21 09:00 (-2923d) | 2008-07-29 09:15 → 2000-07-21 09:15 (-2930d) | 61.28d → 53.41d | 9.24d → 40d | baseline start none → 2000-04-21 08:00; baseline finish none → 2000-07-21 08:15 |
| 257 | Reporting commanditaire 1 | 2008-04-22 09:00 → 2000-04-21 09:00 (-2923d) | 2008-04-22 09:15 → 2000-04-21 09:15 (-2923d) |  | 70.49d → 93.37d | constraint start no earlier than 2008-04-22 08:00 → start no earlier than 2000-04-21 08:00; resources none → Karen; Henri; baseline start none → 2000-04-21 08:00; baseline finish none → 2000-04-21 08:15 |
| 258 | Reporting commanditaire 2 | 2008-04-29 09:00 → 2000-04-28 09:00 (-2923d) | 2008-04-29 09:15 → 2000-04-28 09:15 (-2923d) |  | 66.12d → 89d | constraint start no earlier than 2008-04-29 08:00 → start no earlier than 2000-04-28 08:00; resources none → Karen; Henri; baseline start none → 2000-04-28 08:00; baseline finish none → 2000-04-28 08:15 |
| 259 | Reporting commanditaire 3 | 2008-05-06 09:00 → 2000-05-05 09:00 (-2923d) | 2008-05-06 09:15 → 2000-05-05 09:15 (-2923d) |  | 61.74d → 85.5d | constraint start no earlier than 2008-05-06 08:00 → start no earlier than 2000-05-05 08:00; resources none → Karen; Henri; baseline start none → 2000-05-05 08:00; baseline finish none → 2000-05-05 08:15 |
| 260 | Reporting commanditaire 4 | 2008-05-13 09:00 → 2000-05-12 09:00 (-2923d) | 2008-05-13 09:15 → 2000-05-12 09:15 (-2923d) |  | 57.37d → 82d | constraint start no earlier than 2008-05-13 08:00 → start no earlier than 2000-05-12 08:00; resources none → Karen; Henri; baseline start none → 2000-05-12 08:00; baseline finish none → 2000-05-12 08:15 |
| 261 | Reporting commanditaire 5 | 2008-05-20 09:00 → 2000-05-19 09:00 (-2923d) | 2008-05-20 09:15 → 2000-05-19 09:15 (-2923d) |  | 52.99d → 77.62d | constraint start no earlier than 2008-05-20 08:00 → start no earlier than 2000-05-19 08:00; resources none → Karen; Henri; baseline start none → 2000-05-19 08:00; baseline finish none → 2000-05-19 08:15 |
| 262 | Reporting commanditaire 6 | 2008-05-27 09:00 → 2000-05-26 09:00 (-2923d) | 2008-05-27 09:15 → 2000-05-26 09:15 (-2923d) |  | 48.62d → 73.25d | constraint start no earlier than 2008-05-27 08:00 → start no earlier than 2000-05-26 08:00; resources none → Karen; Henri; baseline start none → 2000-05-26 08:00; baseline finish none → 2000-05-26 08:15 |
| 263 | Reporting commanditaire 7 | 2008-06-03 09:00 → 2000-06-02 09:00 (-2923d) | 2008-06-03 09:15 → 2000-06-02 09:15 (-2923d) |  | 44.24d → 69.75d | constraint start no earlier than 2008-06-03 08:00 → start no earlier than 2000-06-02 08:00; resources none → Karen; Henri; baseline start none → 2000-06-02 08:00; baseline finish none → 2000-06-02 08:15 |
| 264 | Reporting commanditaire 8 | 2008-06-10 09:00 → 2000-06-09 09:00 (-2923d) | 2008-06-10 09:15 → 2000-06-09 09:15 (-2923d) |  | 39.87d → 65.37d | constraint start no earlier than 2008-06-10 08:00 → start no earlier than 2000-06-09 08:00; resources none → Karen; Henri; baseline start none → 2000-06-09 08:00; baseline finish none → 2000-06-09 08:15 |
| 265 | Reporting commanditaire 9 | 2008-06-17 09:00 → 2000-06-16 09:00 (-2923d) | 2008-06-17 09:15 → 2000-06-16 09:15 (-2923d) |  | 35.49d → 61.87d | constraint start no earlier than 2008-06-17 08:00 → start no earlier than 2000-06-16 08:00; resources none → Karen; Henri; baseline start none → 2000-06-16 08:00; baseline finish none → 2000-06-16 08:15 |
| 266 | Reporting commanditaire 10 | 2008-06-24 09:00 → 2000-06-23 09:00 (-2923d) | 2008-06-24 09:15 → 2000-06-23 09:15 (-2923d) |  | 31.12d → 57.5d | constraint start no earlier than 2008-06-24 08:00 → start no earlier than 2000-06-23 08:00; resources none → Karen; Henri; baseline start none → 2000-06-23 08:00; baseline finish none → 2000-06-23 08:15 |
| 267 | Reporting commanditaire 11 | 2008-07-01 09:00 → 2000-06-30 09:00 (-2923d) | 2008-07-01 09:15 → 2000-06-30 09:15 (-2923d) |  | 26.74d → 53.12d | constraint start no earlier than 2008-07-01 08:00 → start no earlier than 2000-06-30 08:00; resources none → Karen; Henri; baseline start none → 2000-06-30 08:00; baseline finish none → 2000-06-30 08:15 |
| 268 | Reporting commanditaire 12 | 2008-07-08 09:00 → 2000-07-07 09:00 (-2923d) | 2008-07-08 09:15 → 2000-07-07 09:15 (-2923d) |  | 22.37d → 48.75d | constraint start no earlier than 2008-07-08 08:00 → start no earlier than 2000-07-07 08:00; resources none → Karen; Henri; baseline start none → 2000-07-07 08:00; baseline finish none → 2000-07-07 08:15 |
| 269 | Reporting commanditaire 13 | 2008-07-15 09:00 → 2000-07-14 09:00 (-2923d) | 2008-07-15 09:15 → 2000-07-14 09:15 (-2923d) |  | 17.99d → 44.37d | constraint start no earlier than 2008-07-15 08:00 → start no earlier than 2000-07-14 08:00; resources none → Karen; Henri; baseline start none → 2000-07-14 08:00; baseline finish none → 2000-07-14 08:15 |
| 270 | Reporting commanditaire 14 | 2008-07-22 09:00 → 2000-07-21 09:00 (-2923d) | 2008-07-22 09:15 → 2000-07-21 09:15 (-2923d) |  | 13.62d → 40d | constraint start no earlier than 2008-07-22 08:00 → start no earlier than 2000-07-21 08:00; resources none → Karen; Henri; baseline start none → 2000-07-21 08:00; baseline finish none → 2000-07-21 08:15 |
| 271 | **Réunion comité de pilotage** | 2008-04-17 09:00 → 2000-05-02 09:00 (-2907d) | 2008-07-18 10:00 → 2000-07-04 10:00 (-2936d) | 57.88d → 36.88d | 15.28d → 51.28d | baseline start none → 2000-05-02 08:00; baseline finish none → 2000-07-03 17:00 |
| 272 | Réunion comité de pilotage 1 | 2008-04-17 09:00 → 2000-05-02 09:00 (-2907d) | 2008-04-18 10:00 → 2000-05-03 10:00 (-2907d) |  | 72.15d → 87.15d | constraint start no earlier than 2008-04-17 08:00 → start no earlier than 2000-05-01 08:00; resources none → Karen; Henri; Philippe; baseline start none → 2000-05-02 08:00; baseline finish none → 2000-05-02 17:00 |
| 273 | Réunion comité de pilotage 2 | 2008-05-19 09:00 → 2000-06-05 09:00 (-2905d) | 2008-05-20 10:00 → 2000-06-06 10:00 (-2905d) |  | 52.9d → 67.9d | constraint start no earlier than 2008-05-17 08:00 → start no earlier than 2000-06-05 08:00; resources none → Karen; Henri; Philippe; baseline start none → 2000-06-05 08:00; baseline finish none → 2000-06-05 17:00 |
| 274 | Réunion comité de pilotage 3 | 2008-06-17 09:00 → 2000-07-03 09:00 (-2906d) | 2008-06-18 10:00 → 2000-07-04 10:00 (-2906d) |  | 34.53d → 51.28d | constraint start no earlier than 2008-06-17 08:00 → start no earlier than 2000-07-03 08:00; resources none → Karen; Henri; Philippe; baseline start none → 2000-07-03 08:00; baseline finish none → 2000-07-03 17:00 |
| 279 | **Mettre à jour le planning** | 2008-04-21 09:00 → 2000-04-17 09:00 (-2926d) | 2008-07-28 10:00 → 2000-07-24 10:00 (-2926d) | 61.38d → 57.88d | 10.03d → 39.03d | baseline start none → 2000-04-17 08:00; baseline finish none → 2000-07-24 09:00 |
| 280 | Mettre à jour le planning 1 | 2008-04-21 09:00 → 2000-04-17 09:00 (-2926d) | 2008-04-21 10:00 → 2000-04-17 10:00 (-2926d) |  | 71.28d → 96.78d | constraint start no earlier than 2008-04-21 08:00 → start no earlier than 2000-04-17 08:00; resources none → Karen; baseline start none → 2000-04-17 08:00; baseline finish none → 2000-04-17 09:00 |
| 281 | Mettre à jour le planning 2 | 2008-04-28 09:00 → 2000-04-24 09:00 (-2926d) | 2008-04-28 10:00 → 2000-04-24 10:00 (-2926d) |  | 66.9d → 92.4d | constraint start no earlier than 2008-04-28 08:00 → start no earlier than 2000-04-24 08:00; resources none → Karen; baseline start none → 2000-04-24 08:00; baseline finish none → 2000-04-24 09:00 |
| 282 | Mettre à jour le planning 3 | 2008-05-05 09:00 → 2000-05-02 09:00 (-2925d) | 2008-05-05 10:00 → 2000-05-02 10:00 (-2925d) |  | 62.53d → 88.03d | constraint start no earlier than 2008-05-05 08:00 → start no earlier than 2000-05-01 08:00; resources none → Karen; baseline start none → 2000-05-02 08:00; baseline finish none → 2000-05-02 09:00 |
| 283 | Mettre à jour le planning 4 | 2008-05-12 09:00 → 2000-05-09 09:00 (-2925d) | 2008-05-12 10:00 → 2000-05-09 10:00 (-2925d) |  | 58.15d → 84.53d | constraint start no earlier than 2008-05-12 08:00 → start no earlier than 2000-05-08 08:00; resources none → Karen; baseline start none → 2000-05-09 08:00; baseline finish none → 2000-05-09 09:00 |
| 284 | Mettre à jour le planning 5 | 2008-05-19 09:00 → 2000-05-15 09:00 (-2926d) | 2008-05-19 10:00 → 2000-05-15 10:00 (-2926d) |  | 53.78d → 81.03d | constraint start no earlier than 2008-05-19 08:00 → start no earlier than 2000-05-15 08:00; resources none → Karen; baseline start none → 2000-05-15 08:00; baseline finish none → 2000-05-15 09:00 |
| 285 | Mettre à jour le planning 6 | 2008-05-26 09:00 → 2000-05-22 09:00 (-2926d) | 2008-05-26 10:00 → 2000-05-22 10:00 (-2926d) |  | 49.4d → 76.65d | constraint start no earlier than 2008-05-26 08:00 → start no earlier than 2000-05-22 08:00; resources none → Karen; baseline start none → 2000-05-22 08:00; baseline finish none → 2000-05-22 09:00 |
| 286 | Mettre à jour le planning 7 | 2008-06-02 09:00 → 2000-05-29 09:00 (-2926d) | 2008-06-02 10:00 → 2000-05-29 10:00 (-2926d) |  | 45.03d → 72.28d | constraint start no earlier than 2008-06-02 08:00 → start no earlier than 2000-05-29 08:00; resources none → Karen; baseline start none → 2000-05-29 08:00; baseline finish none → 2000-05-29 09:00 |
| 287 | Mettre à jour le planning 8 | 2008-06-09 09:00 → 2000-06-05 09:00 (-2926d) | 2008-06-09 10:00 → 2000-06-05 10:00 (-2926d) |  | 40.65d → 68.78d | constraint start no earlier than 2008-06-09 08:00 → start no earlier than 2000-06-05 08:00; resources none → Karen; baseline start none → 2000-06-05 08:00; baseline finish none → 2000-06-05 09:00 |
| 288 | Mettre à jour le planning 9 | 2008-06-16 09:00 → 2000-06-13 09:00 (-2925d) | 2008-06-16 10:00 → 2000-06-13 10:00 (-2925d) |  | 36.28d → 64.4d | constraint start no earlier than 2008-06-16 08:00 → start no earlier than 2000-06-12 08:00; resources none → Karen; baseline start none → 2000-06-13 08:00; baseline finish none → 2000-06-13 09:00 |
| 289 | Mettre à jour le planning 10 | 2008-06-23 09:00 → 2000-06-19 09:00 (-2926d) | 2008-06-23 10:00 → 2000-06-19 10:00 (-2926d) |  | 31.9d → 60.9d | constraint start no earlier than 2008-06-23 08:00 → start no earlier than 2000-06-19 08:00; resources none → Karen; baseline start none → 2000-06-19 08:00; baseline finish none → 2000-06-19 09:00 |
| 290 | Mettre à jour le planning 11 | 2008-06-30 09:00 → 2000-06-26 09:00 (-2926d) | 2008-06-30 10:00 → 2000-06-26 10:00 (-2926d) |  | 27.53d → 56.53d | constraint start no earlier than 2008-06-30 08:00 → start no earlier than 2000-06-26 08:00; resources none → Karen; baseline start none → 2000-06-26 08:00; baseline finish none → 2000-06-26 09:00 |
| 291 | Mettre à jour le planning 12 | 2008-07-07 09:00 → 2000-07-03 09:00 (-2926d) | 2008-07-07 10:00 → 2000-07-03 10:00 (-2926d) |  | 23.15d → 52.15d | constraint start no earlier than 2008-07-07 08:00 → start no earlier than 2000-07-03 08:00; resources none → Karen; baseline start none → 2000-07-03 08:00; baseline finish none → 2000-07-03 09:00 |
| 292 | Mettre à jour le planning 13 | 2008-07-14 09:00 → 2000-07-10 09:00 (-2926d) | 2008-07-14 10:00 → 2000-07-10 10:00 (-2926d) |  | 18.78d → 47.78d | constraint start no earlier than 2008-07-14 08:00 → start no earlier than 2000-07-10 08:00; resources none → Karen; baseline start none → 2000-07-10 08:00; baseline finish none → 2000-07-10 09:00 |
| 293 | Mettre à jour le planning 14 | 2008-07-21 09:00 → 2000-07-17 09:00 (-2926d) | 2008-07-21 10:00 → 2000-07-17 10:00 (-2926d) |  | 14.4d → 43.4d | constraint start no earlier than 2008-07-21 08:00 → start no earlier than 2000-07-17 08:00; resources none → Karen; baseline start none → 2000-07-17 08:00; baseline finish none → 2000-07-17 09:00 |
| 294 | Mettre à jour le planning 15 | 2008-07-28 09:00 → 2000-07-24 09:00 (-2926d) | 2008-07-28 10:00 → 2000-07-24 10:00 (-2926d) |  | 10.03d → 39.03d | constraint start no earlier than 2008-07-28 08:00 → start no earlier than 2000-07-24 08:00; resources none → Karen; baseline start none → 2000-07-24 08:00; baseline finish none → 2000-07-24 09:00 |
| 295 | **Planning détaillé de suivi** | 2008-04-21 08:00 → 2000-04-17 08:00 (-2926d) | 2008-07-28 08:00 → 2000-07-24 08:00 (-2926d) | 61.25d → 57.75d | 10.15d → 39.15d | baseline start none → 2000-04-17 08:00; baseline finish none → 2000-07-24 08:00 |
| 296 | Planning détaillé de suivi 1 | 2008-04-21 08:00 → 2000-04-17 08:00 (-2926d) | 2008-04-21 08:00 → 2000-04-17 08:00 (-2926d) |  | 71.4d → 96.9d | constraint start no earlier than 2008-04-21 08:00 → start no earlier than 2000-04-17 08:00; baseline start none → 2000-04-17 08:00; baseline finish none → 2000-04-17 08:00 |
| 297 | Planning détaillé de suivi 2 | 2008-04-28 08:00 → 2000-04-24 08:00 (-2926d) | 2008-04-28 08:00 → 2000-04-24 08:00 (-2926d) |  | 67.03d → 92.53d | constraint start no earlier than 2008-04-28 08:00 → start no earlier than 2000-04-24 08:00; baseline start none → 2000-04-24 08:00; baseline finish none → 2000-04-24 08:00 |
| 298 | Planning détaillé de suivi 3 | 2008-05-05 08:00 → 2000-05-01 08:00 (-2926d) | 2008-05-05 08:00 → 2000-05-01 08:00 (-2926d) |  | 62.65d → 88.15d | constraint start no earlier than 2008-05-05 08:00 → start no earlier than 2000-05-01 08:00; baseline start none → 2000-05-01 08:00; baseline finish none → 2000-05-01 08:00 |

| ID | Task | Start | Finish | Duration | Total float | Other |
| --- | --- | --- | --- | --- | --- | --- |
| 299 | Planning détaillé de suivi 4 | 2008-05-12 08:00 → 2000-05-08 08:00 (-2926d) | 2008-05-12 08:00 → 2000-05-08 08:00 (-2926d) |  | 58.28d → 84.65d | constraint start no earlier than 2008-05-12 08:00 → start no earlier than 2000-05-08 08:00; baseline start none → 2000-05-08 08:00; baseline finish none → 2000-05-08 08:00 |
| 300 | Planning détaillé de suivi 5 | 2008-05-19 08:00 → 2000-05-15 08:00 (-2926d) | 2008-05-19 08:00 → 2000-05-15 08:00 (-2926d) |  | 53.9d → 81.15d | constraint start no earlier than 2008-05-19 08:00 → start no earlier than 2000-05-15 08:00; baseline start none → 2000-05-15 08:00; baseline finish none → 2000-05-15 08:00 |
| 301 | Planning détaillé de suivi 6 | 2008-05-26 08:00 → 2000-05-22 08:00 (-2926d) | 2008-05-26 08:00 → 2000-05-22 08:00 (-2926d) |  | 49.53d → 76.78d | constraint start no earlier than 2008-05-26 08:00 → start no earlier than 2000-05-22 08:00; baseline start none → 2000-05-22 08:00; baseline finish none → 2000-05-22 08:00 |
| 302 | Planning détaillé de suivi 7 | 2008-06-02 08:00 → 2000-05-29 08:00 (-2926d) | 2008-06-02 08:00 → 2000-05-29 08:00 (-2926d) |  | 45.15d → 72.4d | constraint start no earlier than 2008-06-02 08:00 → start no earlier than 2000-05-29 08:00; baseline start none → 2000-05-29 08:00; baseline finish none → 2000-05-29 08:00 |
| 303 | Planning détaillé de suivi 8 | 2008-06-09 08:00 → 2000-06-05 08:00 (-2926d) | 2008-06-09 08:00 → 2000-06-05 08:00 (-2926d) |  | 40.78d → 68.9d | constraint start no earlier than 2008-06-09 08:00 → start no earlier than 2000-06-05 08:00; baseline start none → 2000-06-05 08:00; baseline finish none → 2000-06-05 08:00 |
| 304 | Planning détaillé de suivi 9 | 2008-06-16 08:00 → 2000-06-12 08:00 (-2926d) | 2008-06-16 08:00 → 2000-06-12 08:00 (-2926d) |  | 36.4d → 64.53d | constraint start no earlier than 2008-06-16 08:00 → start no earlier than 2000-06-12 08:00; baseline start none → 2000-06-12 08:00; baseline finish none → 2000-06-12 08:00 |
| 305 | Planning détaillé de suivi 10 | 2008-06-23 08:00 → 2000-06-19 08:00 (-2926d) | 2008-06-23 08:00 → 2000-06-19 08:00 (-2926d) |  | 32.03d → 61.03d | constraint start no earlier than 2008-06-23 08:00 → start no earlier than 2000-06-19 08:00; baseline start none → 2000-06-19 08:00; baseline finish none → 2000-06-19 08:00 |
| 306 | Planning détaillé de suivi 11 | 2008-06-30 08:00 → 2000-06-26 08:00 (-2926d) | 2008-06-30 08:00 → 2000-06-26 08:00 (-2926d) |  | 27.65d → 56.65d | constraint start no earlier than 2008-06-30 08:00 → start no earlier than 2000-06-26 08:00; baseline start none → 2000-06-26 08:00; baseline finish none → 2000-06-26 08:00 |
| 307 | Planning détaillé de suivi 12 | 2008-07-07 08:00 → 2000-07-03 08:00 (-2926d) | 2008-07-07 08:00 → 2000-07-03 08:00 (-2926d) |  | 23.28d → 52.28d | constraint start no earlier than 2008-07-07 08:00 → start no earlier than 2000-07-03 08:00; baseline start none → 2000-07-03 08:00; baseline finish none → 2000-07-03 08:00 |
| 308 | Planning détaillé de suivi 13 | 2008-07-14 08:00 → 2000-07-10 08:00 (-2926d) | 2008-07-14 08:00 → 2000-07-10 08:00 (-2926d) |  | 18.9d → 47.9d | constraint start no earlier than 2008-07-14 08:00 → start no earlier than 2000-07-10 08:00; baseline start none → 2000-07-10 08:00; baseline finish none → 2000-07-10 08:00 |
| 309 | Planning détaillé de suivi 14 | 2008-07-21 08:00 → 2000-07-17 08:00 (-2926d) | 2008-07-21 08:00 → 2000-07-17 08:00 (-2926d) |  | 14.53d → 43.53d | constraint start no earlier than 2008-07-21 08:00 → start no earlier than 2000-07-17 08:00; baseline start none → 2000-07-17 08:00; baseline finish none → 2000-07-17 08:00 |
| 310 | Planning détaillé de suivi 15 | 2008-07-28 08:00 → 2000-07-24 08:00 (-2926d) | 2008-07-28 08:00 → 2000-07-24 08:00 (-2926d) |  | 10.15d → 39.15d | constraint start no earlier than 2008-07-28 08:00 → start no earlier than 2000-07-24 08:00; baseline start none → 2000-07-24 08:00; baseline finish none → 2000-07-24 08:00 |
| 311 | **Mettre à jour la documentation** | 2008-04-21 09:00 → 2000-04-18 09:00 (-2925d) | 2008-07-28 10:00 → 2000-07-25 10:00 (-2925d) | 61.38d → 57.88d | 10.03d → 38.15d | baseline start none → 2000-04-18 08:00; baseline finish none → 2000-07-25 09:00 |
| 312 | Mettre à jour la documentation 1 | 2008-04-21 09:00 → 2000-04-18 09:00 (-2925d) | 2008-04-21 10:00 → 2000-04-18 10:00 (-2925d) |  | 71.28d → 95.9d | constraint start no earlier than 2008-04-21 08:00 → start no earlier than 2000-04-18 08:00; resources none → Christophe; baseline start none → 2000-04-18 08:00; baseline finish none → 2000-04-18 09:00 |
| 313 | Mettre à jour la documentation 2 | 2008-04-28 09:00 → 2000-04-25 09:00 (-2925d) | 2008-04-28 10:00 → 2000-04-25 10:00 (-2925d) |  | 66.9d → 91.53d | constraint start no earlier than 2008-04-28 08:00 → start no earlier than 2000-04-25 08:00; resources none → Christophe; baseline start none → 2000-04-25 08:00; baseline finish none → 2000-04-25 09:00 |
| 314 | Mettre à jour la documentation 3 | 2008-05-05 09:00 → 2000-05-02 09:00 (-2925d) | 2008-05-05 10:00 → 2000-05-02 10:00 (-2925d) |  | 62.53d → 88.03d | constraint start no earlier than 2008-05-05 08:00 → start no earlier than 2000-05-02 08:00; resources none → Christophe; baseline start none → 2000-05-02 08:00; baseline finish none → 2000-05-02 09:00 |
| 315 | Mettre à jour la documentation 4 | 2008-05-12 09:00 → 2000-05-09 09:00 (-2925d) | 2008-05-12 10:00 → 2000-05-09 10:00 (-2925d) |  | 58.15d → 84.53d | constraint start no earlier than 2008-05-12 08:00 → start no earlier than 2000-05-09 08:00; resources none → Christophe; baseline start none → 2000-05-09 08:00; baseline finish none → 2000-05-09 09:00 |
| 316 | Mettre à jour la documentation 5 | 2008-05-19 09:00 → 2000-05-16 09:00 (-2925d) | 2008-05-19 10:00 → 2000-05-16 10:00 (-2925d) |  | 53.78d → 80.15d | constraint start no earlier than 2008-05-19 08:00 → start no earlier than 2000-05-16 08:00; resources none → Christophe; baseline start none → 2000-05-16 08:00; baseline finish none → 2000-05-16 09:00 |
| 317 | Mettre à jour la documentation 6 | 2008-05-26 09:00 → 2000-05-23 09:00 (-2925d) | 2008-05-26 10:00 → 2000-05-23 10:00 (-2925d) |  | 49.4d → 75.78d | constraint start no earlier than 2008-05-26 08:00 → start no earlier than 2000-05-23 08:00; resources none → Christophe; baseline start none → 2000-05-23 08:00; baseline finish none → 2000-05-23 09:00 |
| 318 | Mettre à jour la documentation 7 | 2008-06-02 09:00 → 2000-05-30 09:00 (-2925d) | 2008-06-02 10:00 → 2000-05-30 10:00 (-2925d) |  | 45.03d → 71.4d | constraint start no earlier than 2008-06-02 08:00 → start no earlier than 2000-05-30 08:00; resources none → Christophe; baseline start none → 2000-05-30 08:00; baseline finish none → 2000-05-30 09:00 |
| 319 | Mettre à jour la documentation 8 | 2008-06-09 09:00 → 2000-06-06 09:00 (-2925d) | 2008-06-09 10:00 → 2000-06-06 10:00 (-2925d) |  | 40.65d → 67.9d | constraint start no earlier than 2008-06-09 08:00 → start no earlier than 2000-06-06 08:00; resources none → Christophe; baseline start none → 2000-06-06 08:00; baseline finish none → 2000-06-06 09:00 |
| 320 | Mettre à jour la documentation 9 | 2008-06-16 09:00 → 2000-06-13 09:00 (-2925d) | 2008-06-16 10:00 → 2000-06-13 10:00 (-2925d) |  | 36.28d → 64.4d | constraint start no earlier than 2008-06-16 08:00 → start no earlier than 2000-06-13 08:00; resources none → Christophe; baseline start none → 2000-06-13 08:00; baseline finish none → 2000-06-13 09:00 |
| 321 | Mettre à jour la documentation 10 | 2008-06-23 09:00 → 2000-06-20 09:00 (-2925d) | 2008-06-23 10:00 → 2000-06-20 10:00 (-2925d) |  | 31.9d → 60.03d | constraint start no earlier than 2008-06-23 08:00 → start no earlier than 2000-06-20 08:00; resources none → Christophe; baseline start none → 2000-06-20 08:00; baseline finish none → 2000-06-20 09:00 |
| 322 | Mettre à jour la documentation 11 | 2008-06-30 09:00 → 2000-06-27 09:00 (-2925d) | 2008-06-30 10:00 → 2000-06-27 10:00 (-2925d) |  | 27.53d → 55.65d | constraint start no earlier than 2008-06-30 08:00 → start no earlier than 2000-06-27 08:00; resources none → Christophe; baseline start none → 2000-06-27 08:00; baseline finish none → 2000-06-27 09:00 |
| 323 | Mettre à jour la documentation 12 | 2008-07-07 09:00 → 2000-07-04 09:00 (-2925d) | 2008-07-07 10:00 → 2000-07-04 10:00 (-2925d) |  | 23.15d → 51.28d | constraint start no earlier than 2008-07-07 08:00 → start no earlier than 2000-07-04 08:00; resources none → Christophe; baseline start none → 2000-07-04 08:00; baseline finish none → 2000-07-04 09:00 |
| 324 | Mettre à jour la documentation 13 | 2008-07-14 09:00 → 2000-07-11 09:00 (-2925d) | 2008-07-14 10:00 → 2000-07-11 10:00 (-2925d) |  | 18.78d → 46.9d | constraint start no earlier than 2008-07-14 08:00 → start no earlier than 2000-07-11 08:00; resources none → Christophe; baseline start none → 2000-07-11 08:00; baseline finish none → 2000-07-11 09:00 |
| 325 | Mettre à jour la documentation 14 | 2008-07-21 09:00 → 2000-07-18 09:00 (-2925d) | 2008-07-21 10:00 → 2000-07-18 10:00 (-2925d) |  | 14.4d → 42.53d | constraint start no earlier than 2008-07-21 08:00 → start no earlier than 2000-07-18 08:00; resources none → Christophe; baseline start none → 2000-07-18 08:00; baseline finish none → 2000-07-18 09:00 |
| 326 | Mettre à jour la documentation 15 | 2008-07-28 09:00 → 2000-07-25 09:00 (-2925d) | 2008-07-28 10:00 → 2000-07-25 10:00 (-2925d) |  | 10.03d → 38.15d | constraint start no earlier than 2008-07-28 08:00 → start no earlier than 2000-07-25 08:00; resources none → Christophe; baseline start none → 2000-07-25 08:00; baseline finish none → 2000-07-25 09:00 |
| 327 | Faire un bilan intermédiaire | 2008-05-15 09:00 → 2000-05-15 09:00 (-2922d) | 2008-05-16 10:00 → 2000-05-16 10:00 (-2922d) |  | 54.65d → 80.15d | constraint start no earlier than 2008-05-15 09:00 → start no earlier than 2000-05-15 08:00; baseline start none → 2000-05-15 08:00; baseline finish none → 2000-05-15 17:00 |
| 328 | Bilan intermédiaire | 2008-05-16 10:00 → 2000-05-16 10:00 (-2922d) | 2008-05-16 10:00 → 2000-05-16 10:00 (-2922d) |  | 54.65d → 80.15d | baseline start none → 2000-05-15 17:00; baseline finish none → 2000-05-15 17:00 |
| 329 | Préparer la communication presse | 2008-05-26 09:00 → 2000-05-25 09:00 (-2923d) | 2008-06-02 16:00 → 2000-06-02 16:00 (-2922d) |  | 44.53d → 69.15d | constraint start no earlier than 2008-05-26 08:00 → start no earlier than 2000-05-25 08:00; baseline start none → 2000-05-25 08:00; baseline finish none → 2000-05-31 17:00 |
| 330 | Envoyer communication presse |  |  |  | 1855.4d → 55.65d | baseline start none → 2000-06-26 08:00; baseline finish none → 2000-06-26 17:00 |
| 331 | Communication presse | 2008-08-06 09:12 → 2000-09-18 10:12 (-2879d) | 2008-08-06 09:12 → 2000-09-18 10:12 (-2879d) |  |  | baseline start none → 2000-08-30 09:12; baseline finish none → 2000-08-30 09:12 |
| 332 | Rédiger la communication clients | 2008-06-26 09:00 → 2000-06-26 09:00 (-2922d) | 2008-06-27 10:00 → 2000-06-27 10:00 (-2922d) |  | 28.4d → 55.65d | constraint start no earlier than 2008-06-26 09:00 → start no earlier than 2000-06-26 08:00; baseline start none → 2000-06-26 08:00; baseline finish none → 2000-06-26 17:00 |
| 333 | Envoyer la communication clients | 2008-08-06 09:12 → 2000-09-18 10:12 (-2879d) | 2008-08-07 10:12 → 2000-09-19 11:12 (-2879d) |  |  | baseline start none → 2000-08-30 09:12; baseline finish none → 2000-08-31 09:12 |
| 334 | Communication clients | 2008-08-07 10:12 → 2000-09-19 11:12 (-2879d) | 2008-08-07 10:12 → 2000-09-19 11:12 (-2879d) |  |  | baseline start none → 2000-08-31 09:12; baseline finish none → 2000-08-31 09:12 |
| 335 | **Faire le bilan du projet** | 2008-08-06 09:12 → 2000-09-18 10:12 (-2879d) | 2008-08-12 15:12 → 2000-09-22 16:12 (-2881d) |  |  | baseline start none → 2000-08-30 09:12; baseline finish none → 2000-09-05 09:12 |
| 336 | **Promotion** | 2008-08-06 09:12 → 2000-09-18 10:12 (-2879d) | 2008-08-07 10:12 → 2000-09-19 11:12 (-2879d) |  |  | baseline start none → 2000-08-30 09:12; baseline finish none → 2000-08-31 09:12 |
| 337 | Vendre le projet | 2008-08-06 09:12 → 2000-09-18 10:12 (-2879d) | 2008-08-07 10:12 → 2000-09-19 11:12 (-2879d) |  |  | baseline start none → 2000-08-30 09:12; baseline finish none → 2000-08-31 09:12 |
| 338 | Présentation de projet | 2008-08-07 10:12 → 2000-09-19 11:12 (-2879d) | 2008-08-07 10:12 → 2000-09-19 11:12 (-2879d) |  |  | baseline start none → 2000-08-31 09:12; baseline finish none → 2000-08-31 09:12 |
| 339 | **Désengagement** | 2008-08-07 10:12 → 2000-09-19 11:12 (-2879d) | 2008-08-08 11:12 → 2000-09-20 14:12 (-2879d) |  |  | baseline start none → 2000-08-31 09:12; baseline finish none → 2000-09-01 09:12 |
| 340 | Mettre un terme à l'engagement contractuel | 2008-08-07 10:12 → 2000-09-19 11:12 (-2879d) | 2008-08-08 11:12 → 2000-09-20 14:12 (-2879d) |  |  | baseline start none → 2000-08-31 09:12; baseline finish none → 2000-09-01 09:12 |
| 341 | Note de désengagement | 2008-08-08 11:12 → 2000-09-20 14:12 (-2879d) | 2008-08-08 11:12 → 2000-09-20 14:12 (-2879d) |  |  | baseline start none → 2000-09-01 09:12; baseline finish none → 2000-09-01 09:12 |
| 342 | **Capitalisation** | 2008-08-08 11:12 → 2000-09-20 14:12 (-2879d) | 2008-08-12 15:12 → 2000-09-22 16:12 (-2881d) |  |  | baseline start none → 2000-09-01 09:12; baseline finish none → 2000-09-05 09:12 |
| 343 | Organiser les réunions de débriefing | 2008-08-08 11:12 → 2000-09-20 14:12 (-2879d) | 2008-08-11 14:12 → 2000-09-21 15:12 (-2881d) |  |  | baseline start none → 2000-09-01 09:12; baseline finish none → 2000-09-04 09:12 |
| 344 | Bilan final de projet | 2008-08-11 14:12 → 2000-09-21 15:12 (-2881d) | 2008-08-11 14:12 → 2000-09-21 15:12 (-2881d) |  |  | baseline start none → 2000-09-04 09:12; baseline finish none → 2000-09-04 09:12 |
| 345 | Archiver les dossiers du projet | 2008-08-11 14:12 → 2000-09-21 15:12 (-2881d) | 2008-08-12 15:12 → 2000-09-22 16:12 (-2881d) |  |  | baseline start none → 2000-09-04 09:12; baseline finish none → 2000-09-05 09:12 |
| 346 | Note d’archivage | 2008-08-12 15:12 → 2000-09-22 16:12 (-2881d) | 2008-08-12 15:12 → 2000-09-22 16:12 (-2881d) |  |  | baseline start none → 2000-09-05 09:12; baseline finish none → 2000-09-05 09:12 |
| 347 | Fin du projet | 2008-08-12 15:12 → 2000-09-22 16:12 (-2881d) | 2008-08-12 15:12 → 2000-09-22 16:12 (-2881d) |  |  | baseline start none → 2000-09-05 09:12; baseline finish none → 2000-09-05 09:12 |

## Version 6 (saved 2008-06-18, file 20-Planning détaillé pour fiche 23-Polo.mpp)

Last finish 2000-09-22 → 2008-05-12 (+2789d). Complete tasks 109 → 0.

Added:

| ID | Task | Duration | Start | Finish |
| --- | --- | --- | --- | --- |
| 169 | Faire les réunions de comité de pilotage | 1d | 2008-04-17 | 2008-04-18 |
| 170 | Rapport flash | 0d | 2008-04-17 | 2008-04-17 |
| 171 | Faire les réunion avec l'équipe projet | 1d | 2008-04-17 | 2008-04-18 |
| 172 | Vérifier le reporting | 1d | 2008-04-17 | 2008-04-18 |
| 173 | Fiche de reporting (suite) | 0d | 2008-04-17 | 2008-04-17 |
| 174 | Mettre à jour la planning | 1d | 2008-04-17 | 2008-04-18 |
| 175 | Planning détaillé (suite) | 0d | 2008-04-17 | 2008-04-17 |
| 176 | Mettre à jour la documentation | 1d | 2008-04-17 | 2008-04-18 |
| 177 | œuvre en œuvre la communication | 1d | 2008-04-17 | 2008-04-18 |

Removed: 169 Reporting CAPS; 170 Reporting CAPS 1; 171 Reporting CAPS 2; 172 Reporting CAPS 3; 173 Reporting CAPS 4; 174 Reporting CAPS 5; 175 Reporting CAPS 6; 176 Reporting CAPS 7; 177 Reporting CAPS 8; 178 Reporting CAPS 9; 179 Reporting CAPS 10; 180 Reporting CAPS 11; 181 Reporting CAPS 12; 182 Reporting CAPS 13; 183 Reporting CAPS 14; 184 Reporting CAPS 15; 185 Reporting CAPS 16; 186 Reporting CAPS 17; 187 Reporting CAPS 18; 188 Reporting CAPS 19; 189 Reporting CAPS 20; 190 Reporting CAPS 21; 191 Reporting CAPS 22; 192 Reporting CAPS 23; 193 Reporting CAPS 24; 194 Reporting CAPS 25; 195 Reporting CAPS 26; 196 Reporting CAPS 27; 197 Reporting CAPS 28; 198 Reporting CAPS 29; 199 Reporting CAPS 30; 200 Reporting CAPS 31; 201 Reporting CAPS 32; 202 Reporting CAPS 33; 203 Reporting CAPS 34; 204 Reporting CAPS 35; 205 Reporting CAPS 36; 206 Reporting CAPS 37; 207 Reporting CAPS 38; 208 Reporting CAPS 39; 209 Reporting CAPS 40; 210 Reporting CAPS 41; 211 Reporting CAPS 42; 212 Reporting CAPS 43; 213 Reporting CAPS 44; 214 Reporting CAPS 45; 215 Reporting CAPS 46; 216 Reporting CAPS 47; 217 Reporting CAPS 48; 218 Reporting CAPS 49; 219 Reporting CAPS 50; 220 Reporting CAPS 51; 221 Reporting CAPS 52; 222 Reporting CAPS 53; 223 Reporting CAPS 54; 224 Reporting CAPS 55; 225 Reporting CAPS 56; 226 Reporting CAPS 57; 227 Reporting EFII; 228 Reporting EFII 1; 229 Reporting EFII 2; 230 Reporting EFII 3; 231 Reporting EFII 4; 232 Reporting EFII 5; 233 Reporting EFII 6; 234 Reporting EFII 7; 235 Reporting EFII 8; 236 Reporting EFII 9; 237 Reporting EFII 10; 238 Reporting EFII 11; 239 Reporting EFII 12; 240 Reporting EFII 13; 241 Fiche de reporting; 242 Fiche de reporting 1; 243 Fiche de reporting 2; 244 Fiche de reporting 3; 245 Fiche de reporting 4; 246 Fiche de reporting 5; 247 Fiche de reporting 6; 248 Fiche de reporting 7; 249 Fiche de reporting 8; 250 Fiche de reporting 9; 251 Fiche de reporting 10; 252 Fiche de reporting 11; 253 Fiche de reporting 12; 254 Fiche de reporting 13; 255 Fiche de reporting 14; 256 Reporting commanditaire; 257 Reporting commanditaire 1; 258 Reporting commanditaire 2; 259 Reporting commanditaire 3; 260 Reporting commanditaire 4; 261 Reporting commanditaire 5; 262 Reporting commanditaire 6; 263 Reporting commanditaire 7; 264 Reporting commanditaire 8; 265 Reporting commanditaire 9; 266 Reporting commanditaire 10; 267 Reporting commanditaire 11; 268 Reporting commanditaire 12; 269 Reporting commanditaire 13; 270 Reporting commanditaire 14; 271 Réunion comité de pilotage; 272 Réunion comité de pilotage 1; 273 Réunion comité de pilotage 2; 274 Réunion comité de pilotage 3; 275 Rapport flash; 276 Rapport flash 1; 277 Rapport flash 2; 278 Rapport flash 3; 279 Mettre à jour le planning; 280 Mettre à jour le planning 1; 281 Mettre à jour le planning 2; 282 Mettre à jour le planning 3; 283 Mettre à jour le planning 4; 284 Mettre à jour le planning 5; 285 Mettre à jour le planning 6; 286 Mettre à jour le planning 7; 287 Mettre à jour le planning 8; 288 Mettre à jour le planning 9; 289 Mettre à jour le planning 10; 290 Mettre à jour le planning 11; 291 Mettre à jour le planning 12; 292 Mettre à jour le planning 13; 293 Mettre à jour le planning 14; 294 Mettre à jour le planning 15; 295 Planning détaillé de suivi; 296 Planning détaillé de suivi 1; 297 Planning détaillé de suivi 2; 298 Planning détaillé de suivi 3; 299 Planning détaillé de suivi 4; 300 Planning détaillé de suivi 5; 301 Planning détaillé de suivi 6; 302 Planning détaillé de suivi 7; 303 Planning détaillé de suivi 8; 304 Planning détaillé de suivi 9; 305 Planning détaillé de suivi 10; 306 Planning détaillé de suivi 11; 307 Planning détaillé de suivi 12; 308 Planning détaillé de suivi 13; 309 Planning détaillé de suivi 14; 310 Planning détaillé de suivi 15; 311 Mettre à jour la documentation; 312 Mettre à jour la documentation 1; 313 Mettre à jour la documentation 2; 314 Mettre à jour la documentation 3; 315 Mettre à jour la documentation 4; 316 Mettre à jour la documentation 5; 317 Mettre à jour la documentation 6; 318 Mettre à jour la documentation 7; 319 Mettre à jour la documentation 8; 320 Mettre à jour la documentation 9; 321 Mettre à jour la documentation 10; 322 Mettre à jour la documentation 11; 323 Mettre à jour la documentation 12; 324 Mettre à jour la documentation 13; 325 Mettre à jour la documentation 14; 326 Mettre à jour la documentation 15; 329 Préparer la communication presse; 330 Envoyer communication presse; 331 Communication presse; 332 Rédiger la communication clients; 333 Envoyer la communication clients; 334 Communication clients

Changed:

| ID | Task | Start | Finish | Duration | Complete | Total float | Predecessors | Other |
| --- | --- | --- | --- | --- | --- | --- | --- | --- |
| 1 | Début du projet | 2000-04-17 08:00 A → 2008-04-17 (+2922d) | 2000-04-17 08:00 A → 2008-04-17 (+2922d) |  | 100% → 0% | none → 15d |  | baseline start 2000-04-17 08:00 → none; baseline finish 2000-04-17 08:00 → none |
| 2 | **GESTION DU PROJET** | 2000-04-17 08:00 A → 2008-04-17 (+2922d) | 2000-04-26 16:12 A → 2008-04-18 (+2914d) | 6.78d → 1d | 100% → 0% | none → 14d |  | baseline start 2000-04-17 08:00 → none; baseline finish 2000-04-26 16:12 → none |
| 3 | **Initialiser le projet** | 2000-04-17 08:00 A → 2008-04-17 (+2922d) | 2000-04-18 15:00 A → 2008-04-17 (+2921d) | 1.38d → 0.25d | 100% → 0% | none → 14.75d |  | baseline start 2000-04-17 08:00 → none; baseline finish 2000-04-18 15:00 → none |
| 4 | **Réception** | 2000-04-17 08:00 A → 2008-04-17 (+2922d) | 2000-04-17 12:00 A → 2008-04-17 (+2922d) | 0.38d → 0.25d | 100% → 0% | none → 14.75d |  | baseline start 2000-04-17 08:00 → none; baseline finish 2000-04-17 12:00 → none |
| 5 | Réceptionner la demande de projet du commanditaire | 2000-04-17 08:00 A → 2008-04-17 (+2922d) | 2000-04-17 10:00 A → 2008-04-17 (+2922d) | 0.12d → 0.25d | 100% → 0% | none → 14.75d |  | resources Henri [200%] → none; baseline start 2000-04-17 08:00 → none; baseline finish 2000-04-17 10:00 → none |
| 6 | Demande de projet du commanditaire | 2000-04-17 10:00 A → 2008-04-17 (+2922d) | 2000-04-17 10:00 A → 2008-04-17 (+2922d) |  | 100% → 0% | none → 15d | 5 → none | baseline start 2000-04-17 10:00 → none; baseline finish 2000-04-17 10:00 → none |
| 7 | Examiner la demande du commanditaire | 2000-04-17 10:00 A → 2008-04-17 (+2922d) | 2000-04-17 12:00 A → 2008-04-17 (+2922d) |  | 100% → 0% | none → 14.75d | 6 → none | resources Karen → none; baseline start 2000-04-17 10:00 → none; baseline finish 2000-04-17 12:00 → none |
| 8 | Réponse à la demande de projet | 2000-04-17 12:00 A → 2008-04-17 (+2922d) | 2000-04-17 12:00 A → 2008-04-17 (+2922d) |  | 100% → 0% | none → 15d | 7 → none | baseline start 2000-04-17 12:00 → none; baseline finish 2000-04-17 12:00 → none |
| 9 | **Affectation** | 2000-04-17 13:00 A → 2008-04-17 (+2922d) | 2000-04-18 15:00 A → 2008-04-17 (+2921d) | 1d → 0.25d | 100% → 0% | none → 14.75d |  | baseline start 2000-04-17 13:00 → none; baseline finish 2000-04-18 15:00 → none |
| 10 | Officialiser la nomination du chef de projet | 2000-04-17 13:00 A → 2008-04-17 (+2922d) | 2000-04-17 15:00 A → 2008-04-17 (+2922d) | 0.12d → 0.25d | 100% → 0% | none → 14.75d | 7 → none | resources Karen; Henri [200%] → none; baseline start 2000-04-17 13:00 → none; baseline finish 2000-04-17 15:00 → none |
| 11 | Note d’affectation du chef de projet | 2000-04-18 15:00 A → 2008-04-17 (+2921d) | 2000-04-18 15:00 A → 2008-04-17 (+2921d) |  | 100% → 0% | none → 15d | 10FS+1d → none | baseline start 2000-04-18 15:00 → none; baseline finish 2000-04-18 15:00 → none |
| 12 | **Préparer le projet** | 2000-04-18 15:00 A → 2008-04-17 (+2921d) | 2000-04-24 15:00 A → 2008-04-18 (+2916d) | 3.5d → 1d | 100% → 0% | none → 14d |  | baseline start 2000-04-18 15:00 → none; baseline finish 2000-04-24 15:00 → none |
| 13 | **Objet** | 2000-04-18 15:00 A → 2008-04-17 (+2921d) | 2000-04-18 17:00 A → 2008-04-17 (+2921d) |  | 100% → 0% | none → 14.75d |  | baseline start 2000-04-18 15:00 → none; baseline finish 2000-04-18 17:00 → none |
| 14 | Définir l’objet précis du projet | 2000-04-18 15:00 A → 2008-04-17 (+2921d) | 2000-04-18 17:00 A → 2008-04-17 (+2921d) |  | 100% → 0% | none → 14.75d | 11 → none | resources Karen [50%] → none; baseline start 2000-04-18 15:00 → none; baseline finish 2000-04-18 17:00 → none |
| 15 | Note de cadrage | 2000-04-18 17:00 A → 2008-04-17 (+2921d) | 2000-04-18 17:00 A → 2008-04-17 (+2921d) |  | 100% → 0% | none → 15d | 14 → none | baseline start 2000-04-18 17:00 → none; baseline finish 2000-04-18 17:00 → none |
| 16 | Lister les motifs et définir le contexte | 2000-04-18 15:00 A → 2008-04-17 (+2921d) | 2000-04-18 17:00 A → 2008-04-17 (+2921d) |  | 100% → 0% | none → 14.75d | 11 → none | resources Karen [50%] → none; baseline start 2000-04-18 15:00 → none; baseline finish 2000-04-18 17:00 → none |
| 17 | Note de cadrage (suite) | 2000-04-18 17:00 A → 2008-04-17 (+2921d) | 2000-04-18 17:00 A → 2008-04-17 (+2921d) |  | 100% → 0% | none → 15d | 16 → none | baseline start 2000-04-18 17:00 → none; baseline finish 2000-04-18 17:00 → none |
| 18 | **Objectifs** | 2000-04-20 08:00 A → 2008-04-17 (+2919d) | 2000-04-20 15:00 A → 2008-04-17 (+2919d) | 0.5d → 0.25d | 100% → 0% | none → 14.75d |  | baseline start 2000-04-20 08:00 → none; baseline finish 2000-04-20 15:00 → none |
| 19 | Définir les objectifs de qualité | 2000-04-20 08:00 A → 2008-04-17 (+2919d) | 2000-04-20 12:00 A → 2008-04-17 (+2919d) | 0.38d → 0.25d | 100% → 0% | none → 14.75d | 17FS+1d → none | resources Karen; Henri → none; baseline start 2000-04-20 08:00 → none; baseline finish 2000-04-20 12:00 → none |
| 20 | Note de cadrage (suite) | 2000-04-20 12:00 A → 2008-04-17 (+2919d) | 2000-04-20 12:00 A → 2008-04-17 (+2919d) |  | 100% → 0% | none → 15d | 19 → none | baseline start 2000-04-20 12:00 → none; baseline finish 2000-04-20 12:00 → none |
| 21 | Définir les objectifs de temps | 2000-04-20 08:00 A → 2008-04-17 (+2919d) | 2000-04-20 10:00 A → 2008-04-17 (+2919d) | 0.12d → 0.25d | 100% → 0% | none → 14.75d | 17FS+1d → none | resources Karen → none; baseline start 2000-04-20 08:00 → none; baseline finish 2000-04-20 10:00 → none |
| 22 | Macro-planning | 2000-04-20 10:00 A → 2008-04-17 (+2919d) | 2000-04-20 10:00 A → 2008-04-17 (+2919d) |  | 100% → 0% | none → 15d | 21 → none | was named macro-planning; baseline start 2000-04-20 10:00 → none; baseline finish 2000-04-20 10:00 → none |
| 23 | Définir les objectifs de charge et de coûts | 2000-04-20 08:00 A → 2008-04-17 (+2919d) | 2000-04-20 10:00 A → 2008-04-17 (+2919d) | 0.12d → 0.25d | 100% → 0% | none → 14.75d | 17FS+1d → none | resources Karen → none; baseline start 2000-04-20 08:00 → none; baseline finish 2000-04-20 10:00 → none |
| 24 | Macro-planning de charge | 2000-04-20 10:00 A → 2008-04-17 (+2919d) | 2000-04-20 10:00 A → 2008-04-17 (+2919d) |  | 100% → 0% | none → 15d | 23 → none | was named macro-planning de charge; baseline start 2000-04-20 10:00 → none; baseline finish 2000-04-20 10:00 → none |
| 25 | Budget prévisionnel | 2000-04-20 10:00 A → 2008-04-17 (+2919d) | 2000-04-20 10:00 A → 2008-04-17 (+2919d) |  | 100% → 0% | none → 15d | 23 → none | baseline start 2000-04-20 10:00 → none; baseline finish 2000-04-20 10:00 → none |
| 26 | Définir les objectifs de communication | 2000-04-20 10:00 A → 2008-04-17 (+2919d) | 2000-04-20 12:00 A → 2008-04-17 (+2919d) |  | 100% → 0% | none → 14.75d | 23 → none | resources Christophe → none; baseline start 2000-04-20 10:00 → none; baseline finish 2000-04-20 12:00 → none |
| 27 | Stratégie de communication | 2000-04-20 12:00 A → 2008-04-17 (+2919d) | 2000-04-20 12:00 A → 2008-04-17 (+2919d) |  | 100% → 0% | none → 15d | 26 → none | baseline start 2000-04-20 12:00 → none; baseline finish 2000-04-20 12:00 → none |
| 28 | Définir les objectifs complémentaires | 2000-04-20 08:00 A → 2008-04-17 (+2919d) | 2000-04-20 10:00 A → 2008-04-17 (+2919d) | 0.12d → 0.25d | 100% → 0% | none → 14.75d | 17FS+1d → none | resources Karen [25%]; Henri [25%] → none; baseline start 2000-04-20 08:00 → none; baseline finish 2000-04-20 10:00 → none |
| 29 | Note de cadrage (suite) | 2000-04-20 10:00 A → 2008-04-17 (+2919d) | 2000-04-20 10:00 A → 2008-04-17 (+2919d) |  | 100% → 0% | none → 15d | 28 → none | baseline start 2000-04-20 10:00 → none; baseline finish 2000-04-20 10:00 → none |
| 30 | Préciser les contraintes sur objectifs | 2000-04-20 10:00 A → 2008-04-17 (+2919d) | 2000-04-20 12:00 A → 2008-04-17 (+2919d) |  | 100% → 0% | none → 14.75d | 29 → none | resources Karen [12.5%]; Henri [12.5%] → none; baseline start 2000-04-20 10:00 → none; baseline finish 2000-04-20 12:00 → none |
| 31 | Note de cadrage (suite) | 2000-04-20 12:00 A → 2008-04-17 (+2919d) | 2000-04-20 12:00 A → 2008-04-17 (+2919d) |  | 100% → 0% | none → 15d | 30 → none | baseline start 2000-04-20 12:00 → none; baseline finish 2000-04-20 12:00 → none |
| 32 | Vérifier l’adéquation entre les objectifs | 2000-04-20 13:00 A → 2008-04-17 (+2919d) | 2000-04-20 15:00 A → 2008-04-17 (+2919d) | 0.12d → 0.25d | 100% → 0% | none → 14.75d | 31 → none | resources Karen → none; baseline start 2000-04-20 13:00 → none; baseline finish 2000-04-20 15:00 → none |
| 33 | Note de cadrage (suite) | 2000-04-20 15:00 A → 2008-04-17 (+2919d) | 2000-04-20 15:00 A → 2008-04-17 (+2919d) |  | 100% → 0% | none → 15d | 32 → none | baseline start 2000-04-20 15:00 → none; baseline finish 2000-04-20 15:00 → none |
| 34 | **Domaine** | 2000-04-20 15:00 A → 2008-04-17 (+2919d) | 2000-04-21 17:00 A → 2008-04-18 (+2919d) | 1.12d → 1d | 100% → 0% | none → 14d |  | baseline start 2000-04-20 15:00 → none; baseline finish 2000-04-21 17:00 → none |
| 35 | Identifier le périmètre et les acteurs | 2000-04-20 15:00 A → 2008-04-17 (+2919d) | 2000-04-21 15:00 A → 2008-04-18 (+2919d) | 0.88d → 1d | 100% → 0% | none → 14d | 33 → none | resources Karen [57.1%] → none; baseline start 2000-04-20 15:00 → none; baseline finish 2000-04-21 15:00 → none |
| 36 | Fichier des acteurs | 2000-04-21 15:00 A → 2008-04-17 (+2918d) | 2000-04-21 15:00 A → 2008-04-17 (+2918d) |  | 100% → 0% | none → 15d | 35 → none | baseline start 2000-04-21 15:00 → none; baseline finish 2000-04-21 15:00 → none |
| 37 | Définir la structure choisie pour la gestion du projet | 2000-04-21 13:00 A → 2008-04-17 (+2918d) | 2000-04-21 15:00 A → 2008-04-17 (+2918d) | 0.12d → 0.25d | 100% → 0% | none → 14.75d | 33, 35FF → none | resources Karen [50%] → none; baseline start 2000-04-21 13:00 → none; baseline finish 2000-04-21 15:00 → none |
| 38 | Organigramme Projet | 2000-04-21 15:00 A → 2008-04-17 (+2918d) | 2000-04-21 15:00 A → 2008-04-17 (+2918d) |  | 100% → 0% | none → 15d | 37 → none | baseline start 2000-04-21 15:00 → none; baseline finish 2000-04-21 15:00 → none |
| 39 | Définir les rôles des acteurs dans les structures projets | 2000-04-21 15:00 A → 2008-04-17 (+2918d) | 2000-04-21 17:00 A → 2008-04-17 (+2918d) |  | 100% → 0% | none → 14.75d | 38 → none | resources Karen [25%] → none; baseline start 2000-04-21 15:00 → none; baseline finish 2000-04-21 17:00 → none |
| 40 | Fiche de poste | 2000-04-21 17:00 A → 2008-04-17 (+2918d) | 2000-04-21 17:00 A → 2008-04-17 (+2918d) |  | 100% → 0% | none → 15d | 39 → none | baseline start 2000-04-21 17:00 → none; baseline finish 2000-04-21 17:00 → none |
| 41 | Carte des acteurs | 2000-04-21 17:00 A → 2008-04-17 (+2918d) | 2000-04-21 17:00 A → 2008-04-17 (+2918d) |  | 100% → 0% | none → 15d | 39 → none | baseline start 2000-04-21 17:00 → none; baseline finish 2000-04-21 17:00 → none |
| 42 | **Risques** | 2000-04-24 08:00 A → 2008-04-17 (+2915d) | 2000-04-24 10:00 A → 2008-04-17 (+2915d) | 0.12d → 0.25d | 100% → 0% | none → 14.75d |  | baseline start 2000-04-24 08:00 → none; baseline finish 2000-04-24 10:00 → none |
| 43 | Identifier, analyser et gérer les freins | 2000-04-24 08:00 A → 2008-04-17 (+2915d) | 2000-04-24 10:00 A → 2008-04-17 (+2915d) | 0.12d → 0.25d | 100% → 0% | none → 14.75d | 41 → none | resources Karen; Henri → none; baseline start 2000-04-24 08:00 → none; baseline finish 2000-04-24 10:00 → none |
| 44 | Grille des freins | 2000-04-24 10:00 A → 2008-04-17 (+2915d) | 2000-04-24 10:00 A → 2008-04-17 (+2915d) |  | 100% → 0% | none → 15d | 43 → none | baseline start 2000-04-24 10:00 → none; baseline finish 2000-04-24 10:00 → none |
| 45 | Identifier, analyser et gérer les facilitants | 2000-04-24 08:00 A → 2008-04-17 (+2915d) | 2000-04-24 10:00 A → 2008-04-17 (+2915d) | 0.12d → 0.25d | 100% → 0% | none → 14.75d | 41 → none | resources Karen [50%]; Henri [50%] → none; baseline start 2000-04-24 08:00 → none; baseline finish 2000-04-24 10:00 → none |
| 46 | Grille des facilitants | 2000-04-24 10:00 A → 2008-04-17 (+2915d) | 2000-04-24 10:00 A → 2008-04-17 (+2915d) |  | 100% → 0% | none → 15d | 44 → none | baseline start 2000-04-24 10:00 → none; baseline finish 2000-04-24 10:00 → none |
| 47 | **Méthode** | 2000-04-24 08:00 A → 2008-04-17 (+2915d) | 2000-04-24 10:00 A → 2008-04-17 (+2915d) | 0.12d → 0.25d | 100% → 0% | none → 14.75d |  | baseline start 2000-04-24 08:00 → none; baseline finish 2000-04-24 10:00 → none |
| 48 | Choisir une méthode et structurer la réal. du produit | 2000-04-24 08:00 A → 2008-04-17 (+2915d) | 2000-04-24 10:00 A → 2008-04-17 (+2915d) | 0.12d → 0.25d | 100% → 0% | none → 14.75d | 41 → none | resources Claudio; François → none; baseline start 2000-04-24 08:00 → none; baseline finish 2000-04-24 10:00 → none |
| 49 | Fiche méthode | 2000-04-24 10:00 A → 2008-04-17 (+2915d) | 2000-04-24 10:00 A → 2008-04-17 (+2915d) |  | 100% → 0% | none → 15d | 48 → none | baseline start 2000-04-24 10:00 → none; baseline finish 2000-04-24 10:00 → none |
| 50 | **Communication** | 2000-04-24 10:00 A → 2008-04-17 (+2915d) | 2000-04-24 12:00 A → 2008-04-17 (+2915d) |  | 100% → 0% | none → 14.75d |  | baseline start 2000-04-24 10:00 → none; baseline finish 2000-04-24 12:00 → none |
| 51 | Définir les axes, cibles et moyens de communication | 2000-04-24 10:00 A → 2008-04-17 (+2915d) | 2000-04-24 12:00 A → 2008-04-17 (+2915d) |  | 100% → 0% | none → 14.75d | 46 → none | resources Christophe → none; baseline start 2000-04-24 10:00 → none; baseline finish 2000-04-24 12:00 → none |
| 52 | Charte graphique | 2000-04-24 12:00 A → 2008-04-17 (+2915d) | 2000-04-24 12:00 A → 2008-04-17 (+2915d) |  | 100% → 0% | none → 15d | 51 → none | baseline start 2000-04-24 12:00 → none; baseline finish 2000-04-24 12:00 → none |
| 53 | Plan de communication | 2000-04-24 12:00 A → 2008-04-17 (+2915d) | 2000-04-24 12:00 A → 2008-04-17 (+2915d) |  | 100% → 0% | none → 15d | 51 → none | baseline start 2000-04-24 12:00 → none; baseline finish 2000-04-24 12:00 → none |
| 54 | **Contractualisation** | 2000-04-24 13:00 A → 2008-04-17 (+2915d) | 2000-04-24 15:00 A → 2008-04-17 (+2915d) | 0.12d → 0.25d | 100% → 0% | none → 14.75d |  | baseline start 2000-04-24 13:00 → none; baseline finish 2000-04-24 15:00 → none |
| 55 | Rédiger la note de cadrage | 2000-04-24 13:00 A → 2008-04-17 (+2915d) | 2000-04-24 15:00 A → 2008-04-17 (+2915d) | 0.12d → 0.25d | 100% → 0% | none → 14.75d | 53 → none | resources Henri; Karen → none; baseline start 2000-04-24 13:00 → none; baseline finish 2000-04-24 15:00 → none |
| 56 | Note de cadrage (suite) | 2000-04-24 15:00 A → 2008-04-17 (+2915d) | 2000-04-24 15:00 A → 2008-04-17 (+2915d) |  | 100% → 0% | none → 15d | 55 → none | baseline start 2000-04-24 15:00 → none; baseline finish 2000-04-24 15:00 → none |
| 57 | **Planifier le projet** | 2000-04-24 15:00 A → 2008-04-17 (+2915d) | 2000-04-26 11:12 A → 2008-04-17 (+2913d) | 1.52d → 0.25d | 100% → 0% | none → 14.75d |  | baseline start 2000-04-24 15:00 → none; baseline finish 2000-04-26 11:12 → none |
| 58 | **Planification détallée** | 2000-04-24 15:00 A → 2008-04-17 (+2915d) | 2000-04-25 16:12 A → 2008-04-17 (+2914d) | 1.02d → 0.1d | 100% → 0% | none → 14.9d |  | baseline start 2000-04-24 15:00 → none; baseline finish 2000-04-25 16:12 → none |
| 59 | Définir l’environnement de planification | 2000-04-24 15:00 A → 2008-04-17 (+2915d) | 2000-04-24 15:48 A → 2008-04-17 (+2915d) |  | 100% → 0% | none → 14.9d | 56 → none | resources Karen [62.5%] → none; baseline start 2000-04-24 15:00 → none; baseline finish 2000-04-24 15:48 → none |
| 60 | Charte de planification | 2000-04-24 15:48 A → 2008-04-17 (+2915d) | 2000-04-24 15:48 A → 2008-04-17 (+2915d) |  | 100% → 0% | none → 15d | 59 → none | baseline start 2000-04-24 15:48 → none; baseline finish 2000-04-24 15:48 → none |
| 61 | Ordonner la liste des tâches de fabrication du produit | 2000-04-24 15:48 A → 2008-04-17 (+2915d) | 2000-04-25 08:48 A → 2008-04-17 (+2914d) | 0.28d → 0.1d | 100% → 0% | none → 14.9d | 60 → none | resources Karen [45.5%]; Claudio [45.5%]; François [45.5%] → none; baseline start 2000-04-24 15:48 → none; baseline finish 2000-04-25 08:48 → none |
| 62 | Organigramme des tâches | 2000-04-25 08:48 A → 2008-04-17 (+2914d) | 2000-04-25 08:48 A → 2008-04-17 (+2914d) |  | 100% → 0% | none → 15d | 61 → none | baseline start 2000-04-25 08:48 → none; baseline finish 2000-04-25 08:48 → none |
| 63 | Affecter des durées ou des charges aux tâches | 2000-04-25 08:48 A → 2008-04-17 (+2914d) | 2000-04-25 09:36 A → 2008-04-17 (+2914d) | 0.07d → 0.1d | 100% → 0% | none → 14.9d | 62 → none | resources Karen [83.3%] → none; baseline start 2000-04-25 08:48 → none; baseline finish 2000-04-25 09:36 → none |
| 64 | Planning détaillé | 2000-04-25 09:36 A → 2008-04-17 (+2914d) | 2000-04-25 09:36 A → 2008-04-17 (+2914d) |  | 100% → 0% | none → 15d | 63 → none | baseline start 2000-04-25 09:36 → none; baseline finish 2000-04-25 09:36 → none |
| 65 | Définir les liens entre les tâches | 2000-04-25 09:36 A → 2008-04-17 (+2914d) | 2000-04-25 10:24 A → 2008-04-17 (+2914d) |  | 100% → 0% | none → 14.9d | 64 → none | resources Karen [31.2%] → none; baseline start 2000-04-25 09:36 → none; baseline finish 2000-04-25 10:24 → none |
| 66 | Planning détaillé (suite) | 2000-04-25 10:24 A → 2008-04-17 (+2914d) | 2000-04-25 10:24 A → 2008-04-17 (+2914d) |  | 100% → 0% | none → 15d | 65 → none | baseline start 2000-04-25 10:24 → none; baseline finish 2000-04-25 10:24 → none |
| 67 | Intégrer les tâches de gestion de projet | 2000-04-25 10:24 A → 2008-04-17 (+2914d) | 2000-04-25 11:12 A → 2008-04-17 (+2914d) |  | 100% → 0% | none → 14.9d | 66 → none | resources Karen [12.5%] → none; baseline start 2000-04-25 10:24 → none; baseline finish 2000-04-25 11:12 → none |
| 68 | Planning détaillé (suite) | 2000-04-25 11:12 A → 2008-04-17 (+2914d) | 2000-04-25 11:12 A → 2008-04-17 (+2914d) |  | 100% → 0% | none → 15d | 67 → none | baseline start 2000-04-25 11:12 → none; baseline finish 2000-04-25 11:12 → none |
| 69 | Affecter les ressources sur les tâches | 2000-04-25 11:12 A → 2008-04-17 (+2914d) | 2000-04-25 16:12 A → 2008-04-17 (+2914d) | 0.38d → 0.1d | 100% → 0% | none → 14.9d | 68 → none | resources Karen [66.7%] → none; baseline start 2000-04-25 11:12 → none; baseline finish 2000-04-25 16:12 → none |
| 70 | Tableau des ressources | 2000-04-25 16:12 A → 2008-04-17 (+2914d) | 2000-04-25 16:12 A → 2008-04-17 (+2914d) |  | 100% → 0% | none → 15d | 69 → none | baseline start 2000-04-25 16:12 → none; baseline finish 2000-04-25 16:12 → none |

| ID | Task | Start | Finish | Duration | Complete | Total float | Predecessors | Other |
| --- | --- | --- | --- | --- | --- | --- | --- | --- |
| 71 | Planning détaillé (suite) | 2000-04-25 16:12 A → 2008-04-17 (+2914d) | 2000-04-25 16:12 A → 2008-04-17 (+2914d) |  | 100% → 0% | none → 15d | 70 → none | baseline start 2000-04-25 16:12 → none; baseline finish 2000-04-25 16:12 → none |
| 72 | **Validation** | 2000-04-25 16:12 A → 2008-04-17 (+2914d) | 2000-04-26 11:12 A → 2008-04-17 (+2913d) | 0.5d → 0.25d | 100% → 0% | none → 14.75d |  | baseline start 2000-04-25 16:12 → none; baseline finish 2000-04-26 11:12 → none |
| 73 | Optimiser le planning détaillé du prévu | 2000-04-25 16:12 A → 2008-04-17 (+2914d) | 2000-04-26 09:12 A → 2008-04-17 (+2913d) |  | 100% → 0% | none → 14.75d | 71 → none | resources Karen [50%]; Claudio [50%]; François [50%] → none; baseline start 2000-04-25 16:12 → none; baseline finish 2000-04-26 09:12 → none |
| 74 | Planning détaillé (suite) | 2000-04-26 09:12 A → 2008-04-17 (+2913d) | 2000-04-26 09:12 A → 2008-04-17 (+2913d) |  | 100% → 0% | none → 15d | 73 → none | baseline start 2000-04-26 09:12 → none; baseline finish 2000-04-26 09:12 → none |
| 75 | Valider, communiquer et enregistrer le planning | 2000-04-26 09:12 A → 2008-04-17 (+2913d) | 2000-04-26 11:12 A → 2008-04-17 (+2913d) |  | 100% → 0% | none → 14.75d | 74 → none | resources Karen [50%]; Christophe [50%] → none; baseline start 2000-04-26 09:12 → none; baseline finish 2000-04-26 11:12 → none |
| 76 | Contrat de planning | 2000-04-26 11:12 A → 2008-04-17 (+2913d) | 2000-04-26 11:12 A → 2008-04-17 (+2913d) |  | 100% → 0% | none → 15d | 75 → none | baseline start 2000-04-26 11:12 → none; baseline finish 2000-04-26 11:12 → none |
| 77 | **Piloter le projet** | 2000-04-26 11:12 A → 2008-04-17 (+2913d) | 2000-04-26 16:12 A → 2008-04-17 (+2913d) | 0.38d → 0.25d | 100% → 0% | none → 14.75d |  | baseline start 2000-04-26 11:12 → none; baseline finish 2000-04-26 16:12 → none |
| 78 | **Lancement** | 2000-04-26 11:12 A → 2008-04-17 (+2913d) | 2000-04-26 16:12 A → 2008-04-17 (+2913d) | 0.38d → 0.25d | 100% → 0% | none → 14.75d |  | baseline start 2000-04-26 11:12 → none; baseline finish 2000-04-26 16:12 → none |
| 79 | Lancer la réalisation | 2000-04-26 11:12 A → 2008-04-17 (+2913d) | 2000-04-26 14:12 A → 2008-04-17 (+2913d) | 0.12d → 0.25d | 100% → 0% | none → 14.75d | 76 → none | resources Karen [50%]; Christophe [50%] → none; baseline start 2000-04-26 11:12 → none; baseline finish 2000-04-26 14:12 → none |
| 80 | Journal du projet | 2000-04-26 14:12 A → 2008-04-17 (+2913d) | 2000-04-26 14:12 A → 2008-04-17 (+2913d) |  | 100% → 0% | none → 15d | 79 → none | baseline start 2000-04-26 14:12 → none; baseline finish 2000-04-26 14:12 → none |
| 81 | Fiche de reporting | 2000-04-26 14:12 A → 2008-04-17 (+2913d) | 2000-04-26 14:12 A → 2008-04-17 (+2913d) |  | 100% → 0% | none → 15d | 80 → none | baseline start 2000-04-26 14:12 → none; baseline finish 2000-04-26 14:12 → none |
| 82 | Mettre en œuvre le plan de communication | 2000-04-26 14:12 A → 2008-04-17 (+2913d) | 2000-04-26 16:12 A → 2008-04-17 (+2913d) |  | 100% → 0% | none → 14.75d | 81 → none | resources Christophe → none; baseline start 2000-04-26 14:12 → none; baseline finish 2000-04-26 16:12 → none |
| 83 | Plan de communication (suite) | 2000-04-26 16:12 A → 2008-04-17 (+2913d) | 2000-04-26 16:12 A → 2008-04-17 (+2913d) |  | 100% → 0% | none → 15d | 82 → none | baseline start 2000-04-26 16:12 → none; baseline finish 2000-04-26 16:12 → none |
| 84 | **FABRICATION DU PRODUIT** | 2000-04-26 16:12 A → 2008-04-17 (+2913d) | 2000-09-18 10:12 → 2008-05-12 (+2793d) | 86.13d → 15d | 45% → 0% | 4d → 0d |  | baseline start 2000-04-26 16:12 → none; baseline finish 2000-08-30 09:12 → none |
| 85 | **Etude de la gestion des stocks** | 2000-04-26 16:12 A → 2008-04-17 (+2913d) | 2000-05-18 16:12 A → 2008-04-21 (+2895d) | 12.25d → 2d | 100% → 0% | none → 13d |  | baseline start 2000-04-26 16:12 → none; baseline finish 2000-05-04 16:12 → none |
| 86 | **Etude opérationnelle** | 2000-04-26 16:12 A → 2008-04-17 (+2913d) | 2000-05-15 16:12 A → 2008-04-18 (+2895d) | 9.62d → 1d | 100% → 0% | none → 14d |  | baseline start 2000-04-26 16:12 → none; baseline finish 2000-04-28 16:12 → none |
| 87 | Analyse de l'existant | 2000-04-26 16:12 A → 2008-04-17 (+2913d) | 2000-05-12 16:12 A → 2008-04-18 (+2898d) | 8.75d → 1d | 100% → 0% | none → 14d | 83 → none | resources Patrick [57.1%] → none; baseline start 2000-04-26 16:12 → none; baseline finish 2000-04-27 16:12 → none |
| 88 | Feuille d'analyse | 2000-05-12 16:12 A → 2008-04-17 (+2897d) | 2000-05-12 16:12 A → 2008-04-17 (+2897d) |  | 100% → 0% | none → 15d | 87 → none | baseline start 2000-04-27 16:12 → none; baseline finish 2000-04-27 16:12 → none |
| 89 | Recherche des améliorations | 2000-05-12 16:12 A → 2008-04-17 (+2897d) | 2000-05-15 16:12 A → 2008-04-18 (+2895d) | 0.88d → 1d | 100% → 0% | none → 14d | 88 → none | resources Patrick [57.1%] → none; baseline start 2000-04-27 16:12 → none; baseline finish 2000-04-28 16:12 → none |
| 90 | Liste des améliorations | 2000-05-15 16:12 A → 2008-04-17 (+2894d) | 2000-05-15 16:12 A → 2008-04-17 (+2894d) |  | 100% → 0% | none → 15d | 89 → none | baseline start 2000-04-28 16:12 → none; baseline finish 2000-04-28 16:12 → none |
| 91 | **Etude fonctionnelle** | 2000-04-26 16:12 A → 2008-04-17 (+2913d) | 2000-05-18 16:12 A → 2008-04-21 (+2895d) | 12.25d → 2d | 100% → 0% | none → 13d |  | baseline start 2000-04-26 16:12 → none; baseline finish 2000-05-04 16:12 → none |
| 92 | Analyse de l'existant | 2000-04-26 16:12 A → 2008-04-17 (+2913d) | 2000-04-27 16:12 A → 2008-04-18 (+2913d) | 0.88d → 1d | 100% → 0% | none → 14d | 83 → none | resources Henri [57.1%] → none; baseline start 2000-04-26 16:12 → none; baseline finish 2000-04-27 16:12 → none |
| 93 | Organigramme fonctionnel | 2000-05-15 16:12 A → 2008-04-17 (+2894d) | 2000-05-15 16:12 A → 2008-04-17 (+2894d) |  | 100% → 0% | none → 15d | 92, 90 → none | baseline start 2000-04-28 16:12 → none; baseline finish 2000-04-28 16:12 → none |
| 94 | Rédaction du cahier des charges | 2000-05-15 16:12 A → 2008-04-17 (+2894d) | 2000-05-18 16:12 A → 2008-04-21 (+2895d) | 1.62d → 2d | 100% → 0% | none → 13d | 93 → none | resources Henri [61.5%] → none; baseline start 2000-04-28 16:12 → none; baseline finish 2000-05-04 16:12 → none |
| 95 | Cahier des charges | 2000-05-18 16:12 A → 2008-04-17 (+2891d) | 2000-05-18 16:12 A → 2008-04-17 (+2891d) |  | 100% → 0% | none → 15d | 94 → none | baseline start 2000-05-04 16:12 → none; baseline finish 2000-05-04 16:12 → none |
| 96 | **Mise en place de la gestion des stocks** | 2000-05-18 16:12 A → 2008-04-17 (+2891d) | 2000-07-26 17:54 → 2008-04-24 (+2829d) | 41.34d → 5d | 78% → 0% | 36.54d → 10d |  | baseline start 2000-05-04 16:12 → none; baseline finish 2000-07-19 15:09 → none |
| 97 | **Recherche progiciels** | 2000-05-18 16:12 A → 2008-04-17 (+2891d) | 2000-05-23 16:12 A → 2008-04-24 (+2893d) | 2.62d → 5d | 100% → 0% | none → 10d |  | baseline start 2000-05-04 16:12 → none; baseline finish 2000-05-15 16:12 → none |
| 98 | Recherche des prestataires | 2000-05-18 16:12 A → 2008-04-17 (+2891d) | 2000-05-22 16:12 A → 2008-04-24 (+2894d) | 1.75d → 5d | 100% → 0% | none → 10d | 95 → none | resources Claudio [22.9%] → none; baseline start 2000-05-04 16:12 → none; baseline finish 2000-05-12 16:12 → none |
| 99 | Liste des prestataires | 2000-05-22 16:12 A → 2008-04-17 (+2887d) | 2000-05-22 16:12 A → 2008-04-17 (+2887d) |  | 100% → 0% | none → 15d | 98 → none | baseline start 2000-05-12 16:12 → none; baseline finish 2000-05-12 16:12 → none |
| 100 | Présélection des progiciels | 2000-05-22 16:12 A → 2008-04-17 (+2887d) | 2000-05-23 16:12 A → 2008-04-18 (+2887d) | 0.88d → 1d | 100% → 0% | none → 14d | 99 → none | resources Claudio [57.1%] → none; baseline start 2000-05-12 16:12 → none; baseline finish 2000-05-15 16:12 → none |
| 101 | Liste des logiciels | 2000-05-23 16:12 A → 2008-04-17 (+2886d) | 2000-05-23 16:12 A → 2008-04-17 (+2886d) |  | 100% → 0% | none → 15d | 100 → none | baseline start 2000-05-15 16:12 → none; baseline finish 2000-05-15 16:12 → none |
| 102 | **Choix progiciels** | 2000-05-23 16:12 A → 2008-04-17 (+2886d) | 2000-05-26 14:12 A → 2008-04-18 (+2884d) | 2.38d → 1d | 100% → 0% | none → 14d |  | baseline start 2000-05-15 16:12 → none; baseline finish 2000-05-17 14:12 → none |
| 103 | Réalisation d'un dossier de choix | 2000-05-23 16:12 A → 2008-04-17 (+2886d) | 2000-05-25 16:12 A → 2008-04-18 (+2885d) | 1.75d → 1d | 100% → 0% | none → 14d | 101 → none | resources Claudio [57.1%] → none; baseline start 2000-05-15 16:12 → none; baseline finish 2000-05-16 16:12 → none |
| 104 | Choix du progiciel | 2000-05-25 16:12 A → 2008-04-17 (+2884d) | 2000-05-26 09:12 A → 2008-04-17 (+2883d) | 0.25d → 0.5d | 100% → 0% | none → 14.5d | 103 → none | resources Claudio [50%]; Henri [55.6%]; Patrick [55.6%] → none; baseline start 2000-05-16 16:12 → none; baseline finish 2000-05-17 09:12 → none |
| 105 | Dossier de choix | 2000-05-26 09:12 A → 2008-04-17 (+2883d) | 2000-05-26 09:12 A → 2008-04-17 (+2883d) |  | 100% → 0% | none → 15d | 104 → none | baseline start 2000-05-17 09:12 → none; baseline finish 2000-05-17 09:12 → none |
| 106 | Passage de la commande | 2000-05-26 09:12 A → 2008-04-17 (+2883d) | 2000-05-26 14:12 A → 2008-04-17 (+2883d) | 0.38d → 0.5d | 100% → 0% | none → 14.5d | 105 → none | resources Henri [133.3%] → none; baseline start 2000-05-17 09:12 → none; baseline finish 2000-05-17 14:12 → none |
| 107 | Bon de commande | 2000-05-26 14:12 A → 2008-04-17 (+2883d) | 2000-05-26 14:12 A → 2008-04-17 (+2883d) |  | 100% → 0% | none → 15d | 106 → none | baseline start 2000-05-17 14:12 → none; baseline finish 2000-05-17 14:12 → none |
| 108 | **Mise en place** | 2000-05-26 09:12 A → 2008-04-17 (+2883d) | 2000-06-29 10:09 A → 2008-04-18 (+2850d) | 19.37d → 1d | 100% → 0% | none → 14d |  | baseline start 2000-05-17 09:12 → none; baseline finish 2000-06-19 15:09 → none |
| 109 | Commande des matériels | 2000-05-26 09:12 A → 2008-04-17 (+2883d) | 2000-05-29 09:12 A → 2008-04-17 (+2880d) | 0.88d → 0.5d | 100% → 0% | none → 14.5d | 105 → none | resources Claudio [57.1%] → none; baseline start 2000-05-17 09:12 → none; baseline finish 2000-05-17 14:12 → none |
| 110 | Bon de commande | 2000-05-29 09:12 A → 2008-04-17 (+2880d) | 2000-05-29 09:12 A → 2008-04-17 (+2880d) |  | 100% → 0% | none → 15d | 109 → none | baseline start 2000-05-17 14:12 → none; baseline finish 2000-05-17 14:12 → none |
| 111 | Vérification des matériels | 2000-05-29 09:12 A → 2008-04-17 (+2880d) | 2000-05-30 09:12 A → 2008-04-18 (+2880d) | 0.88d → 1d | 100% → 0% | none → 14d | 110 → none | resources Programmeur 1 [114.3%] → none; baseline start 2000-05-17 14:12 → none; baseline finish 2000-05-18 14:12 → none |
| 112 | PV de réception | 2000-05-30 09:12 A → 2008-04-17 (+2879d) | 2000-05-30 09:12 A → 2008-04-17 (+2879d) |  | 100% → 0% | none → 15d | 111 → none | baseline start 2000-05-18 14:12 → none; baseline finish 2000-05-18 14:12 → none |
| 113 | Installation des matériels | 2000-05-30 09:12 A → 2008-04-17 (+2879d) | 2000-06-16 09:27 A → 2008-04-18 (+2863d) | 0.88d → 1d | 100% → 0% | none → 14d | 112 → none | resources Programmeur 2 [114.2%] → none; baseline start 2000-05-18 14:12 → none; baseline finish 2000-06-05 14:27 → none |
| 114 | Installation du réseau | 2000-05-30 09:12 A → 2008-04-17 (+2879d) | 2000-05-31 09:27 A → 2008-04-18 (+2879d) | 0.88d → 1d | 100% → 0% | none → 14d | 112 → none | resources Claudio [114.3%] → none; baseline start 2000-05-18 14:12 → none; baseline finish 2000-05-22 14:27 → none |
| 115 | Partie matérielle installée | 2000-06-16 09:27 A → 2008-04-17 (+2862d) | 2000-06-16 09:27 A → 2008-04-17 (+2862d) |  | 100% → 0% | none → 15d | 114, 113 → none | baseline start 2000-06-05 14:27 → none; baseline finish 2000-06-05 14:27 → none |
| 116 | Installation des systèmes d'exploitation | 2000-06-16 09:27 A → 2008-04-17 (+2862d) | 2000-06-20 09:42 A → 2008-04-18 (+2859d) | 1.75d → 1d | 100% → 0% | none → 14d | 115 → none | resources Claudio [114.3%] → none; baseline start 2000-06-05 14:27 → none; baseline finish 2000-06-07 14:42 → none |
| 117 | Installation du progiciel de gestion des stocks | 2000-06-20 09:42 A → 2008-04-17 (+2858d) | 2000-06-29 10:09 A → 2008-04-17 (+2849d) | 0.12d → 0.5d | 100% → 0% | none → 14.5d | 116 → none | resources Programmeur 2 [400%] → none; baseline start 2000-06-07 14:42 → none; baseline finish 2000-06-19 15:09 → none |
| 118 | Partie logicielle installée | 2000-06-29 10:09 A → 2008-04-17 (+2849d) | 2000-06-29 10:09 A → 2008-04-17 (+2849d) |  | 100% → 0% | none → 15d | 117 → none | baseline start 2000-06-19 15:09 → none; baseline finish 2000-06-19 15:09 → none |
| 119 | **Paramétrage** | 2000-05-26 09:12 A → 2008-04-17 (+2883d) | 2000-06-29 09:42 A → 2008-04-24 (+2856d) | 19.31d → 5d | 100% → 0% | none → 10d |  | baseline start 2000-05-17 09:12 → none; baseline finish 2000-06-16 09:57 → none |
| 120 | Définition des paramètres | 2000-05-26 09:12 A → 2008-04-17 (+2883d) | 2000-05-30 09:12 A → 2008-04-21 (+2883d) | 1.75d → 2d | 100% → 0% | none → 13d | 105 → none | resources Patrick [28.6%] → none; baseline start 2000-05-17 09:12 → none; baseline finish 2000-05-19 09:12 → none |
| 121 | Paramétrage du logiciel | 2000-05-30 09:12 A → 2008-04-17 (+2879d) | 2000-06-29 09:42 A → 2008-04-24 (+2856d) | 13.33d → 5d | 100% → 0% | none → 10d | 120 → none | resources Programmeur 2 [101.1%]; Machine de développement 3 [114.3%] → none; baseline start 2000-05-19 09:12 → none; baseline finish 2000-06-16 09:57 → none |
| 122 | Logiciel paramétré | 2000-06-29 09:42 A → 2008-04-17 (+2849d) | 2000-06-29 09:42 A → 2008-04-17 (+2849d) |  | 100% → 0% | none → 15d | 121 → none | baseline start 2000-06-16 09:57 → none; baseline finish 2000-06-16 09:57 → none |
| 123 | **Tests** | 2000-05-26 09:12 A → 2008-04-17 (+2883d) | 2000-07-03 14:54 A → 2008-04-24 (+2852d) | 21.46d → 5d | 100% → 0% | none → 10d |  | baseline start 2000-05-17 09:12 → none; baseline finish 2000-06-20 15:09 → none |
| 124 | Définition des données de test | 2000-05-26 09:12 A → 2008-04-17 (+2883d) | 2000-05-30 09:12 A → 2008-04-18 (+2880d) | 1.75d → 1d | 100% → 0% | none → 14d | 105 → none | resources Patrick [57.1%] → none; baseline start 2000-05-17 09:12 → none; baseline finish 2000-05-19 09:12 → none |
| 125 | Tests du logiciel | 2000-06-29 09:42 A → 2008-04-17 (+2849d) | 2000-07-03 14:54 A → 2008-04-24 (+2852d) | 2.15d → 5d | 100% → 0% | none → 10d | 121, 124 → none | resources Patrick [47.1%]; Programmeur 2 [114.3%] → none; baseline start 2000-06-16 09:57 → none; baseline finish 2000-06-20 15:09 → none |
| 126 | Logiciel testé | 2000-07-03 14:54 A → 2008-04-17 (+2845d) | 2000-07-03 14:54 A → 2008-04-17 (+2845d) |  | 100% → 0% | none → 15d | 125 → none | baseline start 2000-06-20 15:09 → none; baseline finish 2000-06-20 15:09 → none |
| 127 | **Recette** | 2000-07-03 14:54 A → 2008-04-17 (+2845d) | 2000-07-11 14:54 A → 2008-04-24 (+2844d) | 5.25d → 5d | 100% → 0% | none → 10d |  | baseline start 2000-06-20 15:09 → none; baseline finish 2000-07-05 15:09 → none |
| 128 | Effectuer la recette | 2000-07-03 14:54 A → 2008-04-17 (+2845d) | 2000-07-04 14:54 A → 2008-04-18 (+2845d) | 0.88d → 1d | 100% → 0% | none → 14d | 126 → none | resources Henri [114.3%] → none; baseline start 2000-06-20 15:09 → none; baseline finish 2000-06-21 15:09 → none |
| 129 | PV de recette | 2000-07-04 14:54 A → 2008-04-17 (+2844d) | 2000-07-04 14:54 A → 2008-04-17 (+2844d) |  | 100% → 0% | none → 15d | 128 → none | baseline start 2000-06-21 15:09 → none; baseline finish 2000-06-21 15:09 → none |
| 130 | Mettre en production | 2000-07-04 14:54 A → 2008-04-17 (+2844d) | 2000-07-11 14:54 A → 2008-04-24 (+2844d) | 4.38d → 5d | 100% → 0% | none → 10d | 129 → none | resources Programmeur 2 [22.9%] → none; baseline start 2000-06-21 15:09 → none; baseline finish 2000-07-05 15:09 → none |
| 131 | Logiciel opérationnel | 2000-07-11 14:54 A → 2008-04-17 (+2837d) | 2000-07-11 14:54 A → 2008-04-17 (+2837d) |  | 100% → 0% | none → 15d | 130 → none | baseline start 2000-07-05 15:09 → none; baseline finish 2000-07-05 15:09 → none |
| 132 | **Formation** | 2000-07-11 14:54 → 2008-04-17 (+2837d) | 2000-07-26 17:54 → 2008-04-24 (+2829d) | 10d → 5d |  | 36.54d → 10d |  | baseline start 2000-07-05 15:09 → none; baseline finish 2000-07-19 15:09 → none |
| 133 | Former les utilisateurs | 2000-07-11 14:54 → 2008-04-17 (+2837d) | 2000-07-26 17:54 → 2008-04-24 (+2829d) | 10d → 5d |  | 36.54d → 10d | 131 → none | resources Programmeur 2 [40%] → none; baseline start 2000-07-05 15:09 → none; baseline finish 2000-07-19 15:09 → none |
| 134 | Utilisateurs formés | 2000-07-26 17:54 → 2008-04-17 (+2822d) | 2000-07-26 17:54 → 2008-04-17 (+2822d) |  |  | 36.54d → 15d | 133 → none | baseline start 2000-07-19 15:09 → none; baseline finish 2000-07-19 15:09 → none |
| 135 | **Etude du site internet** | 2000-05-18 16:12 A → 2008-04-17 (+2891d) | 2000-06-07 09:12 A → 2008-04-24 (+2878d) | 10.75d → 5d | 100% → 0% | none → 10d |  | baseline start 2000-05-04 16:12 → none; baseline finish 2000-05-24 09:12 → none |
| 136 | **Définition fonctions** | 2000-05-18 16:12 A → 2008-04-17 (+2891d) | 2000-05-25 16:12 A → 2008-04-22 (+2889d) | 4.38d → 3d | 100% → 0% | none → 12d |  | baseline start 2000-05-04 16:12 → none; baseline finish 2000-05-12 16:12 → none |
| 137 | Définir les fonctions | 2000-05-18 16:12 A → 2008-04-17 (+2891d) | 2000-05-23 16:12 A → 2008-04-22 (+2891d) | 2.62d → 3d | 100% → 0% | none → 12d | 95 → none | resources Henri [38.1%] → none; baseline start 2000-05-04 16:12 → none; baseline finish 2000-05-10 16:12 → none |
| 138 | Rédiger le cahier des charges | 2000-05-23 16:12 A → 2008-04-17 (+2886d) | 2000-05-25 16:12 A → 2008-04-21 (+2888d) | 1.75d → 2d | 100% → 0% | none → 13d | 137 → none | resources Henri [57.1%] → none; baseline start 2000-05-10 16:12 → none; baseline finish 2000-05-12 16:12 → none |
| 139 | Cahier des charges | 2000-05-25 16:12 A → 2008-04-17 (+2884d) | 2000-05-25 16:12 A → 2008-04-17 (+2884d) |  | 100% → 0% | none → 15d | 138 → none | baseline start 2000-05-12 16:12 → none; baseline finish 2000-05-12 16:12 → none |
| 140 | **Définition interfaces** | 2000-05-25 16:12 A → 2008-04-17 (+2884d) | 2000-06-07 09:12 A → 2008-04-24 (+2878d) | 6.38d → 5d | 100% → 0% | none → 10d |  | baseline start 2000-05-12 16:12 → none; baseline finish 2000-05-24 09:12 → none |

| ID | Task | Start | Finish | Duration | Complete | Total float | Predecessors | Other |
| --- | --- | --- | --- | --- | --- | --- | --- | --- |
| 141 | Faire les maquettes | 2000-05-25 16:12 A → 2008-04-17 (+2884d) | 2000-06-06 09:12 A → 2008-04-24 (+2879d) | 5.5d → 5d | 100% → 0% | none → 10d | 139 → none | resources François [90.9%] → none; baseline start 2000-05-12 16:12 → none; baseline finish 2000-05-23 09:12 → none |
| 142 | Valider les maquettes | 2000-06-06 09:12 A → 2008-04-17 (+2872d) | 2000-06-07 09:12 A → 2008-04-18 (+2872d) | 0.88d → 1d | 100% → 0% | none → 14d | 141 → none | resources Henri [57.1%] → none; baseline start 2000-05-23 09:12 → none; baseline finish 2000-05-24 09:12 → none |
| 143 | Maquettes validées | 2000-06-07 09:12 A → 2008-04-17 (+2871d) | 2000-06-07 09:12 A → 2008-04-17 (+2871d) |  | 100% → 0% | none → 15d | 142 → none | baseline start 2000-05-24 09:12 → none; baseline finish 2000-05-24 09:12 → none |
| 144 | **Mise en place du site** | 2000-06-07 09:12 A → 2008-04-17 (+2871d) | 2000-08-10 17:12 → 2008-05-12 (+2832d) | 40.13d → 15d | 20% → 0% |  |  | baseline start 2000-05-24 09:12 → none; baseline finish 2000-07-28 09:12 → none |
| 145 | **Développements** | 2000-06-07 09:12 A → 2008-04-17 (+2871d) | 2000-08-08 11:12 → 2008-05-12 (+2834d) | 37.88d → 15d | 22% → 0% |  |  | baseline start 2000-05-24 09:12 → none; baseline finish 2000-07-20 09:12 → none |
| 146 | Définir le nombre de prototypes | 2000-06-07 09:12 A → 2008-04-17 (+2871d) | 2000-06-08 10:12 → 2008-04-18 (+2871d) |  | 25% → 0% | 15.94d → 14d | 143 → none | resources Henri [50%]; François → none; baseline start 2000-05-24 09:12 → none; baseline finish 2000-05-25 09:12 → none |
| 147 | Réaliser le prototype (n fois) | 2000-06-08 09:12 A → 2008-04-17 (+2870d) | 2000-07-17 09:27 → 2008-05-12 (+2856d) | 14.97d → 15d | 14% → 0% | 10.47d → 0d | 146 → none | resources Infographiste [53.3%]; Programmeur 1; Machine de développement 1; Machine de développement 2 → none; baseline start 2000-05-25 09:12 → none; baseline finish 2000-06-29 09:27 → none |
| 148 | Tester le prototype (n fois) | 2000-06-21 09:12 A → 2008-04-17 (+2857d) | 2000-08-08 11:12 → 2008-05-12 (+2834d) | 23.47d → 15d | 25% → 0% | -3.75d → 0d | 146 → none | resources Infographiste [53.3%]; Programmeur 1; Machine de développement 1; Machine de développement 2 → none; baseline start 2000-06-07 09:12 → none; baseline finish 2000-07-20 09:12 → none |
| 149 | Définir les améliorations (n fois) | 2000-06-08 09:12 A → 2008-04-17 (+2870d) | 2000-07-17 14:57 → 2008-05-12 (+2856d) | 22.47d → 15d | 24% → 0% | 10.03d → 0d | 146 → none | resources Henri [53.3%]; Infographiste; Programmeur 2 → none; baseline start 2000-05-25 09:12 → none; baseline finish 2000-06-29 10:57 → none |
| 150 | Prototypes (n) | 2000-08-02 09:12 A → 2008-04-17 (+2815d) | 2000-08-02 09:12 → 2008-04-17 (+2815d) |  | 25% → 0% | 0d → 15d | 147, 148, 149 → none | baseline start 2000-07-20 09:12 → none; baseline finish 2000-07-20 09:12 → none |
| 151 | **Installation** | 2000-08-02 09:12 → 2008-04-17 (+2815d) | 2000-08-10 17:12 → 2008-04-21 (+2811d) | 6d → 2d |  | 0d → 13d |  | baseline start 2000-07-20 09:12 → none; baseline finish 2000-07-28 09:12 → none |
| 152 | Réaliser l'installation avec le prestataire d'accès | 2000-08-02 09:12 → 2008-04-17 (+2815d) | 2000-08-10 17:12 → 2008-04-21 (+2811d) | 6d → 2d |  | 0d → 13d | 150 → none | resources François [50%] → none; baseline start 2000-07-20 09:12 → none; baseline finish 2000-07-28 09:12 → none |
| 153 | Accès internet | 2000-08-10 17:12 → 2008-04-17 (+2807d) | 2000-08-10 17:12 → 2008-04-17 (+2807d) |  |  | 0d → 15d | 152 → none | baseline start 2000-07-28 09:12 → none; baseline finish 2000-07-28 09:12 → none |
| 154 | **Mise en production du site** | 2000-08-10 17:12 → 2008-04-17 (+2807d) | 2000-09-18 10:12 → 2008-05-02 (+2783d) | 23d → 10d |  | 0d → 5d |  | baseline start 2000-07-28 09:12 → none; baseline finish 2000-08-30 09:12 → none |
| 155 | **Test finaux** | 2000-08-10 17:12 → 2008-04-17 (+2807d) | 2000-08-28 11:12 → 2008-05-02 (+2804d) |  |  | 0d → 5d |  | baseline start 2000-07-28 09:12 → none; baseline finish 2000-08-11 09:12 → none |
| 156 | Faire les tests finaux | 2000-08-10 17:12 → 2008-04-17 (+2807d) | 2000-08-28 11:12 → 2008-05-02 (+2804d) |  |  | 0d → 5d | 153 → none | resources Programmeur 2 [80%]; Machine de développement 3 [80%] → none; baseline start 2000-07-28 09:12 → none; baseline finish 2000-08-11 09:12 → none |
| 157 | **Recette** | 2000-08-28 11:12 → 2008-04-17 (+2789d) | 2000-08-31 16:12 → 2008-04-22 (+2791d) |  |  | 0d → 12d |  | baseline start 2000-08-11 09:12 → none; baseline finish 2000-08-16 09:12 → none |
| 158 | Effectuer la recette | 2000-08-28 11:12 → 2008-04-17 (+2789d) | 2000-08-31 16:12 → 2008-04-22 (+2791d) |  |  | 0d → 12d | 156 → none | resources Henri [33.3%] → none; baseline start 2000-08-11 09:12 → none; baseline finish 2000-08-16 09:12 → none |
| 159 | PV de recette | 2000-08-31 16:12 → 2008-04-17 (+2786d) | 2000-08-31 16:12 → 2008-04-17 (+2786d) |  |  | 0d → 15d | 158 → none | baseline start 2000-08-16 09:12 → none; baseline finish 2000-08-16 09:12 → none |
| 160 | **Formation** | 2000-08-31 16:12 → 2008-04-17 (+2786d) | 2000-09-18 10:12 → 2008-04-24 (+2775d) | 10d → 5d |  | 0d → 10d |  | baseline start 2000-08-16 09:12 → none; baseline finish 2000-08-30 09:12 → none |
| 161 | Elaborer la doc utilisateurs | 2000-08-31 16:12 → 2008-04-17 (+2786d) | 2000-09-08 14:12 → 2008-04-24 (+2785d) |  |  | 0d → 10d | 159 → none | resources François [80%] → none; baseline start 2000-08-16 09:12 → none; baseline finish 2000-08-23 09:12 → none |
| 162 | Doc utilisateurs | 2000-09-08 14:12 → 2008-04-17 (+2778d) | 2000-09-08 14:12 → 2008-04-17 (+2778d) |  |  | 0d → 15d | 161 → none | baseline start 2000-08-23 09:12 → none; baseline finish 2000-08-23 09:12 → none |
| 163 | Former les utilisateurs | 2000-09-08 14:12 → 2008-04-17 (+2778d) | 2000-09-18 10:12 → 2008-04-24 (+2775d) |  |  | 0d → 10d | 162 → none | resources Programmeur 2 [80%] → none; baseline start 2000-08-23 09:12 → none; baseline finish 2000-08-30 09:12 → none |
| 164 | Utilisateurs formés | 2000-09-18 10:12 → 2008-04-17 (+2768d) | 2000-09-18 10:12 → 2008-04-17 (+2768d) |  |  | 0d → 15d | 163 → none | baseline start 2000-08-30 09:12 → none; baseline finish 2000-08-30 09:12 → none |
| 165 | **GESTION DU PROJET** | 2000-04-17 08:00 → 2008-04-17 (+2922d) | 2000-09-22 16:12 → 2008-04-18 (+2765d) | 96.9d → 1d |  | 0d → 14d |  | baseline start 2000-04-17 08:00 → none; baseline finish 2000-09-05 09:12 → none |
| 166 | **Piloter le projet** | 2000-04-17 08:00 → 2008-04-17 (+2922d) | 2000-09-19 11:12 → 2008-04-18 (+2768d) | 93.9d → 1d |  | 3d → 14d |  | baseline start 2000-04-17 08:00 → none; baseline finish 2000-08-31 09:12 → none |
| 167 | **Réalisation** | 2000-04-17 08:00 → 2008-04-17 (+2922d) | 2000-09-19 11:12 → 2008-04-18 (+2768d) | 93.9d → 1d |  | 3d → 14d |  | baseline start 2000-04-17 08:00 → none; baseline finish 2000-08-31 09:12 → none |
| 168 | **Piloter la réalisation du produit** | 2000-04-17 08:00 → 2008-04-17 (+2922d) | 2000-09-19 11:12 → 2008-04-18 (+2768d) | 93.9d → 1d |  | 3d → 14d |  | baseline start 2000-04-17 08:00 → none; baseline finish 2000-08-31 09:12 → none |
| 178 | Faire un bilan intermédiaire | 2000-05-15 09:00 → 2008-04-17 (+2894d) | 2000-05-16 10:00 → 2008-04-18 (+2894d) |  |  | 80.15d → 14d |  | constraint start no earlier than 2000-05-15 08:00 → none; resources Karen [50%]; Henri [50%] → none; baseline start 2000-05-15 08:00 → none; baseline finish 2000-05-15 17:00 → none |
| 179 | Bilan intermédiaire | 2000-05-16 10:00 → 2008-04-17 (+2893d) | 2000-05-16 10:00 → 2008-04-17 (+2893d) |  |  | 80.15d → 15d | 178 → none | baseline start 2000-05-15 17:00 → none; baseline finish 2000-05-15 17:00 → none |
| 180 | **Faire le bilan du projet** | 2000-09-18 10:12 → 2008-04-17 (+2768d) | 2000-09-22 16:12 → 2008-04-18 (+2765d) | 4d → 1d |  | 0d → 14d |  | baseline start 2000-08-30 09:12 → none; baseline finish 2000-09-05 09:12 → none |
| 181 | **Promotion** | 2000-09-18 10:12 → 2008-04-17 (+2768d) | 2000-09-19 11:12 → 2008-04-18 (+2768d) |  |  | 0d → 14d |  | baseline start 2000-08-30 09:12 → none; baseline finish 2000-08-31 09:12 → none |
| 182 | Vendre le projet | 2000-09-18 10:12 → 2008-04-17 (+2768d) | 2000-09-19 11:12 → 2008-04-18 (+2768d) |  |  | 0d → 14d | 164 → none | resources Karen [12.5%]; Henri [12.5%] → none; baseline start 2000-08-30 09:12 → none; baseline finish 2000-08-31 09:12 → none |
| 183 | Présentation de projet | 2000-09-19 11:12 → 2008-04-17 (+2767d) | 2000-09-19 11:12 → 2008-04-17 (+2767d) |  |  | 0d → 15d | 182 → none | baseline start 2000-08-31 09:12 → none; baseline finish 2000-08-31 09:12 → none |
| 184 | **Désengagement** | 2000-09-19 11:12 → 2008-04-17 (+2767d) | 2000-09-20 14:12 → 2008-04-18 (+2767d) |  |  | 0d → 14d |  | baseline start 2000-08-31 09:12 → none; baseline finish 2000-09-01 09:12 → none |
| 185 | Mettre un terme à l'engagement contractuel | 2000-09-19 11:12 → 2008-04-17 (+2767d) | 2000-09-20 14:12 → 2008-04-18 (+2767d) |  |  | 0d → 14d | 183 → none | resources Karen [6.2%]; Henri [6.2%] → none; baseline start 2000-08-31 09:12 → none; baseline finish 2000-09-01 09:12 → none |
| 186 | Note de désengagement | 2000-09-20 14:12 → 2008-04-17 (+2766d) | 2000-09-20 14:12 → 2008-04-17 (+2766d) |  |  | 0d → 15d | 185 → none | baseline start 2000-09-01 09:12 → none; baseline finish 2000-09-01 09:12 → none |
| 187 | **Capitalisation** | 2000-09-20 14:12 → 2008-04-17 (+2766d) | 2000-09-22 16:12 → 2008-04-18 (+2765d) | 2d → 1d |  | 0d → 14d |  | baseline start 2000-09-01 09:12 → none; baseline finish 2000-09-05 09:12 → none |
| 188 | Organiser les réunions de débriefing | 2000-09-20 14:12 → 2008-04-17 (+2766d) | 2000-09-21 15:12 → 2008-04-18 (+2766d) |  |  | 0d → 14d | 186 → none | resources Karen [50%]; Christophe; Claudio; François → none; baseline start 2000-09-01 09:12 → none; baseline finish 2000-09-04 09:12 → none |
| 189 | Bilan final de projet | 2000-09-21 15:12 → 2008-04-17 (+2765d) | 2000-09-21 15:12 → 2008-04-17 (+2765d) |  |  | 0d → 15d | 188 → none | baseline start 2000-09-04 09:12 → none; baseline finish 2000-09-04 09:12 → none |
| 190 | Archiver les dossiers du projet | 2000-09-21 15:12 → 2008-04-17 (+2765d) | 2000-09-22 16:12 → 2008-04-18 (+2765d) |  |  | 0d → 14d | 189 → none | resources Christophe [50%] → none; baseline start 2000-09-04 09:12 → none; baseline finish 2000-09-05 09:12 → none |
| 191 | Note d’archivage | 2000-09-22 16:12 → 2008-04-17 (+2764d) | 2000-09-22 16:12 → 2008-04-17 (+2764d) |  |  | 0d → 15d | 190 → none | baseline start 2000-09-05 09:12 → none; baseline finish 2000-09-05 09:12 → none |
| 192 | Fin du projet | 2000-09-22 16:12 → 2008-04-17 (+2764d) | 2000-09-22 16:12 → 2008-04-17 (+2764d) |  |  | 0d → 15d | 191 → none | baseline start 2000-09-05 09:12 → none; baseline finish 2000-09-05 09:12 → none |

## Version 7 (saved 2008-06-18, file 20-Planning détaillé pour fiche 26-Polo.mpp)

Last finish 2008-05-12 → 2008-08-11 (+91d).

Added:

| ID | Task | Duration | Start | Finish | Predecessors | Constraint | Resources |
| --- | --- | --- | --- | --- | --- | --- | --- |
| 169 | **Reporting CAPS** | 66.53d | 2008-04-17 09:00 | 2008-08-01 09:15 |  |  |  |
| 170 | Reporting CAPS 1 | 15min | 2008-04-17 09:00 | 2008-04-17 09:15 |  | start no earlier than 2008-04-17 08:00 |  |
| 171 | Reporting CAPS 2 | 15min | 2008-04-18 09:00 | 2008-04-18 09:15 |  | start no earlier than 2008-04-18 08:00 |  |
| 172 | Reporting CAPS 3 | 15min | 2008-04-21 09:00 | 2008-04-21 09:15 |  | start no earlier than 2008-04-19 08:00 |  |
| 173 | Reporting CAPS 4 | 15min | 2008-04-21 09:00 | 2008-04-21 09:15 |  | start no earlier than 2008-04-20 08:00 |  |
| 174 | Reporting CAPS 5 | 15min | 2008-04-21 09:00 | 2008-04-21 09:15 |  | start no earlier than 2008-04-21 08:00 |  |
| 175 | Reporting CAPS 6 | 15min | 2008-04-22 09:00 | 2008-04-22 09:15 |  | start no earlier than 2008-04-22 08:00 |  |
| 176 | Reporting CAPS 7 | 15min | 2008-04-23 09:00 | 2008-04-23 09:15 |  | start no earlier than 2008-04-23 08:00 |  |
| 177 | Reporting CAPS 8 | 15min | 2008-04-24 09:00 | 2008-04-24 09:15 |  | start no earlier than 2008-04-24 08:00 |  |
| 178 | Reporting CAPS 9 | 15min | 2008-04-25 09:00 | 2008-04-25 09:15 |  | start no earlier than 2008-04-25 08:00 |  |
| 179 | Reporting CAPS 10 | 15min | 2008-04-28 09:00 | 2008-04-28 09:15 |  | start no earlier than 2008-04-26 08:00 |  |
| 180 | Reporting CAPS 11 | 15min | 2008-04-28 09:00 | 2008-04-28 09:15 |  | start no earlier than 2008-04-27 08:00 |  |
| 181 | Reporting CAPS 12 | 15min | 2008-04-28 09:00 | 2008-04-28 09:15 |  | start no earlier than 2008-04-28 08:00 |  |
| 182 | Reporting CAPS 13 | 15min | 2008-04-29 09:00 | 2008-04-29 09:15 |  | start no earlier than 2008-04-29 08:00 |  |
| 183 | Reporting CAPS 14 | 15min | 2008-04-30 09:00 | 2008-04-30 09:15 |  | start no earlier than 2008-04-30 08:00 |  |
| 184 | Reporting CAPS 15 | 15min | 2008-05-01 09:00 | 2008-05-01 09:15 |  | start no earlier than 2008-05-01 08:00 |  |
| 185 | Reporting CAPS 16 | 15min | 2008-05-02 09:00 | 2008-05-02 09:15 |  | start no earlier than 2008-05-02 08:00 |  |
| 186 | Reporting CAPS 17 | 15min | 2008-05-05 09:00 | 2008-05-05 09:15 |  | start no earlier than 2008-05-03 08:00 |  |
| 187 | Reporting CAPS 18 | 15min | 2008-05-05 09:00 | 2008-05-05 09:15 |  | start no earlier than 2008-05-04 08:00 |  |
| 188 | Reporting CAPS 19 | 15min | 2008-05-05 09:00 | 2008-05-05 09:15 |  | start no earlier than 2008-05-05 08:00 |  |
| 189 | Reporting CAPS 20 | 15min | 2008-05-06 09:00 | 2008-05-06 09:15 |  | start no earlier than 2008-05-06 08:00 |  |
| 190 | Reporting CAPS 21 | 15min | 2008-05-07 09:00 | 2008-05-07 09:15 |  | start no earlier than 2008-05-07 08:00 |  |
| 191 | Reporting CAPS 22 | 15min | 2008-05-08 09:00 | 2008-05-08 09:15 |  | start no earlier than 2008-05-08 08:00 |  |
| 192 | Reporting CAPS 23 | 15min | 2008-05-09 09:00 | 2008-05-09 09:15 |  | start no earlier than 2008-05-09 08:00 |  |
| 193 | Reporting CAPS 24 | 15min | 2008-05-12 09:00 | 2008-05-12 09:15 |  | start no earlier than 2008-05-10 08:00 |  |
| 194 | Reporting CAPS 25 | 15min | 2008-05-12 09:00 | 2008-05-12 09:15 |  | start no earlier than 2008-05-11 08:00 |  |
| 195 | Reporting CAPS 26 | 15min | 2008-05-12 09:00 | 2008-05-12 09:15 |  | start no earlier than 2008-05-12 08:00 |  |
| 196 | Reporting CAPS 27 | 15min | 2008-05-13 09:00 | 2008-05-13 09:15 |  | start no earlier than 2008-05-13 08:00 |  |
| 197 | Reporting CAPS 28 | 15min | 2008-05-14 09:00 | 2008-05-14 09:15 |  | start no earlier than 2008-05-14 08:00 |  |
| 198 | Reporting CAPS 29 | 15min | 2008-05-15 09:00 | 2008-05-15 09:15 |  | start no earlier than 2008-05-15 08:00 |  |
| 199 | Reporting CAPS 30 | 15min | 2008-05-16 09:00 | 2008-05-16 09:15 |  | start no earlier than 2008-05-16 08:00 |  |
| 200 | Reporting CAPS 31 | 15min | 2008-05-19 09:00 | 2008-05-19 09:15 |  | start no earlier than 2008-05-17 08:00 |  |
| 201 | Reporting CAPS 32 | 15min | 2008-05-19 09:00 | 2008-05-19 09:15 |  | start no earlier than 2008-05-18 08:00 |  |
| 202 | Reporting CAPS 33 | 15min | 2008-05-19 09:00 | 2008-05-19 09:15 |  | start no earlier than 2008-05-19 08:00 |  |
| 203 | Reporting CAPS 34 | 15min | 2008-05-20 09:00 | 2008-05-20 09:15 |  | start no earlier than 2008-05-20 08:00 |  |
| 204 | Reporting CAPS 35 | 15min | 2008-05-21 09:00 | 2008-05-21 09:15 |  | start no earlier than 2008-05-21 08:00 |  |
| 205 | Reporting CAPS 36 | 15min | 2008-05-22 09:00 | 2008-05-22 09:15 |  | start no earlier than 2008-05-22 08:00 |  |
| 206 | Reporting CAPS 37 | 15min | 2008-05-23 09:00 | 2008-05-23 09:15 |  | start no earlier than 2008-05-23 08:00 |  |
| 207 | Reporting CAPS 38 | 15min | 2008-05-26 09:00 | 2008-05-26 09:15 |  | start no earlier than 2008-05-24 08:00 |  |
| 208 | Reporting CAPS 39 | 15min | 2008-05-26 09:00 | 2008-05-26 09:15 |  | start no earlier than 2008-05-25 08:00 |  |
| 209 | Reporting CAPS 40 | 15min | 2008-05-26 09:00 | 2008-05-26 09:15 |  | start no earlier than 2008-05-26 08:00 |  |
| 210 | Reporting CAPS 41 | 15min | 2008-05-27 09:00 | 2008-05-27 09:15 |  | start no earlier than 2008-05-27 08:00 |  |
| 211 | Reporting CAPS 42 | 15min | 2008-05-28 09:00 | 2008-05-28 09:15 |  | start no earlier than 2008-05-28 08:00 |  |
| 212 | Reporting CAPS 43 | 15min | 2008-05-29 09:00 | 2008-05-29 09:15 |  | start no earlier than 2008-05-29 08:00 |  |
| 213 | Reporting CAPS 44 | 15min | 2008-05-30 09:00 | 2008-05-30 09:15 |  | start no earlier than 2008-05-30 08:00 |  |
| 214 | Reporting CAPS 45 | 15min | 2008-06-02 09:00 | 2008-06-02 09:15 |  | start no earlier than 2008-05-31 08:00 |  |
| 215 | Reporting CAPS 46 | 15min | 2008-06-02 09:00 | 2008-06-02 09:15 |  | start no earlier than 2008-06-01 08:00 |  |
| 216 | Reporting CAPS 47 | 15min | 2008-06-02 09:00 | 2008-06-02 09:15 |  | start no earlier than 2008-06-02 08:00 |  |
| 217 | Reporting CAPS 48 | 15min | 2008-06-03 09:00 | 2008-06-03 09:15 |  | start no earlier than 2008-06-03 08:00 |  |
| 218 | Reporting CAPS 49 | 15min | 2008-06-04 09:00 | 2008-06-04 09:15 |  | start no earlier than 2008-06-04 08:00 |  |
| 219 | Reporting CAPS 50 | 15min | 2008-06-05 09:00 | 2008-06-05 09:15 |  | start no earlier than 2008-06-05 08:00 |  |
| 220 | Reporting CAPS 51 | 15min | 2008-06-06 09:00 | 2008-06-06 09:15 |  | start no earlier than 2008-06-06 08:00 |  |
| 221 | Reporting CAPS 52 | 15min | 2008-06-09 09:00 | 2008-06-09 09:15 |  | start no earlier than 2008-06-07 08:00 |  |
| 222 | Reporting CAPS 53 | 15min | 2008-06-09 09:00 | 2008-06-09 09:15 |  | start no earlier than 2008-06-08 08:00 |  |
| 223 | Reporting CAPS 54 | 15min | 2008-06-09 09:00 | 2008-06-09 09:15 |  | start no earlier than 2008-06-09 08:00 |  |
| 224 | Reporting CAPS 55 | 15min | 2008-06-10 09:00 | 2008-06-10 09:15 |  | start no earlier than 2008-06-10 08:00 |  |
| 225 | Reporting CAPS 56 | 15min | 2008-06-11 09:00 | 2008-06-11 09:15 |  | start no earlier than 2008-06-11 08:00 |  |
| 226 | Reporting CAPS 57 | 15min | 2008-06-12 09:00 | 2008-06-12 09:15 |  | start no earlier than 2008-06-12 08:00 |  |
| 227 | Reporting CAPS 58 | 15min | 2008-06-13 09:00 | 2008-06-13 09:15 |  | start no earlier than 2008-06-13 08:00 |  |
| 228 | Reporting CAPS 59 | 15min | 2008-06-16 09:00 | 2008-06-16 09:15 |  | start no earlier than 2008-06-14 08:00 |  |
| 229 | Reporting CAPS 60 | 15min | 2008-06-16 09:00 | 2008-06-16 09:15 |  | start no earlier than 2008-06-15 08:00 |  |
| 230 | Reporting CAPS 61 | 15min | 2008-06-16 09:00 | 2008-06-16 09:15 |  | start no earlier than 2008-06-16 08:00 |  |
| 231 | Reporting CAPS 62 | 15min | 2008-06-17 09:00 | 2008-06-17 09:15 |  | start no earlier than 2008-06-17 08:00 |  |
| 232 | Reporting CAPS 63 | 15min | 2008-06-18 09:00 | 2008-06-18 09:15 |  | start no earlier than 2008-06-18 08:00 |  |
| 233 | Reporting CAPS 64 | 15min | 2008-06-19 09:00 | 2008-06-19 09:15 |  | start no earlier than 2008-06-19 08:00 |  |
| 234 | Reporting CAPS 65 | 15min | 2008-06-20 09:00 | 2008-06-20 09:15 |  | start no earlier than 2008-06-20 08:00 |  |
| 235 | Reporting CAPS 66 | 15min | 2008-06-23 09:00 | 2008-06-23 09:15 |  | start no earlier than 2008-06-21 08:00 |  |
| 236 | Reporting CAPS 67 | 15min | 2008-06-23 09:00 | 2008-06-23 09:15 |  | start no earlier than 2008-06-22 08:00 |  |
| 237 | Reporting CAPS 68 | 15min | 2008-06-23 09:00 | 2008-06-23 09:15 |  | start no earlier than 2008-06-23 08:00 |  |
| 238 | Reporting CAPS 69 | 15min | 2008-06-24 09:00 | 2008-06-24 09:15 |  | start no earlier than 2008-06-24 08:00 |  |
| 239 | Reporting CAPS 70 | 15min | 2008-06-25 09:00 | 2008-06-25 09:15 |  | start no earlier than 2008-06-25 08:00 |  |
| 240 | Reporting CAPS 71 | 15min | 2008-06-26 09:00 | 2008-06-26 09:15 |  | start no earlier than 2008-06-26 08:00 |  |
| 241 | Reporting CAPS 72 | 15min | 2008-06-27 09:00 | 2008-06-27 09:15 |  | start no earlier than 2008-06-27 08:00 |  |
| 242 | Reporting CAPS 73 | 15min | 2008-06-30 09:00 | 2008-06-30 09:15 |  | start no earlier than 2008-06-28 08:00 |  |
| 243 | Reporting CAPS 74 | 15min | 2008-06-30 09:00 | 2008-06-30 09:15 |  | start no earlier than 2008-06-29 08:00 |  |
| 244 | Reporting CAPS 75 | 15min | 2008-06-30 09:00 | 2008-06-30 09:15 |  | start no earlier than 2008-06-30 08:00 |  |
| 245 | Reporting CAPS 76 | 15min | 2008-07-01 09:00 | 2008-07-01 09:15 |  | start no earlier than 2008-07-01 08:00 |  |
| 246 | Reporting CAPS 77 | 15min | 2008-07-02 09:00 | 2008-07-02 09:15 |  | start no earlier than 2008-07-02 08:00 |  |
| 247 | Reporting CAPS 78 | 15min | 2008-07-03 09:00 | 2008-07-03 09:15 |  | start no earlier than 2008-07-03 08:00 |  |
| 248 | Reporting CAPS 79 | 15min | 2008-07-04 09:00 | 2008-07-04 09:15 |  | start no earlier than 2008-07-04 08:00 |  |
| 249 | Reporting CAPS 80 | 15min | 2008-07-07 09:00 | 2008-07-07 09:15 |  | start no earlier than 2008-07-05 08:00 |  |
| 250 | Reporting CAPS 81 | 15min | 2008-07-07 09:00 | 2008-07-07 09:15 |  | start no earlier than 2008-07-06 08:00 |  |
| 251 | Reporting CAPS 82 | 15min | 2008-07-07 09:00 | 2008-07-07 09:15 |  | start no earlier than 2008-07-07 08:00 |  |
| 252 | Reporting CAPS 83 | 15min | 2008-07-08 09:00 | 2008-07-08 09:15 |  | start no earlier than 2008-07-08 08:00 |  |
| 253 | Reporting CAPS 84 | 15min | 2008-07-09 09:00 | 2008-07-09 09:15 |  | start no earlier than 2008-07-09 08:00 |  |
| 254 | Reporting CAPS 85 | 15min | 2008-07-10 09:00 | 2008-07-10 09:15 |  | start no earlier than 2008-07-10 08:00 |  |
| 255 | Reporting CAPS 86 | 15min | 2008-07-11 09:00 | 2008-07-11 09:15 |  | start no earlier than 2008-07-11 08:00 |  |
| 256 | Reporting CAPS 87 | 15min | 2008-07-14 09:00 | 2008-07-14 09:15 |  | start no earlier than 2008-07-12 08:00 |  |
| 257 | Reporting CAPS 88 | 15min | 2008-07-14 09:00 | 2008-07-14 09:15 |  | start no earlier than 2008-07-13 08:00 |  |
| 258 | Reporting CAPS 89 | 15min | 2008-07-14 09:00 | 2008-07-14 09:15 |  | start no earlier than 2008-07-14 08:00 |  |
| 259 | Reporting CAPS 90 | 15min | 2008-07-15 09:00 | 2008-07-15 09:15 |  | start no earlier than 2008-07-15 08:00 |  |
| 260 | Reporting CAPS 91 | 15min | 2008-07-16 09:00 | 2008-07-16 09:15 |  | start no earlier than 2008-07-16 08:00 |  |
| 261 | Reporting CAPS 92 | 15min | 2008-07-17 09:00 | 2008-07-17 09:15 |  | start no earlier than 2008-07-17 08:00 |  |
| 262 | Reporting CAPS 93 | 15min | 2008-07-18 09:00 | 2008-07-18 09:15 |  | start no earlier than 2008-07-18 08:00 |  |
| 263 | Reporting CAPS 94 | 15min | 2008-07-21 09:00 | 2008-07-21 09:15 |  | start no earlier than 2008-07-19 08:00 |  |
| 264 | Reporting CAPS 95 | 15min | 2008-07-21 09:00 | 2008-07-21 09:15 |  | start no earlier than 2008-07-20 08:00 |  |
| 265 | Reporting CAPS 96 | 15min | 2008-07-21 09:00 | 2008-07-21 09:15 |  | start no earlier than 2008-07-21 08:00 |  |
| 266 | Reporting CAPS 97 | 15min | 2008-07-22 09:00 | 2008-07-22 09:15 |  | start no earlier than 2008-07-22 08:00 |  |
| 267 | Reporting CAPS 98 | 15min | 2008-07-23 09:00 | 2008-07-23 09:15 |  | start no earlier than 2008-07-23 08:00 |  |
| 268 | Reporting CAPS 99 | 15min | 2008-07-24 09:00 | 2008-07-24 09:15 |  | start no earlier than 2008-07-24 08:00 |  |
| 269 | Reporting CAPS 100 | 15min | 2008-07-25 09:00 | 2008-07-25 09:15 |  | start no earlier than 2008-07-25 08:00 |  |
| 270 | Reporting CAPS 101 | 15min | 2008-07-28 09:00 | 2008-07-28 09:15 |  | start no earlier than 2008-07-26 08:00 |  |
| 271 | Reporting CAPS 102 | 15min | 2008-07-28 09:00 | 2008-07-28 09:15 |  | start no earlier than 2008-07-27 08:00 |  |
| 272 | Reporting CAPS 103 | 15min | 2008-07-28 09:00 | 2008-07-28 09:15 |  | start no earlier than 2008-07-28 08:00 |  |
| 273 | Reporting CAPS 104 | 15min | 2008-07-29 09:00 | 2008-07-29 09:15 |  | start no earlier than 2008-07-29 08:00 |  |
| 274 | Reporting CAPS 105 | 15min | 2008-07-30 09:00 | 2008-07-30 09:15 |  | start no earlier than 2008-07-30 08:00 |  |
| 275 | Reporting CAPS 106 | 15min | 2008-07-31 09:00 | 2008-07-31 09:15 |  | start no earlier than 2008-07-31 08:00 |  |
| 276 | Reporting CAPS 107 | 15min | 2008-08-01 09:00 | 2008-08-01 09:15 |  | start no earlier than 2008-08-01 08:00 |  |
| 277 | **Reporting PO** | 62.19d | 2008-04-21 09:00 | 2008-07-29 09:30 |  |  |  |
| 278 | Reporting PO 1 | 30min | 2008-04-21 09:00 | 2008-04-21 09:30 |  | start no earlier than 2008-04-21 08:00 |  |
| 279 | Reporting PO 2 | 30min | 2008-04-22 09:00 | 2008-04-22 09:30 |  | start no earlier than 2008-04-22 08:00 |  |
| 280 | Reporting PO 3 | 30min | 2008-04-28 09:00 | 2008-04-28 09:30 |  | start no earlier than 2008-04-28 08:00 |  |
| 281 | Reporting PO 4 | 30min | 2008-04-29 09:00 | 2008-04-29 09:30 |  | start no earlier than 2008-04-29 08:00 |  |
| 282 | Reporting PO 5 | 30min | 2008-05-05 09:00 | 2008-05-05 09:30 |  | start no earlier than 2008-05-05 08:00 |  |
| 283 | Reporting PO 6 | 30min | 2008-05-06 09:00 | 2008-05-06 09:30 |  | start no earlier than 2008-05-06 08:00 |  |
| 284 | Reporting PO 7 | 30min | 2008-05-12 09:00 | 2008-05-12 09:30 |  | start no earlier than 2008-05-12 08:00 |  |
| 285 | Reporting PO 8 | 30min | 2008-05-13 09:00 | 2008-05-13 09:30 |  | start no earlier than 2008-05-13 08:00 |  |
| 286 | Reporting PO 9 | 30min | 2008-05-19 09:00 | 2008-05-19 09:30 |  | start no earlier than 2008-05-19 08:00 |  |
| 287 | Reporting PO 10 | 30min | 2008-05-20 09:00 | 2008-05-20 09:30 |  | start no earlier than 2008-05-20 08:00 |  |
| 288 | Reporting PO 11 | 30min | 2008-05-26 09:00 | 2008-05-26 09:30 |  | start no earlier than 2008-05-26 08:00 |  |
| 289 | Reporting PO 12 | 30min | 2008-05-27 09:00 | 2008-05-27 09:30 |  | start no earlier than 2008-05-27 08:00 |  |
| 290 | Reporting PO 13 | 30min | 2008-06-02 09:00 | 2008-06-02 09:30 |  | start no earlier than 2008-06-02 08:00 |  |
| 291 | Reporting PO 14 | 30min | 2008-06-03 09:00 | 2008-06-03 09:30 |  | start no earlier than 2008-06-03 08:00 |  |
| 292 | Reporting PO 15 | 30min | 2008-06-09 09:00 | 2008-06-09 09:30 |  | start no earlier than 2008-06-09 08:00 |  |
| 293 | Reporting PO 16 | 30min | 2008-06-10 09:00 | 2008-06-10 09:30 |  | start no earlier than 2008-06-10 08:00 |  |
| 294 | Reporting PO 17 | 30min | 2008-06-16 09:00 | 2008-06-16 09:30 |  | start no earlier than 2008-06-16 08:00 |  |
| 295 | Reporting PO 18 | 30min | 2008-06-17 09:00 | 2008-06-17 09:30 |  | start no earlier than 2008-06-17 08:00 |  |
| 296 | Reporting PO 19 | 30min | 2008-06-23 09:00 | 2008-06-23 09:30 |  | start no earlier than 2008-06-23 08:00 |  |
| 297 | Reporting PO 20 | 30min | 2008-06-24 09:00 | 2008-06-24 09:30 |  | start no earlier than 2008-06-24 08:00 |  |
| 298 | Reporting PO 21 | 30min | 2008-06-30 09:00 | 2008-06-30 09:30 |  | start no earlier than 2008-06-30 08:00 |  |
| 299 | Reporting PO 22 | 30min | 2008-07-01 09:00 | 2008-07-01 09:30 |  | start no earlier than 2008-07-01 08:00 |  |
| 300 | Reporting PO 23 | 30min | 2008-07-07 09:00 | 2008-07-07 09:30 |  | start no earlier than 2008-07-07 08:00 |  |
| 301 | Reporting PO 24 | 30min | 2008-07-08 09:00 | 2008-07-08 09:30 |  | start no earlier than 2008-07-08 08:00 |  |
| 302 | Reporting PO 25 | 30min | 2008-07-14 09:00 | 2008-07-14 09:30 |  | start no earlier than 2008-07-14 08:00 |  |
| 303 | Reporting PO 26 | 30min | 2008-07-15 09:00 | 2008-07-15 09:30 |  | start no earlier than 2008-07-15 08:00 |  |
| 304 | Reporting PO 27 | 30min | 2008-07-21 09:00 | 2008-07-21 09:30 |  | start no earlier than 2008-07-21 08:00 |  |
| 305 | Reporting PO 28 | 30min | 2008-07-22 09:00 | 2008-07-22 09:30 |  | start no earlier than 2008-07-22 08:00 |  |
| 306 | Reporting PO 29 | 30min | 2008-07-28 09:00 | 2008-07-28 09:30 |  | start no earlier than 2008-07-28 08:00 |  |
| 307 | Reporting PO 30 | 30min | 2008-07-29 09:00 | 2008-07-29 09:30 |  | start no earlier than 2008-07-29 08:00 |  |
| 308 | **Reporting commanditaire** | 61.28d | 2008-04-22 09:00 | 2008-07-29 09:15 |  |  |  |
| 309 | Reporting commanditaire 1 | 15min | 2008-04-22 09:00 | 2008-04-22 09:15 |  | start no earlier than 2008-04-22 08:00 |  |
| 310 | Reporting commanditaire 2 | 15min | 2008-04-29 09:00 | 2008-04-29 09:15 |  | start no earlier than 2008-04-29 08:00 |  |
| 311 | Reporting commanditaire 3 | 15min | 2008-05-06 09:00 | 2008-05-06 09:15 |  | start no earlier than 2008-05-06 08:00 |  |
| 312 | Reporting commanditaire 4 | 15min | 2008-05-13 09:00 | 2008-05-13 09:15 |  | start no earlier than 2008-05-13 08:00 |  |
| 313 | Reporting commanditaire 5 | 15min | 2008-05-20 09:00 | 2008-05-20 09:15 |  | start no earlier than 2008-05-20 08:00 |  |
| 314 | Reporting commanditaire 6 | 15min | 2008-05-27 09:00 | 2008-05-27 09:15 |  | start no earlier than 2008-05-27 08:00 |  |
| 315 | Reporting commanditaire 7 | 15min | 2008-06-03 09:00 | 2008-06-03 09:15 |  | start no earlier than 2008-06-03 08:00 |  |
| 316 | Reporting commanditaire 8 | 15min | 2008-06-10 09:00 | 2008-06-10 09:15 |  | start no earlier than 2008-06-10 08:00 |  |
| 317 | Reporting commanditaire 9 | 15min | 2008-06-17 09:00 | 2008-06-17 09:15 |  | start no earlier than 2008-06-17 08:00 |  |
| 318 | Reporting commanditaire 10 | 15min | 2008-06-24 09:00 | 2008-06-24 09:15 |  | start no earlier than 2008-06-24 08:00 |  |
| 319 | Reporting commanditaire 11 | 15min | 2008-07-01 09:00 | 2008-07-01 09:15 |  | start no earlier than 2008-07-01 08:00 |  |
| 320 | Reporting commanditaire 12 | 15min | 2008-07-08 09:00 | 2008-07-08 09:15 |  | start no earlier than 2008-07-08 08:00 |  |
| 321 | Reporting commanditaire 13 | 15min | 2008-07-15 09:00 | 2008-07-15 09:15 |  | start no earlier than 2008-07-15 08:00 |  |
| 322 | Reporting commanditaire 14 | 15min | 2008-07-22 09:00 | 2008-07-22 09:15 |  | start no earlier than 2008-07-22 08:00 |  |
| 323 | Reporting commanditaire 15 | 15min | 2008-07-29 09:00 | 2008-07-29 09:15 |  | start no earlier than 2008-07-29 08:00 |  |
| 324 | **Fiche de reporting** | 61.25d | 2008-04-21 08:00 | 2008-07-28 08:00 |  |  |  |
| 325 | Fiche de reporting 1 | 0d | 2008-04-21 08:00 | 2008-04-21 08:00 |  | start no earlier than 2008-04-21 08:00 |  |
| 326 | Fiche de reporting 2 | 0d | 2008-04-28 08:00 | 2008-04-28 08:00 |  | start no earlier than 2008-04-28 08:00 |  |
| 327 | Fiche de reporting 3 | 0d | 2008-05-05 08:00 | 2008-05-05 08:00 |  | start no earlier than 2008-05-05 08:00 |  |
| 328 | Fiche de reporting 4 | 0d | 2008-05-12 08:00 | 2008-05-12 08:00 |  | start no earlier than 2008-05-12 08:00 |  |
| 329 | Fiche de reporting 5 | 0d | 2008-05-19 08:00 | 2008-05-19 08:00 |  | start no earlier than 2008-05-19 08:00 |  |
| 330 | Fiche de reporting 6 | 0d | 2008-05-26 08:00 | 2008-05-26 08:00 |  | start no earlier than 2008-05-26 08:00 |  |
| 331 | Fiche de reporting 7 | 0d | 2008-06-02 08:00 | 2008-06-02 08:00 |  | start no earlier than 2008-06-02 08:00 |  |
| 332 | Fiche de reporting 8 | 0d | 2008-06-09 08:00 | 2008-06-09 08:00 |  | start no earlier than 2008-06-09 08:00 |  |
| 333 | Fiche de reporting 9 | 0d | 2008-06-16 08:00 | 2008-06-16 08:00 |  | start no earlier than 2008-06-16 08:00 |  |
| 334 | Fiche de reporting 10 | 0d | 2008-06-23 08:00 | 2008-06-23 08:00 |  | start no earlier than 2008-06-23 08:00 |  |
| 335 | Fiche de reporting 11 | 0d | 2008-06-30 08:00 | 2008-06-30 08:00 |  | start no earlier than 2008-06-30 08:00 |  |
| 336 | Fiche de reporting 12 | 0d | 2008-07-07 08:00 | 2008-07-07 08:00 |  | start no earlier than 2008-07-07 08:00 |  |
| 337 | Fiche de reporting 13 | 0d | 2008-07-14 08:00 | 2008-07-14 08:00 |  | start no earlier than 2008-07-14 08:00 |  |
| 338 | Fiche de reporting 14 | 0d | 2008-07-21 08:00 | 2008-07-21 08:00 |  | start no earlier than 2008-07-21 08:00 |  |
| 339 | Fiche de reporting 15 | 0d | 2008-07-28 08:00 | 2008-07-28 08:00 |  | start no earlier than 2008-07-28 08:00 |  |
| 340 | **Réunion comité de pilotage** | 57.88d | 2008-04-17 09:00 | 2008-07-18 10:00 |  |  |  |
| 341 | Réunion comité de pilotage 1 | 1d | 2008-04-17 09:00 | 2008-04-18 10:00 |  | start no earlier than 2008-04-17 08:00 |  |
| 342 | Réunion comité de pilotage 2 | 1d | 2008-05-19 09:00 | 2008-05-20 10:00 |  | start no earlier than 2008-05-17 08:00 |  |
| 343 | Réunion comité de pilotage 3 | 1d | 2008-06-17 09:00 | 2008-06-18 10:00 |  | start no earlier than 2008-06-17 08:00 |  |
| 344 | Réunion comité de pilotage 4 | 1d | 2008-07-17 09:00 | 2008-07-18 10:00 |  | start no earlier than 2008-07-17 08:00 |  |
| 345 | **Rapport Flash** | 56.88d | 2008-04-17 08:00 | 2008-07-17 08:00 |  |  |  |
| 346 | Rapport Flash 1 | 0d | 2008-04-17 08:00 | 2008-04-17 08:00 |  | start no earlier than 2008-04-17 08:00 |  |
| 347 | Rapport Flash 2 | 0d | 2008-05-17 08:00 | 2008-05-17 08:00 |  | start no earlier than 2008-05-17 08:00 |  |
| 348 | Rapport Flash 3 | 0d | 2008-06-17 08:00 | 2008-06-17 08:00 |  | start no earlier than 2008-06-17 08:00 |  |
| 349 | Rapport Flash 4 | 0d | 2008-07-17 08:00 | 2008-07-17 08:00 |  | start no earlier than 2008-07-17 08:00 |  |
| 350 | **Mettre à jour le planning** | 61.38d | 2008-04-21 09:00 | 2008-07-28 10:00 |  |  |  |
| 351 | Mettre à jour le planning 1 | 1h | 2008-04-21 09:00 | 2008-04-21 10:00 |  | start no earlier than 2008-04-21 08:00 |  |
| 352 | Mettre à jour le planning 2 | 1h | 2008-04-28 09:00 | 2008-04-28 10:00 |  | start no earlier than 2008-04-28 08:00 |  |
| 353 | Mettre à jour le planning 3 | 1h | 2008-05-05 09:00 | 2008-05-05 10:00 |  | start no earlier than 2008-05-05 08:00 |  |
| 354 | Mettre à jour le planning 4 | 1h | 2008-05-12 09:00 | 2008-05-12 10:00 |  | start no earlier than 2008-05-12 08:00 |  |
| 355 | Mettre à jour le planning 5 | 1h | 2008-05-19 09:00 | 2008-05-19 10:00 |  | start no earlier than 2008-05-19 08:00 |  |
| 356 | Mettre à jour le planning 6 | 1h | 2008-05-26 09:00 | 2008-05-26 10:00 |  | start no earlier than 2008-05-26 08:00 |  |
| 357 | Mettre à jour le planning 7 | 1h | 2008-06-02 09:00 | 2008-06-02 10:00 |  | start no earlier than 2008-06-02 08:00 |  |
| 358 | Mettre à jour le planning 8 | 1h | 2008-06-09 09:00 | 2008-06-09 10:00 |  | start no earlier than 2008-06-09 08:00 |  |
| 359 | Mettre à jour le planning 9 | 1h | 2008-06-16 09:00 | 2008-06-16 10:00 |  | start no earlier than 2008-06-16 08:00 |  |
| 360 | Mettre à jour le planning 10 | 1h | 2008-06-23 09:00 | 2008-06-23 10:00 |  | start no earlier than 2008-06-23 08:00 |  |
| 361 | Mettre à jour le planning 11 | 1h | 2008-06-30 09:00 | 2008-06-30 10:00 |  | start no earlier than 2008-06-30 08:00 |  |
| 362 | Mettre à jour le planning 12 | 1h | 2008-07-07 09:00 | 2008-07-07 10:00 |  | start no earlier than 2008-07-07 08:00 |  |
| 363 | Mettre à jour le planning 13 | 1h | 2008-07-14 09:00 | 2008-07-14 10:00 |  | start no earlier than 2008-07-14 08:00 |  |
| 364 | Mettre à jour le planning 14 | 1h | 2008-07-21 09:00 | 2008-07-21 10:00 |  | start no earlier than 2008-07-21 08:00 |  |
| 365 | Mettre à jour le planning 15 | 1h | 2008-07-28 09:00 | 2008-07-28 10:00 |  | start no earlier than 2008-07-28 08:00 |  |
| 366 | **Planning détaillé de suivi** | 61.25d | 2008-04-21 08:00 | 2008-07-28 08:00 |  |  |  |
| 367 | Planning détaillé de suivi 1 | 0d | 2008-04-21 08:00 | 2008-04-21 08:00 |  | start no earlier than 2008-04-21 08:00 |  |
| 368 | Planning détaillé de suivi 2 | 0d | 2008-04-28 08:00 | 2008-04-28 08:00 |  | start no earlier than 2008-04-28 08:00 |  |
| 369 | Planning détaillé de suivi 3 | 0d | 2008-05-05 08:00 | 2008-05-05 08:00 |  | start no earlier than 2008-05-05 08:00 |  |
| 370 | Planning détaillé de suivi 4 | 0d | 2008-05-12 08:00 | 2008-05-12 08:00 |  | start no earlier than 2008-05-12 08:00 |  |
| 371 | Planning détaillé de suivi 5 | 0d | 2008-05-19 08:00 | 2008-05-19 08:00 |  | start no earlier than 2008-05-19 08:00 |  |
| 372 | Planning détaillé de suivi 6 | 0d | 2008-05-26 08:00 | 2008-05-26 08:00 |  | start no earlier than 2008-05-26 08:00 |  |
| 373 | Planning détaillé de suivi 7 | 0d | 2008-06-02 08:00 | 2008-06-02 08:00 |  | start no earlier than 2008-06-02 08:00 |  |
| 374 | Planning détaillé de suivi 8 | 0d | 2008-06-09 08:00 | 2008-06-09 08:00 |  | start no earlier than 2008-06-09 08:00 |  |
| 375 | Planning détaillé de suivi 9 | 0d | 2008-06-16 08:00 | 2008-06-16 08:00 |  | start no earlier than 2008-06-16 08:00 |  |
| 376 | Planning détaillé de suivi 10 | 0d | 2008-06-23 08:00 | 2008-06-23 08:00 |  | start no earlier than 2008-06-23 08:00 |  |
| 377 | Planning détaillé de suivi 11 | 0d | 2008-06-30 08:00 | 2008-06-30 08:00 |  | start no earlier than 2008-06-30 08:00 |  |
| 378 | Planning détaillé de suivi 12 | 0d | 2008-07-07 08:00 | 2008-07-07 08:00 |  | start no earlier than 2008-07-07 08:00 |  |
| 379 | Planning détaillé de suivi 13 | 0d | 2008-07-14 08:00 | 2008-07-14 08:00 |  | start no earlier than 2008-07-14 08:00 |  |
| 380 | Planning détaillé de suivi 14 | 0d | 2008-07-21 08:00 | 2008-07-21 08:00 |  | start no earlier than 2008-07-21 08:00 |  |
| 381 | Planning détaillé de suivi 15 | 0d | 2008-07-28 08:00 | 2008-07-28 08:00 |  | start no earlier than 2008-07-28 08:00 |  |
| 382 | **Mettre à jour la documentation** | 61.38d | 2008-04-21 09:00 | 2008-07-28 10:00 |  |  |  |
| 383 | Mettre à jour la documentation 1 | 1h | 2008-04-21 09:00 | 2008-04-21 10:00 |  | start no earlier than 2008-04-21 08:00 |  |
| 384 | Mettre à jour la documentation 2 | 1h | 2008-04-28 09:00 | 2008-04-28 10:00 |  | start no earlier than 2008-04-28 08:00 |  |
| 385 | Mettre à jour la documentation 3 | 1h | 2008-05-05 09:00 | 2008-05-05 10:00 |  | start no earlier than 2008-05-05 08:00 |  |
| 386 | Mettre à jour la documentation 4 | 1h | 2008-05-12 09:00 | 2008-05-12 10:00 |  | start no earlier than 2008-05-12 08:00 |  |
| 387 | Mettre à jour la documentation 5 | 1h | 2008-05-19 09:00 | 2008-05-19 10:00 |  | start no earlier than 2008-05-19 08:00 |  |
| 388 | Mettre à jour la documentation 6 | 1h | 2008-05-26 09:00 | 2008-05-26 10:00 |  | start no earlier than 2008-05-26 08:00 |  |
| 389 | Mettre à jour la documentation 7 | 1h | 2008-06-02 09:00 | 2008-06-02 10:00 |  | start no earlier than 2008-06-02 08:00 |  |
| 390 | Mettre à jour la documentation 8 | 1h | 2008-06-09 09:00 | 2008-06-09 10:00 |  | start no earlier than 2008-06-09 08:00 |  |
| 391 | Mettre à jour la documentation 9 | 1h | 2008-06-16 09:00 | 2008-06-16 10:00 |  | start no earlier than 2008-06-16 08:00 |  |
| 392 | Mettre à jour la documentation 10 | 1h | 2008-06-23 09:00 | 2008-06-23 10:00 |  | start no earlier than 2008-06-23 08:00 |  |
| 393 | Mettre à jour la documentation 11 | 1h | 2008-06-30 09:00 | 2008-06-30 10:00 |  | start no earlier than 2008-06-30 08:00 |  |
| 394 | Mettre à jour la documentation 12 | 1h | 2008-07-07 09:00 | 2008-07-07 10:00 |  | start no earlier than 2008-07-07 08:00 |  |
| 395 | Mettre à jour la documentation 13 | 1h | 2008-07-14 09:00 | 2008-07-14 10:00 |  | start no earlier than 2008-07-14 08:00 |  |
| 396 | Mettre à jour la documentation 14 | 1h | 2008-07-21 09:00 | 2008-07-21 10:00 |  | start no earlier than 2008-07-21 08:00 |  |
| 397 | Mettre à jour la documentation 15 | 1h | 2008-07-28 09:00 | 2008-07-28 10:00 |  | start no earlier than 2008-07-28 08:00 |  |
| 400 | Préparer la communication presse | 5d | 2008-05-26 09:00 | 2008-06-02 16:00 |  | start no earlier than 2008-05-26 08:00 | Christophe [20%] |
| 401 | Envoyer communication presse | 1d | 2008-06-26 09:00 | 2008-06-27 10:00 |  | start no earlier than 2008-06-26 09:00 | Christophe [25%] |
| 402 | Communication presse | 0d | 2008-08-05 11:48 | 2008-08-05 11:48 | 164, 401 |  |  |
| 403 | Rédiger la communication clients | 1d | 2008-06-26 09:00 | 2008-06-27 10:00 |  | start no earlier than 2008-06-26 09:00 | Henri [50%] |
| 404 | Envoyer la communication clients | 1d | 2008-08-05 11:48 | 2008-08-06 14:48 | 164 |  | Henri |
| 405 | Communication clients | 0d | 2008-08-06 14:48 | 2008-08-06 14:48 | 404 |  |  |

Removed: 169 Faire les réunions de comité de pilotage; 170 Rapport flash; 171 Faire les réunion avec l'équipe projet; 172 Vérifier le reporting; 173 Fiche de reporting (suite); 174 Mettre à jour la planning; 175 Planning détaillé (suite); 176 Mettre à jour la documentation; 177 œuvre en œuvre la communication

Changed:

| ID | Task | Start | Finish | Duration | Total float | Predecessors | Other |
| --- | --- | --- | --- | --- | --- | --- | --- |
| 1 | Début du projet | 2008-04-17 → 2008-04-17 08:00 | 2008-04-17 → 2008-04-17 08:00 |  | 15d → 72.6d |  |  |
| 2 | **GESTION DU PROJET** | 2008-04-17 → 2008-04-17 09:00 | 2008-04-18 → 2008-04-29 11:48 (+11d) | 1d → 7.35d | 14d → 0d |  |  |
| 3 | **Initialiser le projet** | 2008-04-17 → 2008-04-17 09:00 | 2008-04-17 → 2008-04-18 18:00 (+1d) | 0.25d → 1.75d | 14.75d → 0d |  |  |
| 4 | **Réception** | 2008-04-17 → 2008-04-17 09:00 | 2008-04-17 → 2008-04-17 15:00 | 0.25d → 0.5d | 14.75d → 0d |  |  |
| 5 | Réceptionner la demande de projet du commanditaire | 2008-04-17 → 2008-04-17 09:00 | 2008-04-17 → 2008-04-17 11:00 |  | 14.75d → 0d |  | resources none → Henri |
| 6 | Demande de projet du commanditaire | 2008-04-17 → 2008-04-17 11:00 | 2008-04-17 → 2008-04-17 11:00 |  | 15d → 0d | none → 5 |  |
| 7 | Examiner la demande du commanditaire | 2008-04-17 → 2008-04-17 11:00 | 2008-04-17 → 2008-04-17 15:00 |  | 14.75d → 0d | none → 6 | resources none → Karen |
| 8 | Réponse à la demande de projet | 2008-04-17 → 2008-04-17 15:00 | 2008-04-17 → 2008-04-17 15:00 |  | 15d → 72.1d | none → 7 |  |
| 9 | **Affectation** | 2008-04-17 → 2008-04-17 15:00 | 2008-04-17 → 2008-04-18 18:00 (+1d) | 0.25d → 1.25d | 14.75d → 0d |  |  |
| 10 | Officialiser la nomination du chef de projet | 2008-04-17 → 2008-04-17 15:00 | 2008-04-17 → 2008-04-17 17:00 |  | 14.75d → 0d | none → 7 | resources none → Karen [50%]; Henri |
| 11 | Note d’affectation du chef de projet | 2008-04-17 → 2008-04-18 18:00 (+1d) | 2008-04-17 → 2008-04-18 18:00 (+1d) |  | 15d → 0d | none → 10FS+1d |  |
| 12 | **Préparer le projet** | 2008-04-17 → 2008-04-21 09:00 (+4d) | 2008-04-18 → 2008-04-25 15:00 (+7d) | 1d → 4d | 14d → 0d |  |  |
| 13 | **Objet** | 2008-04-17 → 2008-04-21 09:00 (+4d) | 2008-04-17 → 2008-04-21 11:00 (+4d) |  | 14.75d → 0d |  |  |
| 14 | Définir l’objet précis du projet | 2008-04-17 → 2008-04-21 09:00 (+4d) | 2008-04-17 → 2008-04-21 11:00 (+4d) |  | 14.75d → 70.6d | none → 11 | resources none → Karen [50%] |
| 15 | Note de cadrage | 2008-04-17 → 2008-04-21 11:00 (+4d) | 2008-04-17 → 2008-04-21 11:00 (+4d) |  | 15d → 70.6d | none → 14 |  |
| 16 | Lister les motifs et définir le contexte | 2008-04-17 → 2008-04-21 09:00 (+4d) | 2008-04-17 → 2008-04-21 11:00 (+4d) |  | 14.75d → 0d | none → 11 | resources none → Karen [50%] |
| 17 | Note de cadrage (suite) | 2008-04-17 → 2008-04-21 11:00 (+4d) | 2008-04-17 → 2008-04-21 11:00 (+4d) |  | 15d → 0d | none → 16 |  |
| 18 | **Objectifs** | 2008-04-17 → 2008-04-22 14:00 (+5d) | 2008-04-17 → 2008-04-23 11:00 (+6d) | 0.25d → 0.75d | 14.75d → 0d |  |  |
| 19 | Définir les objectifs de qualité | 2008-04-17 → 2008-04-22 14:00 (+5d) | 2008-04-17 → 2008-04-22 16:00 (+5d) |  | 14.75d → 69.35d | none → 17FS+1d | resources none → Karen [150%]; Henri [150%] |
| 20 | Note de cadrage (suite) | 2008-04-17 → 2008-04-22 16:00 (+5d) | 2008-04-17 → 2008-04-22 16:00 (+5d) |  | 15d → 69.35d | none → 19 |  |
| 21 | Définir les objectifs de temps | 2008-04-17 → 2008-04-22 14:00 (+5d) | 2008-04-17 → 2008-04-22 16:00 (+5d) |  | 14.75d → 69.35d | none → 17FS+1d | resources none → Karen [50%] |
| 22 | macro-planning | 2008-04-17 → 2008-04-22 16:00 (+5d) | 2008-04-17 → 2008-04-22 16:00 (+5d) |  | 15d → 69.35d | none → 21 | was named Macro-planning |
| 23 | Définir les objectifs de charge et de coûts | 2008-04-17 → 2008-04-22 14:00 (+5d) | 2008-04-17 → 2008-04-22 16:00 (+5d) |  | 14.75d → 69.1d | none → 17FS+1d | resources none → Karen [50%] |
| 24 | macro-planning de charge | 2008-04-17 → 2008-04-22 16:00 (+5d) | 2008-04-17 → 2008-04-22 16:00 (+5d) |  | 15d → 69.35d | none → 23 | was named Macro-planning de charge |
| 25 | Budget prévisionnel | 2008-04-17 → 2008-04-22 16:00 (+5d) | 2008-04-17 → 2008-04-22 16:00 (+5d) |  | 15d → 69.35d | none → 23 |  |
| 26 | Définir les objectifs de communication | 2008-04-17 → 2008-04-22 16:00 (+5d) | 2008-04-17 → 2008-04-22 18:00 (+5d) |  | 14.75d → 69.1d | none → 23 | resources none → Christophe |
| 27 | Stratégie de communication | 2008-04-17 → 2008-04-22 18:00 (+5d) | 2008-04-17 → 2008-04-22 18:00 (+5d) |  | 15d → 69.1d | none → 26 |  |
| 28 | Définir les objectifs complémentaires | 2008-04-17 → 2008-04-22 14:00 (+5d) | 2008-04-17 → 2008-04-22 16:00 (+5d) |  | 14.75d → 0d | none → 17FS+1d | resources none → Karen [12.5%]; Henri [12.5%] |
| 29 | Note de cadrage (suite) | 2008-04-17 → 2008-04-22 16:00 (+5d) | 2008-04-17 → 2008-04-22 16:00 (+5d) |  | 15d → 0d | none → 28 |  |
| 30 | Préciser les contraintes sur objectifs | 2008-04-17 → 2008-04-22 16:00 (+5d) | 2008-04-17 → 2008-04-22 18:00 (+5d) |  | 14.75d → 0d | none → 29 | resources none → Karen [12.5%]; Henri [12.5%] |
| 31 | Note de cadrage (suite) | 2008-04-17 → 2008-04-22 18:00 (+5d) | 2008-04-17 → 2008-04-22 18:00 (+5d) |  | 15d → 0d | none → 30 |  |
| 32 | Vérifier l’adéquation entre les objectifs | 2008-04-17 → 2008-04-23 09:00 (+6d) | 2008-04-17 → 2008-04-23 11:00 (+6d) |  | 14.75d → 0d | none → 31 | resources none → Karen [50%] |
| 33 | Note de cadrage (suite) | 2008-04-17 → 2008-04-23 11:00 (+6d) | 2008-04-17 → 2008-04-23 11:00 (+6d) |  | 15d → 0d | none → 32 |  |
| 34 | **Domaine** | 2008-04-17 → 2008-04-23 11:00 (+6d) | 2008-04-18 → 2008-04-24 16:00 (+6d) | 1d → 1.25d | 14d → 0d |  |  |
| 35 | Identifier le périmètre et les acteurs | 2008-04-17 → 2008-04-23 11:00 (+6d) | 2008-04-18 → 2008-04-24 12:00 (+6d) |  | 14d → 0d | none → 33 | resources none → Karen [50%] |
| 36 | Fichier des acteurs | 2008-04-17 → 2008-04-24 12:00 (+7d) | 2008-04-17 → 2008-04-24 12:00 (+7d) |  | 15d → 67.85d | none → 35 |  |
| 37 | Définir la structure choisie pour la gestion du projet | 2008-04-17 → 2008-04-24 10:00 (+7d) | 2008-04-17 → 2008-04-24 12:00 (+7d) |  | 14.75d → 0d | none → 33, 35FF | resources none → Karen [25%] |
| 38 | Organigramme Projet | 2008-04-17 → 2008-04-24 12:00 (+7d) | 2008-04-17 → 2008-04-24 12:00 (+7d) |  | 15d → 0d | none → 37 |  |
| 39 | Définir les rôles des acteurs dans les structures projets | 2008-04-17 → 2008-04-24 14:00 (+7d) | 2008-04-17 → 2008-04-24 16:00 (+7d) |  | 14.75d → 0d | none → 38 | resources none → Karen [25%] |
| 40 | Fiche de poste | 2008-04-17 → 2008-04-24 16:00 (+7d) | 2008-04-17 → 2008-04-24 16:00 (+7d) |  | 15d → 67.6d | none → 39 |  |
| 41 | Carte des acteurs | 2008-04-17 → 2008-04-24 16:00 (+7d) | 2008-04-17 → 2008-04-24 16:00 (+7d) |  | 15d → 0d | none → 39 |  |
| 42 | **Risques** | 2008-04-17 → 2008-04-24 16:00 (+7d) | 2008-04-17 → 2008-04-24 18:00 (+7d) |  | 14.75d → 0d |  |  |
| 43 | Identifier, analyser et gérer les freins | 2008-04-17 → 2008-04-24 16:00 (+7d) | 2008-04-17 → 2008-04-24 18:00 (+7d) |  | 14.75d → 0d | none → 41 | resources none → Karen [50%]; Henri [50%] |
| 44 | Grille des freins | 2008-04-17 → 2008-04-24 18:00 (+7d) | 2008-04-17 → 2008-04-24 18:00 (+7d) |  | 15d → 0d | none → 43 |  |
| 45 | Identifier, analyser et gérer les facilitants | 2008-04-17 → 2008-04-24 16:00 (+7d) | 2008-04-17 → 2008-04-24 18:00 (+7d) |  | 14.75d → 67.35d | none → 41 | resources none → Karen [25%]; Henri [25%] |
| 46 | Grille des facilitants | 2008-04-17 → 2008-04-24 18:00 (+7d) | 2008-04-17 → 2008-04-24 18:00 (+7d) |  | 15d → 0d | none → 44 |  |
| 47 | **Méthode** | 2008-04-17 → 2008-04-24 16:00 (+7d) | 2008-04-17 → 2008-04-24 18:00 (+7d) |  | 14.75d → 67.35d |  |  |
| 48 | Choisir une méthode et structurer la réal. du produit | 2008-04-17 → 2008-04-24 16:00 (+7d) | 2008-04-17 → 2008-04-24 18:00 (+7d) |  | 14.75d → 67.35d | none → 41 | resources none → Claudio [50%]; François [50%] |
| 49 | Fiche méthode | 2008-04-17 → 2008-04-24 18:00 (+7d) | 2008-04-17 → 2008-04-24 18:00 (+7d) |  | 15d → 67.35d | none → 48 |  |
| 50 | **Communication** | 2008-04-17 → 2008-04-25 09:00 (+8d) | 2008-04-17 → 2008-04-25 11:00 (+8d) |  | 14.75d → 0d |  |  |
| 51 | Définir les axes, cibles et moyens de communication | 2008-04-17 → 2008-04-25 09:00 (+8d) | 2008-04-17 → 2008-04-25 11:00 (+8d) |  | 14.75d → 0d | none → 46 | resources none → Christophe |
| 52 | Charte graphique | 2008-04-17 → 2008-04-25 11:00 (+8d) | 2008-04-17 → 2008-04-25 11:00 (+8d) |  | 15d → 67.1d | none → 51 |  |
| 53 | Plan de communication | 2008-04-17 → 2008-04-25 11:00 (+8d) | 2008-04-17 → 2008-04-25 11:00 (+8d) |  | 15d → 0d | none → 51 |  |
| 54 | **Contractualisation** | 2008-04-17 → 2008-04-25 11:00 (+8d) | 2008-04-17 → 2008-04-25 15:00 (+8d) |  | 14.75d → 0d |  |  |
| 55 | Rédiger la note de cadrage | 2008-04-17 → 2008-04-25 11:00 (+8d) | 2008-04-17 → 2008-04-25 15:00 (+8d) |  | 14.75d → 0d | none → 53 | resources none → Henri [50%]; Karen [50%] |
| 56 | Note de cadrage (suite) | 2008-04-17 → 2008-04-25 15:00 (+8d) | 2008-04-17 → 2008-04-25 15:00 (+8d) |  | 15d → 0d | none → 55 |  |
| 57 | **Planifier le projet** | 2008-04-17 → 2008-04-25 15:00 (+8d) | 2008-04-17 → 2008-04-28 16:48 (+11d) | 0.25d → 1.1d | 14.75d → 0d |  |  |
| 58 | **Planification détallée** | 2008-04-17 → 2008-04-25 15:00 (+8d) | 2008-04-17 → 2008-04-28 10:48 (+11d) | 0.1d → 0.6d | 14.9d → 0d |  |  |
| 59 | Définir l’environnement de planification | 2008-04-17 → 2008-04-25 15:00 (+8d) | 2008-04-17 → 2008-04-25 15:48 (+8d) |  | 14.9d → 0d | none → 56 | resources none → Karen [62.5%] |
| 60 | Charte de planification | 2008-04-17 → 2008-04-25 15:48 (+8d) | 2008-04-17 → 2008-04-25 15:48 (+8d) |  | 15d → 0d | none → 59 |  |
| 61 | Ordonner la liste des tâches de fabrication du produit | 2008-04-17 → 2008-04-25 15:48 (+8d) | 2008-04-17 → 2008-04-25 16:36 (+8d) |  | 14.9d → 0d | none → 60 | resources none → Karen [125%]; Claudio [125%]; François [125%] |
| 62 | Organigramme des tâches | 2008-04-17 → 2008-04-25 16:36 (+8d) | 2008-04-17 → 2008-04-25 16:36 (+8d) |  | 15d → 0d | none → 61 |  |
| 63 | Affecter des durées ou des charges aux tâches | 2008-04-17 → 2008-04-25 16:36 (+8d) | 2008-04-17 → 2008-04-25 17:24 (+8d) |  | 14.9d → 0d | none → 62 | resources none → Karen [62.5%] |
| 64 | Planning détaillé | 2008-04-17 → 2008-04-25 17:24 (+8d) | 2008-04-17 → 2008-04-25 17:24 (+8d) |  | 15d → 0d | none → 63 |  |
| 65 | Définir les liens entre les tâches | 2008-04-17 → 2008-04-25 17:24 (+8d) | 2008-04-17 → 2008-04-28 09:12 (+11d) |  | 14.9d → 0d | none → 64 | resources none → Karen [31.2%] |
| 66 | Planning détaillé (suite) | 2008-04-17 → 2008-04-28 09:12 (+11d) | 2008-04-17 → 2008-04-28 09:12 (+11d) |  | 15d → 0d | none → 65 |  |
| 67 | Intégrer les tâches de gestion de projet | 2008-04-17 → 2008-04-28 09:12 (+11d) | 2008-04-17 → 2008-04-28 10:00 (+11d) |  | 14.9d → 0d | none → 66 | resources none → Karen [12.5%] |
| 68 | Planning détaillé (suite) | 2008-04-17 → 2008-04-28 10:00 (+11d) | 2008-04-17 → 2008-04-28 10:00 (+11d) |  | 15d → 0d | none → 67 |  |
| 69 | Affecter les ressources sur les tâches | 2008-04-17 → 2008-04-28 10:00 (+11d) | 2008-04-17 → 2008-04-28 10:48 (+11d) |  | 14.9d → 0d | none → 68 | resources none → Karen [250%] |
| 70 | Tableau des ressources | 2008-04-17 → 2008-04-28 10:48 (+11d) | 2008-04-17 → 2008-04-28 10:48 (+11d) |  | 15d → 0d | none → 69 |  |

| ID | Task | Start | Finish | Duration | Total float | Predecessors | Other |
| --- | --- | --- | --- | --- | --- | --- | --- |
| 71 | Planning détaillé (suite) | 2008-04-17 → 2008-04-28 10:48 (+11d) | 2008-04-17 → 2008-04-28 10:48 (+11d) |  | 15d → 0d | none → 70 |  |
| 72 | **Validation** | 2008-04-17 → 2008-04-28 10:48 (+11d) | 2008-04-17 → 2008-04-28 16:48 (+11d) | 0.25d → 0.5d | 14.75d → 0d |  |  |
| 73 | Optimiser le planning détaillé du prévu | 2008-04-17 → 2008-04-28 10:48 (+11d) | 2008-04-17 → 2008-04-28 14:48 (+11d) |  | 14.75d → 0d | none → 71 | resources none → Karen [50%]; Claudio [50%]; François [50%] |
| 74 | Planning détaillé (suite) | 2008-04-17 → 2008-04-28 14:48 (+11d) | 2008-04-17 → 2008-04-28 14:48 (+11d) |  | 15d → 0d | none → 73 |  |
| 75 | Valider, communiquer et enregistrer le planning | 2008-04-17 → 2008-04-28 14:48 (+11d) | 2008-04-17 → 2008-04-28 16:48 (+11d) |  | 14.75d → 0d | none → 74 | resources none → Karen [50%]; Christophe [50%] |
| 76 | Contrat de planning | 2008-04-17 → 2008-04-28 16:48 (+11d) | 2008-04-17 → 2008-04-28 16:48 (+11d) |  | 15d → 0d | none → 75 |  |
| 77 | **Piloter le projet** | 2008-04-17 → 2008-04-28 16:48 (+11d) | 2008-04-17 → 2008-04-29 11:48 (+12d) | 0.25d → 0.5d | 14.75d → 0d |  |  |
| 78 | **Lancement** | 2008-04-17 → 2008-04-28 16:48 (+11d) | 2008-04-17 → 2008-04-29 11:48 (+12d) | 0.25d → 0.5d | 14.75d → 0d |  |  |
| 79 | Lancer la réalisation | 2008-04-17 → 2008-04-28 16:48 (+11d) | 2008-04-17 → 2008-04-29 09:48 (+12d) |  | 14.75d → 0d | none → 76 | resources none → Karen [25%]; Christophe [25%] |
| 80 | Journal du projet | 2008-04-17 → 2008-04-29 09:48 (+12d) | 2008-04-17 → 2008-04-29 09:48 (+12d) |  | 15d → 0d | none → 79 |  |
| 81 | Fiche de reporting | 2008-04-17 → 2008-04-29 09:48 (+12d) | 2008-04-17 → 2008-04-29 09:48 (+12d) |  | 15d → 0d | none → 80 |  |
| 82 | Mettre en œuvre le plan de communication | 2008-04-17 → 2008-04-29 09:48 (+12d) | 2008-04-17 → 2008-04-29 11:48 (+12d) |  | 14.75d → 0d | none → 81 | resources none → Christophe |
| 83 | Plan de communication (suite) | 2008-04-17 → 2008-04-29 11:48 (+12d) | 2008-04-17 → 2008-04-29 11:48 (+12d) |  | 15d → 0d | none → 82 |  |
| 84 | **FABRICATION DU PRODUIT** | 2008-04-17 → 2008-04-29 11:48 (+12d) | 2008-05-12 → 2008-08-05 11:48 (+85d) | 15d → 61.25d |  |  |  |
| 85 | **Etude de la gestion des stocks** | 2008-04-17 → 2008-04-29 11:48 (+12d) | 2008-04-21 → 2008-05-05 17:48 (+14d) | 2d → 4d | 13d → 0d |  |  |
| 86 | **Etude opérationnelle** | 2008-04-17 → 2008-04-29 11:48 (+12d) | 2008-04-18 → 2008-05-01 15:48 (+13d) | 1d → 2d | 14d → 0d |  |  |
| 87 | Analyse de l'existant | 2008-04-17 → 2008-04-29 11:48 (+12d) | 2008-04-18 → 2008-04-30 14:48 (+12d) |  | 14d → 0d | none → 83 | resources none → Patrick [50%] |
| 88 | Feuille d'analyse | 2008-04-17 → 2008-04-30 14:48 (+13d) | 2008-04-17 → 2008-04-30 14:48 (+13d) |  | 15d → 0d | none → 87 |  |
| 89 | Recherche des améliorations | 2008-04-17 → 2008-04-30 14:48 (+13d) | 2008-04-18 → 2008-05-01 15:48 (+13d) |  | 14d → 0d | none → 88 | resources none → Patrick [50%] |
| 90 | Liste des améliorations | 2008-04-17 → 2008-05-01 15:48 (+14d) | 2008-04-17 → 2008-05-01 15:48 (+14d) |  | 15d → 0d | none → 89 |  |
| 91 | **Etude fonctionnelle** | 2008-04-17 → 2008-04-29 11:48 (+12d) | 2008-04-21 → 2008-05-05 17:48 (+14d) | 2d → 4d | 13d → 0d |  |  |
| 92 | Analyse de l'existant | 2008-04-17 → 2008-04-29 11:48 (+12d) | 2008-04-18 → 2008-04-30 14:48 (+12d) |  | 14d → 1d | none → 83 | resources none → Henri [50%] |
| 93 | Organigramme fonctionnel | 2008-04-17 → 2008-05-01 15:48 (+14d) | 2008-04-17 → 2008-05-01 15:48 (+14d) |  | 15d → 0d | none → 92, 90 |  |
| 94 | Rédaction du cahier des charges | 2008-04-17 → 2008-05-01 15:48 (+14d) | 2008-04-21 → 2008-05-05 17:48 (+14d) |  | 13d → 0d | none → 93 | resources none → Henri [50%] |
| 95 | Cahier des charges | 2008-04-17 → 2008-05-05 17:48 (+18d) | 2008-04-17 → 2008-05-05 17:48 (+18d) |  | 15d → 0d | none → 94 |  |
| 96 | **Mise en place de la gestion des stocks** | 2008-04-17 → 2008-05-05 17:48 (+18d) | 2008-04-24 → 2008-07-11 16:48 (+78d) | 5d → 42.75d | 10d → 18.5d |  |  |
| 97 | **Recherche progiciels** | 2008-04-17 → 2008-05-05 17:48 (+18d) | 2008-04-24 → 2008-05-14 16:48 (+20d) | 5d → 6d | 10d → 18.5d |  |  |
| 98 | Recherche des prestataires | 2008-04-17 → 2008-05-05 17:48 (+18d) | 2008-04-24 → 2008-05-13 15:48 (+19d) |  | 10d → 18.5d | none → 95 | resources none → Claudio [20%] |
| 99 | Liste des prestataires | 2008-04-17 → 2008-05-13 15:48 (+26d) | 2008-04-17 → 2008-05-13 15:48 (+26d) |  | 15d → 18.5d | none → 98 |  |
| 100 | Présélection des progiciels | 2008-04-17 → 2008-05-13 15:48 (+26d) | 2008-04-18 → 2008-05-14 16:48 (+26d) |  | 14d → 18.5d | none → 99 | resources none → Claudio [50%] |
| 101 | Liste des logiciels | 2008-04-17 → 2008-05-14 16:48 (+27d) | 2008-04-17 → 2008-05-14 16:48 (+27d) |  | 15d → 18.5d | none → 100 |  |
| 102 | **Choix progiciels** | 2008-04-17 → 2008-05-14 16:48 (+27d) | 2008-04-18 → 2008-05-16 16:48 (+28d) | 1d → 1.75d | 14d → 18.5d |  |  |
| 103 | Réalisation d'un dossier de choix | 2008-04-17 → 2008-05-14 16:48 (+27d) | 2008-04-18 → 2008-05-15 17:48 (+27d) |  | 14d → 18.5d | none → 101 | resources none → Claudio [50%] |
| 104 | Choix du progiciel | 2008-04-17 → 2008-05-15 17:48 (+28d) | 2008-04-17 → 2008-05-16 10:48 (+29d) | 0.5d → 0.25d | 14.5d → 18.5d | none → 103 | resources none → Claudio [50%]; Henri; Patrick |
| 105 | Dossier de choix | 2008-04-17 → 2008-05-16 10:48 (+29d) | 2008-04-17 → 2008-05-16 10:48 (+29d) |  | 15d → 18.5d | none → 104 |  |
| 106 | Passage de la commande | 2008-04-17 → 2008-05-16 10:48 (+29d) | 2008-04-17 → 2008-05-16 16:48 (+29d) |  | 14.5d → 53.5d | none → 105 | resources none → Henri |
| 107 | Bon de commande | 2008-04-17 → 2008-05-16 16:48 (+29d) | 2008-04-17 → 2008-05-16 16:48 (+29d) |  | 15d → 53.5d | none → 106 |  |
| 108 | **Mise en place** | 2008-04-17 → 2008-05-16 10:48 (+29d) | 2008-04-18 → 2008-05-27 15:48 (+39d) | 1d → 6.5d | 14d → 47.5d |  |  |
| 109 | Commande des matériels | 2008-04-17 → 2008-05-16 10:48 (+29d) | 2008-04-17 → 2008-05-16 16:48 (+29d) |  | 14.5d → 47.5d | none → 105 | resources none → Claudio [50%] |
| 110 | Bon de commande | 2008-04-17 → 2008-05-16 16:48 (+29d) | 2008-04-17 → 2008-05-16 16:48 (+29d) |  | 15d → 47.5d | none → 109 |  |
| 111 | Vérification des matériels | 2008-04-17 → 2008-05-16 16:48 (+29d) | 2008-04-18 → 2008-05-19 17:48 (+31d) |  | 14d → 47.5d | none → 110 | resources none → Programmeur 1 |
| 112 | PV de réception | 2008-04-17 → 2008-05-19 17:48 (+32d) | 2008-04-17 → 2008-05-19 17:48 (+32d) |  | 15d → 47.5d | none → 111 |  |
| 113 | Installation des matériels | 2008-04-17 → 2008-05-19 17:48 (+32d) | 2008-04-18 → 2008-05-21 09:48 (+33d) |  | 14d → 48.5d | none → 112 | resources none → Programmeur 2 |
| 114 | Installation du réseau | 2008-04-17 → 2008-05-19 17:48 (+32d) | 2008-04-18 → 2008-05-22 10:48 (+34d) | 1d → 2d | 14d → 47.5d | none → 112 | resources none → Claudio |
| 115 | Partie matérielle installée | 2008-04-17 → 2008-05-22 10:48 (+35d) | 2008-04-17 → 2008-05-22 10:48 (+35d) |  | 15d → 47.5d | none → 114, 113 |  |
| 116 | Installation des systèmes d'exploitation | 2008-04-17 → 2008-05-22 10:48 (+35d) | 2008-04-18 → 2008-05-26 14:48 (+38d) | 1d → 2d | 14d → 47.5d | none → 115 | resources none → Claudio |
| 117 | Installation du progiciel de gestion des stocks | 2008-04-17 → 2008-05-26 14:48 (+39d) | 2008-04-17 → 2008-05-27 15:48 (+40d) | 0.5d → 1d | 14.5d → 47.5d | none → 116 | resources none → Programmeur 2 [50%] |
| 118 | Partie logicielle installée | 2008-04-17 → 2008-05-27 15:48 (+40d) | 2008-04-17 → 2008-05-27 15:48 (+40d) |  | 15d → 47.5d | none → 117 |  |
| 119 | **Paramétrage** | 2008-04-17 → 2008-05-16 10:48 (+29d) | 2008-04-24 → 2008-06-04 17:48 (+41d) | 5d → 12d | 10d → 18.5d |  |  |
| 120 | Définition des paramètres | 2008-04-17 → 2008-05-16 10:48 (+29d) | 2008-04-21 → 2008-05-20 14:48 (+29d) |  | 13d → 18.5d | none → 105 | resources none → Patrick [25%] |
| 121 | Paramétrage du logiciel | 2008-04-17 → 2008-05-20 14:48 (+33d) | 2008-04-24 → 2008-06-04 17:48 (+41d) | 5d → 10d | 10d → 18.5d | none → 120 | resources none → Programmeur 2 [80%]; Machine de développement 3 |
| 122 | Logiciel paramétré | 2008-04-17 → 2008-06-04 17:48 (+48d) | 2008-04-17 → 2008-06-04 17:48 (+48d) |  | 15d → 42d | none → 121 |  |
| 123 | **Tests** | 2008-04-17 → 2008-05-16 10:48 (+29d) | 2008-04-24 → 2008-06-09 16:48 (+46d) | 5d → 14.5d | 10d → 18.5d |  |  |
| 124 | Définition des données de test | 2008-04-17 → 2008-05-16 10:48 (+29d) | 2008-04-18 → 2008-05-20 14:48 (+32d) | 1d → 2d | 14d → 28.5d | none → 105 | resources none → Patrick [50%] |
| 125 | Tests du logiciel | 2008-04-17 → 2008-06-04 17:48 (+48d) | 2008-04-24 → 2008-06-09 16:48 (+46d) | 5d → 2.5d | 10d → 18.5d | none → 121, 124 | resources none → Patrick [40%]; Programmeur 2 |
| 126 | Logiciel testé | 2008-04-17 → 2008-06-09 16:48 (+53d) | 2008-04-17 → 2008-06-09 16:48 (+53d) |  | 15d → 18.5d | none → 125 |  |
| 127 | **Recette** | 2008-04-17 → 2008-06-09 16:48 (+53d) | 2008-04-24 → 2008-06-26 11:48 (+63d) | 5d → 11d | 10d → 18.5d |  |  |
| 128 | Effectuer la recette | 2008-04-17 → 2008-06-09 16:48 (+53d) | 2008-04-18 → 2008-06-10 17:48 (+53d) |  | 14d → 18.5d | none → 126 | resources none → Henri |
| 129 | PV de recette | 2008-04-17 → 2008-06-10 17:48 (+54d) | 2008-04-17 → 2008-06-10 17:48 (+54d) |  | 15d → 18.5d | none → 128 |  |
| 130 | Mettre en production | 2008-04-17 → 2008-06-10 17:48 (+54d) | 2008-04-24 → 2008-06-26 11:48 (+63d) | 5d → 10d | 10d → 18.5d | none → 129 | resources none → Programmeur 2 [20%] |
| 131 | Logiciel opérationnel | 2008-04-17 → 2008-06-26 11:48 (+70d) | 2008-04-17 → 2008-06-26 11:48 (+70d) |  | 15d → 18.5d | none → 130 |  |
| 132 | **Formation** | 2008-04-17 → 2008-06-26 11:48 (+70d) | 2008-04-24 → 2008-07-11 16:48 (+78d) | 5d → 10d | 10d → 18.5d |  |  |
| 133 | Former les utilisateurs | 2008-04-17 → 2008-06-26 11:48 (+70d) | 2008-04-24 → 2008-07-11 16:48 (+78d) | 5d → 10d | 10d → 18.5d | none → 131 | resources none → Programmeur 2 [40%] |
| 134 | Utilisateurs formés | 2008-04-17 → 2008-07-11 16:48 (+85d) | 2008-04-17 → 2008-07-11 16:48 (+85d) |  | 15d → 18.5d | none → 133 |  |
| 135 | **Etude du site internet** | 2008-04-17 → 2008-05-05 17:48 (+18d) | 2008-04-24 → 2008-05-23 17:48 (+29d) | 5d → 12.25d | 10d → 0d |  |  |
| 136 | **Définition fonctions** | 2008-04-17 → 2008-05-05 17:48 (+18d) | 2008-04-22 → 2008-05-13 15:48 (+21d) | 3d → 5d | 12d → 0d |  |  |
| 137 | Définir les fonctions | 2008-04-17 → 2008-05-05 17:48 (+18d) | 2008-04-22 → 2008-05-09 11:48 (+17d) |  | 12d → 0d | none → 95 | resources none → Henri [33.3%] |
| 138 | Rédiger le cahier des charges | 2008-04-17 → 2008-05-09 11:48 (+22d) | 2008-04-21 → 2008-05-13 15:48 (+22d) |  | 13d → 0d | none → 137 | resources none → Henri [50%] |
| 139 | Cahier des charges | 2008-04-17 → 2008-05-13 15:48 (+26d) | 2008-04-17 → 2008-05-13 15:48 (+26d) |  | 15d → 0d | none → 138 |  |
| 140 | **Définition interfaces** | 2008-04-17 → 2008-05-13 15:48 (+26d) | 2008-04-24 → 2008-05-23 17:48 (+29d) | 5d → 7.25d | 10d → 0d |  |  |

| ID | Task | Start | Finish | Duration | Total float | Predecessors | Other |
| --- | --- | --- | --- | --- | --- | --- | --- |
| 141 | Faire les maquettes | 2008-04-17 → 2008-05-13 15:48 (+26d) | 2008-04-24 → 2008-05-22 16:48 (+28d) | 5d → 6.25d | 10d → 0d | none → 139 | resources none → François [80%] |
| 142 | Valider les maquettes | 2008-04-17 → 2008-05-22 16:48 (+35d) | 2008-04-18 → 2008-05-23 17:48 (+35d) |  | 14d → 0d | none → 141 | resources none → Henri [50%] |
| 143 | Maquettes validées | 2008-04-17 → 2008-05-23 17:48 (+36d) | 2008-04-17 → 2008-05-23 17:48 (+36d) |  | 15d → 0d | none → 142 |  |
| 144 | **Mise en place du site** | 2008-04-17 → 2008-05-23 17:48 (+36d) | 2008-05-12 → 2008-06-30 09:48 (+49d) | 15d → 22d |  |  |  |
| 145 | **Développements** | 2008-04-17 → 2008-05-23 17:48 (+36d) | 2008-05-12 → 2008-06-19 10:48 (+38d) | 15d → 16d |  |  |  |
| 146 | Définir le nombre de prototypes | 2008-04-17 → 2008-05-23 17:48 (+36d) | 2008-04-18 → 2008-05-27 09:48 (+39d) |  | 14d → 0d | none → 143 | resources none → Henri [50%]; François |
| 147 | Réaliser le prototype (n fois) | 2008-04-17 → 2008-05-27 09:48 (+40d) | 2008-05-12 → 2008-06-19 10:48 (+38d) |  |  | none → 146 | resources none → Infographiste [53.3%]; Programmeur 1; Machine de développement 1; Machine de développement 2 |
| 148 | Tester le prototype (n fois) | 2008-04-17 → 2008-05-27 09:48 (+40d) | 2008-05-12 → 2008-06-19 10:48 (+38d) |  |  | none → 146 | resources none → Infographiste [53.3%]; Programmeur 1; Machine de développement 1; Machine de développement 2 |
| 149 | Définir les améliorations (n fois) | 2008-04-17 → 2008-05-27 09:48 (+40d) | 2008-05-12 → 2008-06-19 10:48 (+38d) |  |  | none → 146 | resources none → Henri [53.3%]; Infographiste; Programmeur 2 |
| 150 | Prototypes (n) | 2008-04-17 → 2008-06-19 10:48 (+63d) | 2008-04-17 → 2008-06-19 10:48 (+63d) |  | 15d → 0d | none → 147, 148, 149 |  |
| 151 | **Installation** | 2008-04-17 → 2008-06-19 10:48 (+63d) | 2008-04-21 → 2008-06-30 09:48 (+70d) | 2d → 6d | 13d → 0d |  |  |
| 152 | Réaliser l'installation avec le prestataire d'accès | 2008-04-17 → 2008-06-19 10:48 (+63d) | 2008-04-21 → 2008-06-30 09:48 (+70d) | 2d → 6d | 13d → 0d | none → 150 | resources none → François [50%] |
| 153 | Accès internet | 2008-04-17 → 2008-06-30 09:48 (+74d) | 2008-04-17 → 2008-06-30 09:48 (+74d) |  | 15d → 0d | none → 152 |  |
| 154 | **Mise en production du site** | 2008-04-17 → 2008-06-30 09:48 (+74d) | 2008-05-02 → 2008-08-05 11:48 (+95d) | 10d → 23d | 5d → 0d |  |  |
| 155 | **Test finaux** | 2008-04-17 → 2008-06-30 09:48 (+74d) | 2008-05-02 → 2008-07-15 14:48 (+74d) |  | 5d → 0d |  |  |
| 156 | Faire les tests finaux | 2008-04-17 → 2008-06-30 09:48 (+74d) | 2008-05-02 → 2008-07-15 14:48 (+74d) |  | 5d → 0d | none → 153 | resources none → Programmeur 2 [80%]; Machine de développement 3 [80%] |
| 157 | **Recette** | 2008-04-17 → 2008-07-15 14:48 (+89d) | 2008-04-22 → 2008-07-18 17:48 (+87d) |  | 12d → 0d |  |  |
| 158 | Effectuer la recette | 2008-04-17 → 2008-07-15 14:48 (+89d) | 2008-04-22 → 2008-07-18 17:48 (+87d) |  | 12d → 0d | none → 156 | resources none → Henri [33.3%] |
| 159 | PV de recette | 2008-04-17 → 2008-07-18 17:48 (+92d) | 2008-04-17 → 2008-07-18 17:48 (+92d) |  | 15d → 0d | none → 158 |  |
| 160 | **Formation** | 2008-04-17 → 2008-07-18 17:48 (+92d) | 2008-04-24 → 2008-08-05 11:48 (+103d) | 5d → 10d | 10d → 0d |  |  |
| 161 | Elaborer la doc utilisateurs | 2008-04-17 → 2008-07-18 17:48 (+92d) | 2008-04-24 → 2008-07-28 15:48 (+95d) |  | 10d → 0d | none → 159 | resources none → François [80%] |
| 162 | Doc utilisateurs | 2008-04-17 → 2008-07-28 15:48 (+102d) | 2008-04-17 → 2008-07-28 15:48 (+102d) |  | 15d → 0d | none → 161 |  |
| 163 | Former les utilisateurs | 2008-04-17 → 2008-07-28 15:48 (+102d) | 2008-04-24 → 2008-08-05 11:48 (+103d) |  | 10d → 0d | none → 162 | resources none → Programmeur 2 [80%] |
| 164 | Utilisateurs formés | 2008-04-17 → 2008-08-05 11:48 (+110d) | 2008-04-17 → 2008-08-05 11:48 (+110d) |  | 15d → 0d | none → 163 |  |
| 165 | **GESTION DU PROJET** | 2008-04-17 → 2008-04-17 08:00 | 2008-04-18 → 2008-08-11 17:48 (+115d) | 1d → 72.6d | 14d → 0d |  |  |
| 166 | **Piloter le projet** | 2008-04-17 → 2008-04-17 08:00 | 2008-04-18 → 2008-08-06 14:48 (+110d) | 1d → 69.6d | 14d → 3d |  |  |
| 167 | **Réalisation** | 2008-04-17 → 2008-04-17 08:00 | 2008-04-18 → 2008-08-06 14:48 (+110d) | 1d → 69.6d | 14d → 3d |  |  |
| 168 | **Piloter la réalisation du produit** | 2008-04-17 → 2008-04-17 08:00 | 2008-04-18 → 2008-08-06 14:48 (+110d) | 1d → 69.6d | 14d → 3d |  |  |
| 398 | Faire un bilan intermédiaire | 2008-04-17 → 2008-05-15 09:00 (+28d) | 2008-04-18 → 2008-05-16 10:00 (+28d) |  | 14d → 54.1d |  | constraint none → start no earlier than 2008-05-15 09:00; resources none → Karen [50%]; Henri [50%] |
| 399 | Bilan intermédiaire | 2008-04-17 → 2008-05-16 10:00 (+29d) | 2008-04-17 → 2008-05-16 10:00 (+29d) |  | 15d → 54.1d | none → 398 |  |
| 406 | **Faire le bilan du projet** | 2008-04-17 → 2008-08-05 11:48 (+110d) | 2008-04-18 → 2008-08-11 17:48 (+115d) | 1d → 4d | 14d → 0d |  |  |
| 407 | **Promotion** | 2008-04-17 → 2008-08-05 11:48 (+110d) | 2008-04-18 → 2008-08-06 14:48 (+110d) |  | 14d → 0d |  |  |
| 408 | Vendre le projet | 2008-04-17 → 2008-08-05 11:48 (+110d) | 2008-04-18 → 2008-08-06 14:48 (+110d) |  | 14d → 0d | none → 164 | resources none → Karen [12.5%]; Henri [12.5%] |
| 409 | Présentation de projet | 2008-04-17 → 2008-08-06 14:48 (+111d) | 2008-04-17 → 2008-08-06 14:48 (+111d) |  | 15d → 0d | none → 408 |  |
| 410 | **Désengagement** | 2008-04-17 → 2008-08-06 14:48 (+111d) | 2008-04-18 → 2008-08-07 15:48 (+111d) |  | 14d → 0d |  |  |
| 411 | Mettre un terme à l'engagement contractuel | 2008-04-17 → 2008-08-06 14:48 (+111d) | 2008-04-18 → 2008-08-07 15:48 (+111d) |  | 14d → 0d | none → 409 | resources none → Karen [6.2%]; Henri [6.2%] |
| 412 | Note de désengagement | 2008-04-17 → 2008-08-07 15:48 (+112d) | 2008-04-17 → 2008-08-07 15:48 (+112d) |  | 15d → 0d | none → 411 |  |
| 413 | **Capitalisation** | 2008-04-17 → 2008-08-07 15:48 (+112d) | 2008-04-18 → 2008-08-11 17:48 (+115d) | 1d → 2d | 14d → 0d |  |  |
| 414 | Organiser les réunions de débriefing | 2008-04-17 → 2008-08-07 15:48 (+112d) | 2008-04-18 → 2008-08-08 16:48 (+112d) |  | 14d → 0d | none → 412 | resources none → Karen [50%]; Christophe; Claudio; François |
| 415 | Bilan final de projet | 2008-04-17 → 2008-08-08 16:48 (+113d) | 2008-04-17 → 2008-08-08 16:48 (+113d) |  | 15d → 0d | none → 414 |  |
| 416 | Archiver les dossiers du projet | 2008-04-17 → 2008-08-08 16:48 (+113d) | 2008-04-18 → 2008-08-11 17:48 (+115d) |  | 14d → 0d | none → 415 | resources none → Christophe [50%] |
| 417 | Note d’archivage | 2008-04-17 → 2008-08-11 17:48 (+116d) | 2008-04-17 → 2008-08-11 17:48 (+116d) |  | 15d → 0d | none → 416 |  |
| 418 | Fin du projet | 2008-04-17 → 2008-08-11 17:48 (+116d) | 2008-04-17 → 2008-08-11 17:48 (+116d) |  | 15d → 0d | none → 417 |  |
